# CKM Office Renovation

How a schedule from MS Project changed from version to version. A marks actual dates.

## Version 1 (saved 2018-01-08, file Advanced Tracking - Completed.mpp)

| ID | WBS | Task | Duration | Start | Finish | Predecessors | Total float | Constraint |
| --- | --- | --- | --- | --- | --- | --- | --- | --- |
| 1 | 1 | **Planning & Research** | 15.5d | 2018-05-07 | 2018-05-28 |  | 0.57d |  |
| 2 |  | Develop Requirements Documentation | 1d | 2018-05-07 | 2018-05-07 |  | 0.57d |  |
| 3 |  | Fit-Out Consultant Research | 2d | 2018-05-08 | 2018-05-09 | 2 | 0.57d |  |
| 4 |  | Telecommunications Consultant Research | 2d | 2018-05-10 | 2018-05-11 | 3 | 0.57d |  |
| 5 |  | IT Network Contractor Research | 2d | 2018-05-14 | 2018-05-15 | 4 | 0.57d |  |
| 6 |  | Building Contractors Research | 2d | 2018-05-16 | 2018-05-17 | 5 | 0.57d |  |
| 7 |  | Submit Requirements to Resources & Request Quotes | 1d | 2018-05-18 | 2018-05-18 | 6 | 0.57d |  |
| 8 |  | Quotes Received | 0.5d | 2018-05-28 | 2018-05-28 | 7FS+5d | 0.57d |  |
| 9 |  | Planning & Research Complete | 0d | 2018-05-28 | 2018-05-28 | 8 | 0.57d |  |
| 10 | 2 | **Management Approval** | 4.14d | 2018-05-28 | 2018-06-01 |  | 0.57d |  |
| 11 |  | Consolidate Quotes and develop proposal | 2d | 2018-05-28 | 2018-05-30 | 9 | 0.57d |  |
| 12 |  | Develop Project Plan & Durations | 2d | 2018-05-30 | 2018-06-01 | 11 | 0.57d |  |
| 13 |  | Submit Project Plan & Costs to Management | 1h | 2018-06-01 | 2018-06-01 | 12 | 0.57d |  |
| 14 |  | Management Approval Received | 0d | 2018-06-01 | 2018-06-01 | 13 | 0.57d |  |
| 15 | 3 | **Refit Office** | 27.36d | 2018-06-01 | 2018-07-10 |  | 0d |  |
| 16 |  | Appoint Resources | 1d | 2018-06-01 | 2018-06-04 | 14 | 0.57d |  |
| 17 |  | Staff Briefing | 1h | 2018-06-04 | 2018-06-04 | 16 | 0.57d |  |
| 18 | 3.3 | **Fit-Out Consultations** | 2.5d | 2018-06-04 | 2018-06-07 |  | 0.57d |  |
| 19 |  | Office Space / Structure Plan | 1d | 2018-06-04 | 2018-06-05 | 17 | 0.57d |  |
| 20 |  | Select & Order Carpet | 0.5d | 2018-06-05 | 2018-06-06 | 19 | 0.57d |  |
| 21 |  | Select & Order Paint | 0.5d | 2018-06-06 | 2018-06-06 | 20 | 0.57d |  |
| 22 |  | Select & Order Office Furniture | 0.5d | 2018-06-06 | 2018-06-07 | 21 | 0.57d |  |
| 23 | 3.4 | **Telecommuncations Consultations** | 2d | 2018-06-07 | 2018-06-11 |  | 0.57d |  |
| 24 |  | Design Telephone Access Points Map | 1d | 2018-06-07 | 2018-06-08 | 22 | 0.57d |  |
| 25 |  | Select & Order New PABX | 1d | 2018-06-08 | 2018-06-11 | 24 | 0.57d |  |
| 26 | 3.5 | **IT Networking Consultations** | 9.14d | 2018-06-11 | 2018-06-22 |  | 0.57d |  |
| 27 |  | Design Network Access Points Map | 2d | 2018-06-11 | 2018-06-13 | 25 | 0.57d |  |
| 28 |  | Select & Order New PCs | 1d | 2018-06-13 | 2018-06-14 | 27 | 0.57d |  |
| 29 |  | New PCs Arrive | 1h | 2018-06-21 | 2018-06-21 | 28FS+5d | 0.57d |  |
| 30 |  | Configure SOE on PCs | 1d | 2018-06-21 | 2018-06-22 | 29 | 0.57d |  |
| 31 | 3.6 | **Restructure Office** | 12d | 2018-06-23 | 2018-07-10 |  | 0d |  |
| 32 |  | Erect New Walls | 7h | 2018-06-23 | 2018-06-23 | 30 | 0d |  |
| 33 |  | Gyprock, Plaster & Finish | 14h | 2018-06-25 | 2018-06-29 | 32 | 0d |  |
| 34 |  | Install Network Points | 5h | 2018-07-02 | 2018-07-02 | 33FS+1d | 0.71d |  |
| 35 |  | Install Phone Connections | 2h | 2018-07-02 | 2018-07-02 | 34SS | 0.71d |  |
| 36 |  | Re-Paint | 1d | 2018-07-03 | 2018-07-05 | 35 | 0d |  |
| 37 |  | Carpet | 1d | 2018-07-06 | 2018-07-07 | 36FS+1d | 0d |  |
| 38 |  | Install New Furniture | 1d | 2018-07-07 | 2018-07-10 | 37 | 0d |  |
| 39 |  | Install New PCs | 1d | 2018-07-10 | 2018-07-10 | 38 | 0d |  |
| 40 |  | Refit Office Complete | 0d | 2018-07-10 | 2018-07-10 | 39 | 0d |  |
| 41 | 4 | **Office Move** | 5d | 2018-07-10 | 2018-07-17 |  | 0d |  |
| 42 |  | Order packing boxes | 1h | 2018-07-10 | 2018-07-10 | 38 | 0.86d |  |
| 43 |  | Staff Pack | 1d | 2018-07-11 | 2018-07-11 | 40, 42 | 0d |  |
| 44 |  | Staff Move | 3.57d | 2018-07-12 | 2018-07-17 | 43 | 0d |  |
| 45 |  | Office Move Complete | 0d | 2018-07-17 | 2018-07-17 | 44 | 0d | finish no later than 2018-07-20 |

## Version 2 (saved 2018-01-08, file Bar Styles - completed.mpp)

Last finish 2018-07-17 → 2018-07-03 (-14d).

Changed:

| ID | Task | Start | Finish | Duration | Total float | Predecessors | Other |
| --- | --- | --- | --- | --- | --- | --- | --- |
| 1 | **Planning & Research** |  |  |  | 0.57d → 0d |  | baseline start 2018-05-07 → none; baseline finish 2018-05-28 → none |
| 2 | Develop Requirements Documentation |  |  |  | 0.57d → 0d |  | resources Project Manager → none; baseline start 2018-05-07 → none; baseline finish 2018-05-07 → none |
| 3 | Fit-Out Consultant Research |  |  |  | 0.57d → 0d |  | resources Project Manager → none; baseline start 2018-05-08 → none; baseline finish 2018-05-09 → none |
| 4 | Telecommunications Consultant Research |  |  |  | 0.57d → 0d |  | resources Project Manager → none; baseline start 2018-05-10 → none; baseline finish 2018-05-11 → none |
| 5 | IT Network Contractor Research |  |  |  | 0.57d → 0d |  | resources Project Manager → none; baseline start 2018-05-14 → none; baseline finish 2018-05-15 → none |
| 6 | Building Contractors Research |  |  |  | 0.57d → 0d |  | resources Project Manager → none; baseline start 2018-05-16 → none; baseline finish 2018-05-17 → none |
| 7 | Submit Requirements to Resources & Request Quotes |  |  |  | 0.57d → 0d |  | resources Project Manager → none; baseline start 2018-05-18 → none; baseline finish 2018-05-18 → none |
| 8 | Quotes Received |  |  |  | 0.57d → 0d |  | resources Project Manager → none; baseline start 2018-05-28 → none; baseline finish 2018-05-28 → none |
| 9 | Planning & Research Complete |  |  |  | 0.57d → 0d |  | baseline start 2018-05-28 → none; baseline finish 2018-05-28 → none |
| 10 | **Management Approval** |  |  |  | 0.57d → 0d |  | baseline start 2018-05-28 → none; baseline finish 2018-06-01 → none |
| 11 | Consolidate Quotes and develop proposal |  |  |  | 0.57d → 0d |  | resources Project Manager → none; baseline start 2018-05-28 → none; baseline finish 2018-05-30 → none |
| 12 | Develop Project Plan & Durations |  |  |  | 0.57d → 0d |  | resources Project Manager → none; baseline start 2018-05-30 → none; baseline finish 2018-06-01 → none |
| 13 | Submit Project Plan & Costs to Management |  |  |  | 0.57d → 0d |  | resources Management; Project Manager → none; baseline start 2018-06-01 → none; baseline finish 2018-06-01 → none |
| 14 | Management Approval Received |  |  |  | 0.57d → 0d |  | baseline start 2018-06-01 → none; baseline finish 2018-06-01 → none |
| 15 | **Refit Office** |  | 2018-07-10 → 2018-06-29 (-11d) | 27.36d → 20.07d |  |  | baseline start 2018-06-01 → none; baseline finish 2018-07-10 → none |
| 16 | Appoint Resources |  |  |  | 0.57d → 0d |  | resources Project Manager → none; baseline start 2018-06-01 → none; baseline finish 2018-06-04 → none |
| 17 | Staff Briefing |  |  |  | 0.57d → 0d |  | resources Project Manager; Staff [700%] → none; baseline start 2018-06-04 → none; baseline finish 2018-06-04 → none |
| 18 | **Fit-Out Consultations** |  |  |  | 0.57d → 0d |  | baseline start 2018-06-04 → none; baseline finish 2018-06-07 → none |
| 19 | Office Space / Structure Plan |  |  |  | 0.57d → 0d |  | resources Fit-out Consultant; Project Manager → none; baseline start 2018-06-04 → none; baseline finish 2018-06-05 → none |
| 20 | Select & Order Carpet |  |  |  | 0.57d → 0d |  | resources Fit-out Consultant; Project Manager → none; baseline start 2018-06-05 → none; baseline finish 2018-06-06 → none |
| 21 | Select & Order Paint |  |  |  | 0.57d → 0d |  | resources Fit-out Consultant; Project Manager → none; baseline start 2018-06-06 → none; baseline finish 2018-06-06 → none |
| 22 | Select & Order Office Furniture |  |  |  | 0.57d → 0d |  | resources Fit-out Consultant; Project Manager → none; baseline start 2018-06-06 → none; baseline finish 2018-06-07 → none |
| 23 | **Telecommuncations Consultations** |  |  |  | 0.57d → 16.43d |  | baseline start 2018-06-07 → none; baseline finish 2018-06-11 → none |
| 24 | Design Telephone Access Points Map |  |  |  | 0.57d → 16.43d |  | resources Project Manager; Telecommunications consultant → none; baseline start 2018-06-07 → none; baseline finish 2018-06-08 → none |
| 25 | Select & Order New PABX |  |  |  | 0.57d → 16.43d |  | resources Project Manager → none; baseline start 2018-06-08 → none; baseline finish 2018-06-11 → none |
| 26 | **IT Networking Consultations** | 2018-06-11 → 2018-06-07 (-4d) | 2018-06-22 → 2018-06-19 (-3d) | 9.14d → 8.14d | 0.57d → 0d |  | baseline start 2018-06-11 → none; baseline finish 2018-06-22 → none |
| 27 | Design Network Access Points Map | 2018-06-11 → 2018-06-07 (-4d) | 2018-06-13 → 2018-06-08 (-5d) | 2d → 1d | 0.57d → 0d | 25 → 22 | resources IT Consultant; Project Manager → none; baseline start 2018-06-11 → none; baseline finish 2018-06-13 → none |
| 28 | Select & Order New PCs | 2018-06-13 → 2018-06-08 (-5d) | 2018-06-14 → 2018-06-11 (-3d) |  | 0.57d → 0d |  | resources Project Manager → none; baseline start 2018-06-13 → none; baseline finish 2018-06-14 → none |
| 29 | New PCs Arrive | 2018-06-21 → 2018-06-18 (-3d) | 2018-06-21 → 2018-06-18 (-3d) |  | 0.57d → 0d |  | resources Project Manager → none; baseline start 2018-06-21 → none; baseline finish 2018-06-21 → none |
| 30 | Configure SOE on PCs | 2018-06-21 → 2018-06-18 (-3d) | 2018-06-22 → 2018-06-19 (-3d) |  | 0.57d → 0d |  | resources IT Consultant → none; baseline start 2018-06-21 → none; baseline finish 2018-06-22 → none |
| 31 | **Restructure Office** | 2018-06-23 → 2018-06-19 (-4d) | 2018-07-10 → 2018-06-29 (-11d) | 12d → 8.29d |  |  | baseline start 2018-06-23 → none; baseline finish 2018-07-10 → none |
| 32 | Erect New Walls | 2018-06-23 → 2018-06-19 (-4d) | 2018-06-23 → 2018-06-20 (-3d) |  |  |  | resources Carpenter [200%] → none; baseline start 2018-06-23 → none; baseline finish 2018-06-23 → none |
| 33 | Gyprock, Plaster & Finish | 2018-06-25 → 2018-06-20 (-5d) | 2018-06-29 → 2018-06-21 (-8d) | 14h → 7h |  |  | resources Plasterer → none; baseline start 2018-06-25 → none; baseline finish 2018-06-29 → none |
| 34 | Install Network Points | 2018-07-02 → 2018-06-22 (-10d) | 2018-07-02 → 2018-06-25 (-7d) |  | 0.71d → 0d |  | resources IT Consultant → none; baseline start 2018-07-02 → none; baseline finish 2018-07-02 → none |
| 35 | Install Phone Connections | 2018-07-02 → 2018-06-22 (-10d) | 2018-07-02 → 2018-06-22 (-10d) |  | 0.71d → 0d |  | resources Telecommunications consultant → none; baseline start 2018-07-02 → none; baseline finish 2018-07-02 → none |
| 36 | Re-Paint | 2018-07-03 → 2018-06-22 (-11d) | 2018-07-05 → 2018-06-25 (-10d) |  |  |  | resources Painter; Paint [100 Litre] → none; baseline start 2018-07-03 → none; baseline finish 2018-07-05 → none |
| 37 | Carpet | 2018-07-06 → 2018-06-26 (-10d) | 2018-07-07 → 2018-06-27 (-10d) |  |  |  | resources Carpet Contractor; Carpet [100 Lin Metre] → none; baseline start 2018-07-06 → none; baseline finish 2018-07-07 → none |
| 38 | Install New Furniture | 2018-07-07 → 2018-06-27 (-10d) | 2018-07-10 → 2018-06-28 (-12d) |  |  |  | resources Labourer → none; baseline start 2018-07-07 → none; baseline finish 2018-07-10 → none |
| 39 | Install New PCs | 2018-07-10 → 2018-06-28 (-12d) | 2018-07-10 → 2018-06-29 (-11d) |  |  |  | resources IT Consultant → none; baseline start 2018-07-10 → none; baseline finish 2018-07-10 → none |
| 40 | Refit Office Complete | 2018-07-10 → 2018-06-29 (-11d) | 2018-07-10 → 2018-06-29 (-11d) |  |  |  | baseline start 2018-07-10 → none; baseline finish 2018-07-10 → none |
| 41 | **Office Move** | 2018-07-10 → 2018-06-28 (-12d) | 2018-07-17 → 2018-07-03 (-14d) | 5d → 3d |  |  | baseline start 2018-07-10 → none; baseline finish 2018-07-17 → none |
| 42 | Order packing boxes | 2018-07-10 → 2018-06-28 (-12d) | 2018-07-10 → 2018-06-28 (-12d) |  | 0.86d → none |  | resources Project Manager → none; baseline start 2018-07-10 → none; baseline finish 2018-07-10 → none |
| 43 | Staff Pack | 2018-07-11 → 2018-06-29 (-12d) | 2018-07-11 → 2018-07-02 (-9d) |  | 0d → none | 40, 42 → 40 | resources Project Manager; Staff [2000%] → none; baseline start 2018-07-11 → none; baseline finish 2018-07-11 → none |
| 44 | Staff Move | 2018-07-12 → 2018-07-02 (-10d) | 2018-07-17 → 2018-07-03 (-14d) | 3.57d → 1d | 0d → none |  | resources Staff [2000%]; Labourer → none; baseline start 2018-07-12 → none; baseline finish 2018-07-17 → none |
| 45 | Office Move Complete | 2018-07-17 → 2018-07-03 (-14d) | 2018-07-17 → 2018-07-03 (-14d) |  | 0d → none |  | constraint finish no later than 2018-07-20 → none; baseline start 2018-07-17 → none; baseline finish 2018-07-17 → none |

## Version 3 (saved 2018-01-08, file Entering Progress - completed.mpp)

Last finish 2018-07-03 → 2018-07-23 (+20d). Complete tasks 0 → 9.

Changed:

| ID | Task | Start | Finish | Duration | Complete | Total float | Predecessors | Other |
| --- | --- | --- | --- | --- | --- | --- | --- | --- |
| 1 | **Planning & Research** | 2018-05-07 A | 2018-05-28 A |  | 0% → 100% | 0d → none |  | baseline start none → 2018-05-07; baseline finish none → 2018-05-28 |
| 2 | Develop Requirements Documentation | 2018-05-07 A | 2018-05-07 A |  | 0% → 100% | 0d → none |  | resources none → Project Manager; baseline start none → 2018-05-07; baseline finish none → 2018-05-07 |
| 3 | Fit-Out Consultant Research | 2018-05-08 A | 2018-05-09 A |  | 0% → 100% | 0d → none |  | resources none → Project Manager; baseline start none → 2018-05-08; baseline finish none → 2018-05-09 |
| 4 | Telecommunications Consultant Research | 2018-05-10 A | 2018-05-11 A |  | 0% → 100% | 0d → none |  | resources none → Project Manager; baseline start none → 2018-05-10; baseline finish none → 2018-05-11 |
| 5 | IT Network Contractor Research | 2018-05-14 A | 2018-05-15 A |  | 0% → 100% | 0d → none |  | resources none → Project Manager; baseline start none → 2018-05-14; baseline finish none → 2018-05-15 |
| 6 | Building Contractors Research | 2018-05-16 A | 2018-05-17 A |  | 0% → 100% | 0d → none |  | resources none → Project Manager; baseline start none → 2018-05-16; baseline finish none → 2018-05-17 |
| 7 | Submit Requirements to Resources & Request Quotes | 2018-05-18 A | 2018-05-18 A |  | 0% → 100% | 0d → none |  | resources none → Project Manager; baseline start none → 2018-05-18; baseline finish none → 2018-05-18 |
| 8 | Quotes Received | 2018-05-28 A | 2018-05-28 A |  | 0% → 100% | 0d → none |  | resources none → Project Manager; baseline start none → 2018-05-28; baseline finish none → 2018-05-28 |
| 9 | Planning & Research Complete | 2018-05-28 A | 2018-05-28 A |  | 0% → 100% | 0d → none |  | baseline start none → 2018-05-28; baseline finish none → 2018-05-28 |
| 10 | **Management Approval** | 2018-05-28 A | 2018-06-01 → 2018-06-06 (+5d) | 4.14d → 6.64d | 0% → 48% | 0d → 2.07d |  | baseline start none → 2018-05-28; baseline finish none → 2018-06-06 |
| 11 | Consolidate Quotes and develop proposal | 2018-05-28 A | 2018-05-30 A |  | 0% → 100% | 0d → none |  | resources none → Project Manager; baseline start none → 2018-05-28; baseline finish none → 2018-05-30 |
| 12 | Develop Project Plan & Durations | 2018-05-30 → 2018-06-04 A (+5d) | 2018-06-01 → 2018-06-05 (+4d) |  |  | 0d → 2.07d |  | resources none → Project Manager; baseline start none → 2018-06-04; baseline finish none → 2018-06-05 |
| 13 | Submit Project Plan & Costs to Management | 2018-06-01 → 2018-06-06 (+5d) | 2018-06-01 → 2018-06-06 (+5d) |  |  | 0d → 2.07d |  | resources none → Management; Project Manager; baseline start none → 2018-06-06; baseline finish none → 2018-06-06 |
| 14 | Management Approval Received | 2018-06-01 → 2018-06-06 (+5d) | 2018-06-01 → 2018-06-06 (+5d) |  |  | 0d → 2.07d |  | baseline start none → 2018-06-06; baseline finish none → 2018-06-06 |
| 15 | **Refit Office** | 2018-06-01 → 2018-06-06 (+5d) | 2018-06-29 → 2018-07-16 (+17d) | 20.07d → 28.86d |  |  |  | baseline start none → 2018-06-06; baseline finish none → 2018-07-16 |
| 16 | Appoint Resources | 2018-06-01 → 2018-06-06 (+5d) | 2018-06-04 → 2018-06-07 (+3d) |  |  | 0d → 2.07d |  | resources none → Project Manager; baseline start none → 2018-06-06; baseline finish none → 2018-06-07 |
| 17 | Staff Briefing | 2018-06-04 → 2018-06-07 (+3d) | 2018-06-04 → 2018-06-07 (+3d) |  |  | 0d → 2.07d |  | resources none → Project Manager; Staff [700%]; baseline start none → 2018-06-07; baseline finish none → 2018-06-07 |
| 18 | **Fit-Out Consultations** | 2018-06-04 → 2018-06-07 (+3d) | 2018-06-07 → 2018-06-11 (+4d) |  |  | 0d → 2.07d |  | baseline start none → 2018-06-07; baseline finish none → 2018-06-11 |
| 19 | Office Space / Structure Plan | 2018-06-04 → 2018-06-07 (+3d) | 2018-06-05 → 2018-06-08 (+3d) |  |  | 0d → 2.07d |  | resources none → Fit-out Consultant; Project Manager; baseline start none → 2018-06-07; baseline finish none → 2018-06-08 |
| 20 | Select & Order Carpet | 2018-06-05 → 2018-06-08 (+3d) | 2018-06-06 → 2018-06-08 (+2d) |  |  | 0d → 2.07d |  | resources none → Fit-out Consultant; Project Manager; baseline start none → 2018-06-08; baseline finish none → 2018-06-08 |
| 21 | Select & Order Paint | 2018-06-06 → 2018-06-08 (+2d) | 2018-06-06 → 2018-06-11 (+5d) |  |  | 0d → 2.07d |  | resources none → Fit-out Consultant; Project Manager; baseline start none → 2018-06-08; baseline finish none → 2018-06-11 |
| 22 | Select & Order Office Furniture | 2018-06-06 → 2018-06-11 (+5d) | 2018-06-07 → 2018-06-11 (+4d) |  |  | 0d → 2.07d |  | resources none → Fit-out Consultant; Project Manager; baseline start none → 2018-06-11; baseline finish none → 2018-06-11 |
| 23 | **Telecommuncations Consultations** | 2018-06-07 → 2018-06-11 (+4d) | 2018-06-11 → 2018-06-13 (+2d) |  |  | 16.43d → 2.07d |  | baseline start none → 2018-06-11; baseline finish none → 2018-06-13 |
| 24 | Design Telephone Access Points Map | 2018-06-07 → 2018-06-11 (+4d) | 2018-06-08 → 2018-06-12 (+4d) |  |  | 16.43d → 2.07d |  | resources none → Project Manager; Telecommunications consultant; baseline start none → 2018-06-11; baseline finish none → 2018-06-12 |
| 25 | Select & Order New PABX | 2018-06-08 → 2018-06-12 (+4d) | 2018-06-11 → 2018-06-13 (+2d) |  |  | 16.43d → 2.07d |  | resources none → Project Manager; baseline start none → 2018-06-12; baseline finish none → 2018-06-13 |
| 26 | **IT Networking Consultations** | 2018-06-07 → 2018-06-13 (+6d) | 2018-06-19 → 2018-06-26 (+7d) | 8.14d → 9.14d |  | 0d → 2.07d |  | baseline start none → 2018-06-13; baseline finish none → 2018-06-26 |
| 27 | Design Network Access Points Map | 2018-06-07 → 2018-06-13 (+6d) | 2018-06-08 → 2018-06-15 (+7d) | 1d → 2d |  | 0d → 2.07d | 22 → 25 | resources none → IT Consultant; Project Manager; baseline start none → 2018-06-13; baseline finish none → 2018-06-15 |
| 28 | Select & Order New PCs | 2018-06-08 → 2018-06-15 (+7d) | 2018-06-11 → 2018-06-18 (+7d) |  |  | 0d → 2.07d |  | resources none → Project Manager; baseline start none → 2018-06-15; baseline finish none → 2018-06-18 |
| 29 | New PCs Arrive | 2018-06-18 → 2018-06-25 (+7d) | 2018-06-18 → 2018-06-25 (+7d) |  |  | 0d → 2.07d |  | resources none → Project Manager; baseline start none → 2018-06-25; baseline finish none → 2018-06-25 |
| 30 | Configure SOE on PCs | 2018-06-18 → 2018-06-25 (+7d) | 2018-06-19 → 2018-06-26 (+7d) |  |  | 0d → 2.07d |  | resources none → IT Consultant; baseline start none → 2018-06-25; baseline finish none → 2018-06-26 |
| 31 | **Restructure Office** | 2018-06-19 → 2018-06-27 (+8d) | 2018-06-29 → 2018-07-16 (+17d) | 8.29d → 14d |  |  |  | baseline start none → 2018-06-27; baseline finish none → 2018-07-16 |
| 32 | Erect New Walls | 2018-06-19 → 2018-06-27 (+8d) | 2018-06-20 → 2018-06-29 (+9d) |  |  | 0d → 1d |  | resources none → Carpenter [200%]; baseline start none → 2018-06-27; baseline finish none → 2018-06-29 |
| 33 | Gyprock, Plaster & Finish | 2018-06-20 → 2018-06-29 (+9d) | 2018-06-21 → 2018-07-03 (+12d) | 7h → 14h |  | 0d → 1d |  | resources none → Plasterer; baseline start none → 2018-06-29; baseline finish none → 2018-07-03 |
| 34 | Install Network Points | 2018-06-22 → 2018-07-04 (+12d) | 2018-06-25 → 2018-07-04 (+9d) |  |  | 0d → 2.71d |  | resources none → IT Consultant; baseline start none → 2018-07-04; baseline finish none → 2018-07-04 |
| 35 | Install Phone Connections | 2018-06-22 → 2018-07-04 (+12d) | 2018-06-22 → 2018-07-04 (+12d) |  |  | 0d → 2.71d |  | resources none → Telecommunications consultant; baseline start none → 2018-07-04; baseline finish none → 2018-07-04 |
| 36 | Re-Paint | 2018-06-22 → 2018-07-05 (+13d) | 2018-06-25 → 2018-07-07 (+12d) |  |  | 0d → 2d |  | resources none → Painter; Paint [100 Litre]; baseline start none → 2018-07-05; baseline finish none → 2018-07-07 |
| 37 | Carpet | 2018-06-26 → 2018-07-10 (+14d) | 2018-06-27 → 2018-07-12 (+15d) |  |  | 0d → 2d |  | resources none → Carpet Contractor; Carpet [100 Lin Metre]; baseline start none → 2018-07-10; baseline finish none → 2018-07-12 |
| 38 | Install New Furniture | 2018-06-27 → 2018-07-12 (+15d) | 2018-06-28 → 2018-07-14 (+16d) |  |  |  |  | resources none → Labourer; baseline start none → 2018-07-12; baseline finish none → 2018-07-14 |
| 39 | Install New PCs | 2018-06-28 → 2018-07-16 (+18d) | 2018-06-29 → 2018-07-16 (+17d) |  |  |  |  | resources none → IT Consultant; baseline start none → 2018-07-16; baseline finish none → 2018-07-16 |
| 40 | Refit Office Complete | 2018-06-29 → 2018-07-16 (+17d) | 2018-06-29 → 2018-07-16 (+17d) |  |  |  |  | baseline start none → 2018-07-16; baseline finish none → 2018-07-16 |
| 41 | **Office Move** | 2018-06-28 → 2018-07-16 (+18d) | 2018-07-03 → 2018-07-23 (+20d) | 3d → 5d |  |  |  | baseline start none → 2018-07-16; baseline finish none → 2018-07-23 |
| 42 | Order packing boxes | 2018-06-28 → 2018-07-16 (+18d) | 2018-06-28 → 2018-07-16 (+18d) |  |  | none → 0.86d |  | resources none → Project Manager; baseline start none → 2018-07-16; baseline finish none → 2018-07-16 |
| 43 | Staff Pack | 2018-06-29 → 2018-07-17 (+18d) | 2018-07-02 → 2018-07-17 (+15d) |  |  | none → 0d | 40 → 40, 42 | resources none → Project Manager; Staff [2000%]; baseline start none → 2018-07-17; baseline finish none → 2018-07-17 |
| 44 | Staff Move | 2018-07-02 → 2018-07-18 (+16d) | 2018-07-03 → 2018-07-23 (+20d) | 1d → 3.57d |  | none → 0d |  | resources none → Staff [2000%]; Labourer; baseline start none → 2018-07-18; baseline finish none → 2018-07-23 |
| 45 | Office Move Complete | 2018-07-03 → 2018-07-23 (+20d) | 2018-07-03 → 2018-07-23 (+20d) |  |  | none → 0d |  | constraint none → finish no later than 2018-07-23; baseline start none → 2018-07-23; baseline finish none → 2018-07-23 |

## Version 4 (saved 2018-01-08, file Filters completed.mpp)

Last finish 2018-07-23 → 2018-06-14 (-39d). Complete tasks 9 → 25.

Changed:

| ID | Task | Start | Finish | Duration | Complete | Total float | Predecessors | Other |
| --- | --- | --- | --- | --- | --- | --- | --- | --- |
| 1 | **Planning & Research** | 2018-05-07 A → 2018-05-07 09:00 A | 2018-05-28 A → 2018-05-17 12:00 A (-11d) | 15.5d → 8.43d |  |  |  | baseline start 2018-05-07 → 2011-04-04 09:00; baseline finish 2018-05-28 → 2011-04-14 12:00 |
| 2 | Develop Requirements Documentation | 2018-05-07 A → 2018-05-07 09:00 A | 2018-05-07 A → 2018-05-07 17:00 A |  |  |  |  | baseline start 2018-05-07 → 2011-04-04 09:00; baseline finish 2018-05-07 → 2011-04-04 17:00 |
| 3 | Fit-Out Consultant Research | 2018-05-08 A → 2018-05-08 09:00 A | 2018-05-09 A → 2018-05-08 12:30 A (-1d) | 2d → 0.5d |  |  |  | baseline start 2018-05-08 → 2011-04-05 09:00; baseline finish 2018-05-09 → 2011-04-05 12:30 |
| 4 | Telecommunications Consultant Research | 2018-05-10 A → 2018-05-08 12:30 A (-2d) | 2018-05-11 A → 2018-05-08 17:00 A (-3d) | 2d → 0.5d |  |  |  | baseline start 2018-05-10 → 2011-04-05 12:30; baseline finish 2018-05-11 → 2011-04-05 17:00 |
| 5 | IT Network Contractor Research | 2018-05-14 A → 2018-05-09 09:00 A (-5d) | 2018-05-15 A → 2018-05-09 12:30 A (-6d) | 2d → 0.5d |  |  |  | baseline start 2018-05-14 → 2011-04-06 09:00; baseline finish 2018-05-15 → 2011-04-06 12:30 |
| 6 | Building Contractors Research | 2018-05-16 A → 2018-05-09 12:30 A (-7d) | 2018-05-17 A → 2018-05-09 17:00 A (-8d) | 2d → 0.5d |  |  |  | baseline start 2018-05-16 → 2011-04-06 12:30; baseline finish 2018-05-17 → 2011-04-06 17:00 |
| 7 | Submit Requirements to Resources & Request Quotes | 2018-05-18 A → 2018-05-10 09:00 A (-8d) | 2018-05-18 A → 2018-05-10 11:00 A (-8d) | 1d → 2h |  |  |  | baseline start 2018-05-18 → 2011-04-07 09:00; baseline finish 2018-05-18 → 2011-04-07 11:00 |
| 8 | Quotes Received | 2018-05-28 A → 2018-05-17 11:00 A (-11d) | 2018-05-28 A → 2018-05-17 12:00 A (-11d) | 0.5d → 1h |  |  |  | baseline start 2018-05-28 → 2011-04-14 11:00; baseline finish 2018-05-28 → 2011-04-14 12:00 |
| 9 | Planning & Research Complete | 2018-05-28 A → 2018-05-17 12:00 A (-11d) | 2018-05-28 A → 2018-05-17 12:00 A (-11d) |  |  |  |  | baseline start 2018-05-28 → 2011-04-14 12:00; baseline finish 2018-05-28 → 2011-04-14 12:00 |
| 10 | **Management Approval** | 2018-05-28 A → 2018-05-17 12:00 A (-11d) | 2018-06-06 → 2018-05-21 10:30 A (-16d) | 6.64d → 1.79d | 48% → 100% | 2.07d → none |  | baseline start 2018-05-28 → 2011-04-14 12:00; baseline finish 2018-06-06 → 2011-04-15 15:00 |
| 11 | Consolidate Quotes and develop proposal | 2018-05-28 A → 2018-05-17 12:00 A (-11d) | 2018-05-30 A → 2018-05-18 16:30 A (-12d) | 2d → 1.5d |  |  |  | baseline start 2018-05-28 → 2011-04-14 12:00; baseline finish 2018-05-30 → 2011-04-15 12:00 |
| 12 | Develop Project Plan & Durations | 2018-06-04 A → 2018-05-18 16:30 A (-17d) | 2018-06-05 → 2018-05-21 09:30 A (-15d) | 2d → 1h | 0% → 100% | 2.07d → none |  | baseline start 2018-06-04 → 2011-04-15 12:00; baseline finish 2018-06-05 → 2011-04-15 13:00 |
| 13 | Submit Project Plan & Costs to Management | 2018-06-06 → 2018-05-21 09:30 A (-16d) | 2018-06-06 → 2018-05-21 10:30 A (-16d) |  | 0% → 100% | 2.07d → none |  | resources Management; Project Manager → Project Manager; Management; baseline start 2018-06-06 → 2011-04-15 14:00; baseline finish 2018-06-06 → 2011-04-15 15:00 |
| 14 | Management Approval Received | 2018-06-06 → 2018-05-21 10:30 A (-16d) | 2018-06-06 → 2018-05-21 10:30 A (-16d) |  | 0% → 100% | 2.07d → none |  | baseline start 2018-06-06 → 2011-04-15 15:00; baseline finish 2018-06-06 → 2011-04-15 15:00 |
| 15 | **Refit Office** | 2018-06-06 → 2018-05-21 10:30 A (-16d) | 2018-07-16 → 2018-06-11 09:00 (-35d) | 28.86d → 14.79d | 0% → 32% | 0d → 3d |  | baseline start 2018-06-06 → 2011-04-15 15:00; baseline finish 2018-07-16 → 2011-05-11 17:00 |
| 16 | Appoint Resources | 2018-06-06 → 2018-05-21 10:30 A (-16d) | 2018-06-07 → 2018-05-21 12:30 A (-17d) | 1d → 2h | 0% → 100% | 2.07d → none |  | baseline start 2018-06-06 → 2011-04-15 15:00; baseline finish 2018-06-07 → 2011-04-15 17:00 |
| 17 | Staff Briefing | 2018-06-07 → 2018-05-21 12:30 A (-17d) | 2018-06-07 → 2018-05-21 14:30 A (-17d) |  | 0% → 100% | 2.07d → none |  | baseline start 2018-06-07 → 2011-04-18 09:00; baseline finish 2018-06-07 → 2011-04-18 10:00 |
| 18 | **Fit-Out Consultations** | 2018-06-07 → 2018-05-21 14:30 A (-17d) | 2018-06-11 → 2018-05-22 13:00 A (-20d) | 2.5d → 0.93d | 0% → 100% | 2.07d → none |  | baseline start 2018-06-07 → 2011-04-18 10:00; baseline finish 2018-06-11 → 2011-04-19 09:30 |
| 19 | Office Space / Structure Plan | 2018-06-07 → 2018-05-21 14:30 A (-17d) | 2018-06-08 → 2018-05-22 10:00 A (-17d) | 1d → 0.5d | 0% → 100% | 2.07d → none |  | baseline start 2018-06-07 → 2011-04-18 10:00; baseline finish 2018-06-08 → 2011-04-18 14:30 |
| 20 | Select & Order Carpet | 2018-06-08 → 2018-05-22 10:00 A (-17d) | 2018-06-08 → 2018-05-22 11:00 A (-17d) | 0.5d → 1h | 0% → 100% | 2.07d → none |  | baseline start 2018-06-08 → 2011-04-18 14:30; baseline finish 2018-06-08 → 2011-04-18 15:30 |
| 21 | Select & Order Paint | 2018-06-08 → 2018-05-22 11:00 A (-17d) | 2018-06-11 → 2018-05-22 12:00 A (-20d) | 0.5d → 1h | 0% → 100% | 2.07d → none |  | baseline start 2018-06-08 → 2011-04-18 15:30; baseline finish 2018-06-11 → 2011-04-18 16:30 |
| 22 | Select & Order Office Furniture | 2018-06-11 → 2018-05-22 12:00 A (-20d) | 2018-06-11 → 2018-05-22 13:00 A (-20d) | 0.5d → 1h | 0% → 100% | 2.07d → none |  | baseline start 2018-06-11 → 2011-04-18 16:30; baseline finish 2018-06-11 → 2011-04-19 09:30 |
| 23 | **Telecommuncations Consultations** | 2018-06-11 → 2018-05-22 14:00 A (-20d) | 2018-06-13 → 2018-05-23 10:30 A (-21d) | 2d → 0.64d | 0% → 100% | 2.07d → none |  | baseline start 2018-06-11 → 2011-04-19 09:30; baseline finish 2018-06-13 → 2011-04-19 15:00 |
| 24 | Design Telephone Access Points Map | 2018-06-11 → 2018-05-22 14:00 A (-20d) | 2018-06-12 → 2018-05-23 09:30 A (-20d) | 1d → 0.5d | 0% → 100% | 2.07d → none |  | baseline start 2018-06-11 → 2011-04-19 09:30; baseline finish 2018-06-12 → 2011-04-19 13:00 |
| 25 | Select & Order New PABX | 2018-06-12 → 2018-05-23 09:30 A (-20d) | 2018-06-13 → 2018-05-23 10:30 A (-21d) | 1d → 1h | 0% → 100% | 2.07d → none |  | baseline start 2018-06-12 → 2011-04-19 14:00; baseline finish 2018-06-13 → 2011-04-19 15:00 |
| 26 | **IT Networking Consultations** | 2018-06-13 → 2018-05-23 10:30 A (-21d) | 2018-06-26 → 2018-05-31 17:00 A (-26d) | 9.14d → 6.79d | 0% → 100% | 2.07d → none |  | baseline start 2018-06-13 → 2011-04-19 15:00; baseline finish 2018-06-26 → 2011-05-03 12:30 |
| 27 | Design Network Access Points Map | 2018-06-13 → 2018-05-23 10:30 A (-21d) | 2018-06-15 → 2018-05-23 15:00 A (-23d) | 2d → 0.5d | 0% → 100% | 2.07d → none | 25 → 22, 25 | baseline start 2018-06-13 → 2011-04-19 15:00; baseline finish 2018-06-15 → 2011-04-20 10:30 |
| 28 | Select & Order New PCs | 2018-06-15 → 2018-05-23 15:00 A (-23d) | 2018-06-18 → 2018-05-23 16:00 A (-26d) | 1d → 1h | 0% → 100% | 2.07d → none |  | baseline start 2018-06-15 → 2011-04-20 10:30; baseline finish 2018-06-18 → 2011-04-20 11:30 |
| 29 | New PCs Arrive | 2018-06-25 → 2018-05-30 16:00 A (-26d) | 2018-06-25 → 2018-05-30 17:00 A (-26d) |  | 0% → 100% | 2.07d → none |  | baseline start 2018-06-25 → 2011-04-29 11:30; baseline finish 2018-06-25 → 2011-04-29 12:30 |
| 30 | Configure SOE on PCs | 2018-06-25 → 2018-05-31 09:00 A (-25d) | 2018-06-26 → 2018-05-31 17:00 A (-26d) |  | 0% → 100% | 2.07d → none |  | baseline start 2018-06-25 → 2011-04-29 12:30; baseline finish 2018-06-26 → 2011-05-03 12:30 |
| 31 | **Restructure Office** | 2018-06-27 → 2018-05-23 06:00 A (-35d) | 2018-07-16 → 2018-06-11 09:00 (-35d) | 14d → 13d |  | 0d → 3d |  | baseline start 2018-06-27 → 2011-04-20 06:00; baseline finish 2018-07-16 → 2011-05-11 17:00 |
| 32 | Erect New Walls | 2018-06-27 → 2018-05-23 06:00 (-35d) | 2018-06-29 → 2018-05-25 07:00 (-35d) |  |  | 1d → 4d | 30 → 22 | baseline start 2018-06-27 → 2011-04-20 06:00; baseline finish 2018-06-29 → 2011-04-26 07:00 |
| 33 | Gyprock, Plaster & Finish | 2018-06-29 → 2018-05-25 07:00 (-35d) | 2018-07-03 → 2018-05-29 08:00 (-35d) |  |  | 1d → 4d |  | baseline start 2018-06-29 → 2011-04-26 07:00; baseline finish 2018-07-03 → 2011-04-30 10:00 |
| 34 | Install Network Points | 2018-07-04 → 2018-06-01 09:00 (-33d) | 2018-07-04 → 2018-06-01 15:00 (-33d) |  |  | 2.71d → 2.5d | 33FS+1d → 33FS+1ed, 30 | baseline start 2018-07-04 → 2011-05-03 12:30; baseline finish 2018-07-04 → 2011-05-04 10:30 |
| 35 | Install Phone Connections | 2018-07-04 → 2018-06-01 09:00 (-33d) | 2018-07-04 → 2018-06-01 12:30 (-33d) | 2h → 0.5d |  | 2.71d → 2.5d |  | baseline start 2018-07-04 → 2011-05-03 12:30; baseline finish 2018-07-04 → 2011-05-03 17:00 |
| 36 | Re-Paint | 2018-07-05 → 2018-06-02 07:00 (-33d) | 2018-07-07 → 2018-06-02 15:00 (-35d) |  |  |  |  | resources Painter; Paint [100 Litre] → Paint [100 Litre]; Painter; baseline start 2018-07-05 → 2011-05-04 06:00; baseline finish 2018-07-07 → 2011-05-06 07:00 |
| 37 | Carpet | 2018-07-10 → 2018-06-04 06:00 (-36d) | 2018-07-12 → 2018-06-06 07:00 (-36d) |  |  | 2d → 3d | 36FS+1d → 36FS+1ed | resources Carpet Contractor; Carpet [100 Lin Metre] → Carpet [100 Lin Metre]; Carpet Contractor; baseline start 2018-07-10 → 2011-05-07 07:00; baseline finish 2018-07-12 → 2011-05-07 15:00 |
| 38 | Install New Furniture | 2018-07-12 → 2018-06-06 07:00 (-36d) | 2018-07-14 → 2018-06-08 08:00 (-36d) |  |  | 0d → 3d |  | baseline start 2018-07-12 → 2011-05-09 06:00; baseline finish 2018-07-14 → 2011-05-11 07:00 |
| 39 | Install New PCs | 2018-07-16 → 2018-06-08 09:00 (-38d) | 2018-07-16 → 2018-06-08 17:00 (-38d) |  |  | 0d → 3d |  | baseline start 2018-07-16 → 2011-05-11 09:00; baseline finish 2018-07-16 → 2011-05-11 17:00 |
| 40 | Refit Office Complete | 2018-07-16 → 2018-06-11 09:00 A (-35d) | 2018-07-16 → 2018-06-11 09:00 A (-35d) |  | 0% → 100% | 0d → none |  | baseline start 2018-07-16 → 2011-05-11 17:00; baseline finish 2018-07-16 → 2011-05-11 17:00 |
| 41 | **Office Move** | 2018-07-16 → 2018-05-31 09:00 (-46d) | 2018-07-23 → 2018-06-14 07:00 (-39d) | 5d → 10d |  |  |  | baseline start 2018-07-16 → 2011-04-29 12:30; baseline finish 2018-07-23 → 2011-05-16 17:00 |
| 42 | Order packing boxes | 2018-07-16 → 2018-05-31 09:00 (-46d) | 2018-07-16 → 2018-05-31 10:00 (-46d) |  |  | 0.86d → 7.36d | 38 → 29 | baseline start 2018-07-16 → 2011-04-29 12:30; baseline finish 2018-07-16 → 2011-04-29 14:30 |
| 43 | Staff Pack | 2018-07-17 → 2018-06-11 09:00 (-36d) | 2018-07-17 → 2018-06-11 12:30 (-36d) | 1d → 0.5d |  | 0d → 0.5d |  | baseline start 2018-07-17 → 2011-05-12 09:00; baseline finish 2018-07-17 → 2011-05-12 12:30 |
| 44 | Staff Move | 2018-07-18 → 2018-06-11 12:30 (-37d) | 2018-07-23 → 2018-06-14 07:00 (-39d) | 3.57d → 2d |  |  |  | baseline start 2018-07-18 → 2011-05-12 12:30; baseline finish 2018-07-23 → 2011-05-14 11:00 |
| 45 | Office Move Complete | 2018-07-23 → 2018-06-14 07:00 (-39d) | 2018-07-23 → 2018-06-14 07:00 (-39d) |  |  |  |  | constraint finish no later than 2018-07-23 → none; baseline start 2018-07-23 → 2011-05-16 17:00; baseline finish 2018-07-23 → 2011-05-16 17:00 |

## Version 5 (saved 2018-01-08, file Office Renovation Cost Resources - completed.mpp)

Last finish stays 2018-06-14. Complete tasks 25 → 0.

Changed:

| ID | Task | Start | Finish | Complete | Total float | Other |
| --- | --- | --- | --- | --- | --- | --- |
| 1 | **Planning & Research** | 2018-05-07 09:00 A → 2018-05-07 09:00 | 2018-05-17 12:00 A → 2018-05-17 12:00 | 100% → 0% | none → 0.5d | baseline start 2011-04-04 09:00 → none; baseline finish 2011-04-14 12:00 → none |
| 2 | Develop Requirements Documentation | 2018-05-07 09:00 A → 2018-05-07 09:00 | 2018-05-07 17:00 A → 2018-05-07 17:00 | 100% → 0% | none → 0.5d | baseline start 2011-04-04 09:00 → none; baseline finish 2011-04-04 17:00 → none |
| 3 | Fit-Out Consultant Research | 2018-05-08 09:00 A → 2018-05-08 09:00 | 2018-05-08 12:30 A → 2018-05-08 12:30 | 100% → 0% | none → 0.5d | baseline start 2011-04-05 09:00 → none; baseline finish 2011-04-05 12:30 → none |
| 4 | Telecommunications Consultant Research | 2018-05-08 12:30 A → 2018-05-08 12:30 | 2018-05-08 17:00 A → 2018-05-08 17:00 | 100% → 0% | none → 0.5d | baseline start 2011-04-05 12:30 → none; baseline finish 2011-04-05 17:00 → none |
| 5 | IT Network Contractor Research | 2018-05-09 09:00 A → 2018-05-09 09:00 | 2018-05-09 12:30 A → 2018-05-09 12:30 | 100% → 0% | none → 0.5d | baseline start 2011-04-06 09:00 → none; baseline finish 2011-04-06 12:30 → none |
| 6 | Building Contractors Research | 2018-05-09 12:30 A → 2018-05-09 12:30 | 2018-05-09 17:00 A → 2018-05-09 17:00 | 100% → 0% | none → 0.5d | baseline start 2011-04-06 12:30 → none; baseline finish 2011-04-06 17:00 → none |
| 7 | Submit Requirements to Resources & Request Quotes | 2018-05-10 09:00 A → 2018-05-10 09:00 | 2018-05-10 11:00 A → 2018-05-10 11:00 | 100% → 0% | none → 0.5d | baseline start 2011-04-07 09:00 → none; baseline finish 2011-04-07 11:00 → none |
| 8 | Quotes Received | 2018-05-17 11:00 A → 2018-05-17 11:00 | 2018-05-17 12:00 A → 2018-05-17 12:00 | 100% → 0% | none → 0.5d | baseline start 2011-04-14 11:00 → none; baseline finish 2011-04-14 12:00 → none |
| 9 | Planning & Research Complete | 2018-05-17 12:00 A → 2018-05-17 12:00 | 2018-05-17 12:00 A → 2018-05-17 12:00 | 100% → 0% | none → 0.5d | baseline start 2011-04-14 12:00 → none; baseline finish 2011-04-14 12:00 → none |
| 10 | **Management Approval** | 2018-05-17 12:00 A → 2018-05-17 12:00 | 2018-05-21 10:30 A → 2018-05-21 10:30 | 100% → 0% | none → 0.5d | baseline start 2011-04-14 12:00 → none; baseline finish 2011-04-15 15:00 → none |
| 11 | Consolidate Quotes and develop proposal | 2018-05-17 12:00 A → 2018-05-17 12:00 | 2018-05-18 16:30 A → 2018-05-18 16:30 | 100% → 0% | none → 0.5d | baseline start 2011-04-14 12:00 → none; baseline finish 2011-04-15 12:00 → none |
| 12 | Develop Project Plan & Durations | 2018-05-18 16:30 A → 2018-05-18 16:30 | 2018-05-21 09:30 A → 2018-05-21 09:30 | 100% → 0% | none → 0.5d | baseline start 2011-04-15 12:00 → none; baseline finish 2011-04-15 13:00 → none |
| 13 | Submit Project Plan & Costs to Management | 2018-05-21 09:30 A → 2018-05-21 09:30 | 2018-05-21 10:30 A → 2018-05-21 10:30 | 100% → 0% | none → 0.5d | resources Project Manager; Management → Project Manager; Management; Airfare [0.1%]; Travel Allowance [0.1%]; baseline start 2011-04-15 14:00 → none; baseline finish 2011-04-15 15:00 → none |
| 14 | Management Approval Received | 2018-05-21 10:30 A → 2018-05-21 10:30 | 2018-05-21 10:30 A → 2018-05-21 10:30 | 100% → 0% | none → 0.5d | baseline start 2011-04-15 15:00 → none; baseline finish 2011-04-15 15:00 → none |
| 15 | **Refit Office** | 2018-05-21 10:30 A → 2018-05-21 10:30 | 2018-06-11 09:00 → 2018-06-08 17:00 (-3d) | 32% → 0% | 3d → 0.5d | baseline start 2011-04-15 15:00 → none; baseline finish 2011-05-11 17:00 → none |
| 16 | Appoint Resources | 2018-05-21 10:30 A → 2018-05-21 10:30 | 2018-05-21 12:30 A → 2018-05-21 12:30 | 100% → 0% | none → 0.5d | baseline start 2011-04-15 15:00 → none; baseline finish 2011-04-15 17:00 → none |
| 17 | Staff Briefing | 2018-05-21 12:30 A → 2018-05-21 12:30 | 2018-05-21 14:30 A → 2018-05-21 14:30 | 100% → 0% | none → 0.5d | baseline start 2011-04-18 09:00 → none; baseline finish 2011-04-18 10:00 → none |
| 18 | **Fit-Out Consultations** | 2018-05-21 14:30 A → 2018-05-21 14:30 | 2018-05-22 13:00 A → 2018-05-22 13:00 | 100% → 0% | none → 0.5d | baseline start 2011-04-18 10:00 → none; baseline finish 2011-04-19 09:30 → none |
| 19 | Office Space / Structure Plan | 2018-05-21 14:30 A → 2018-05-21 14:30 | 2018-05-22 10:00 A → 2018-05-22 10:00 | 100% → 0% | none → 0.5d | baseline start 2011-04-18 10:00 → none; baseline finish 2011-04-18 14:30 → none |
| 20 | Select & Order Carpet | 2018-05-22 10:00 A → 2018-05-22 10:00 | 2018-05-22 11:00 A → 2018-05-22 11:00 | 100% → 0% | none → 0.5d | baseline start 2011-04-18 14:30 → none; baseline finish 2011-04-18 15:30 → none |
| 21 | Select & Order Paint | 2018-05-22 11:00 A → 2018-05-22 11:00 | 2018-05-22 12:00 A → 2018-05-22 12:00 | 100% → 0% | none → 0.5d | baseline start 2011-04-18 15:30 → none; baseline finish 2011-04-18 16:30 → none |
| 22 | Select & Order Office Furniture | 2018-05-22 12:00 A → 2018-05-22 12:00 | 2018-05-22 13:00 A → 2018-05-22 13:00 | 100% → 0% | none → 0.5d | baseline start 2011-04-18 16:30 → none; baseline finish 2011-04-19 09:30 → none |
| 23 | **Telecommuncations Consultations** | 2018-05-22 14:00 A → 2018-05-22 14:00 | 2018-05-23 10:30 A → 2018-05-23 10:30 | 100% → 0% | none → 0.5d | baseline start 2011-04-19 09:30 → none; baseline finish 2011-04-19 15:00 → none |
| 24 | Design Telephone Access Points Map | 2018-05-22 14:00 A → 2018-05-22 14:00 | 2018-05-23 09:30 A → 2018-05-23 09:30 | 100% → 0% | none → 0.5d | baseline start 2011-04-19 09:30 → none; baseline finish 2011-04-19 13:00 → none |
| 25 | Select & Order New PABX | 2018-05-23 09:30 A → 2018-05-23 09:30 | 2018-05-23 10:30 A → 2018-05-23 10:30 | 100% → 0% | none → 0.5d | resources Project Manager → Project Manager; PABX & Points [0.1%]; baseline start 2011-04-19 14:00 → none; baseline finish 2011-04-19 15:00 → none |
| 26 | **IT Networking Consultations** | 2018-05-23 10:30 A → 2018-05-23 10:30 | 2018-05-31 17:00 A → 2018-05-31 17:00 | 100% → 0% | none → 0.5d | baseline start 2011-04-19 15:00 → none; baseline finish 2011-05-03 12:30 → none |
| 27 | Design Network Access Points Map | 2018-05-23 10:30 A → 2018-05-23 10:30 | 2018-05-23 15:00 A → 2018-05-23 15:00 | 100% → 0% | none → 0.5d | baseline start 2011-04-19 15:00 → none; baseline finish 2011-04-20 10:30 → none |
| 28 | Select & Order New PCs | 2018-05-23 15:00 A → 2018-05-23 15:00 | 2018-05-23 16:00 A → 2018-05-23 16:00 | 100% → 0% | none → 0.5d | baseline start 2011-04-20 10:30 → none; baseline finish 2011-04-20 11:30 → none |
| 29 | New PCs Arrive | 2018-05-30 16:00 A → 2018-05-30 16:00 | 2018-05-30 17:00 A → 2018-05-30 17:00 | 100% → 0% | none → 0.5d | baseline start 2011-04-29 11:30 → none; baseline finish 2011-04-29 12:30 → none |
| 30 | Configure SOE on PCs | 2018-05-31 09:00 A → 2018-05-31 09:00 | 2018-05-31 17:00 A → 2018-05-31 17:00 | 100% → 0% | none → 0.5d | baseline start 2011-04-29 12:30 → none; baseline finish 2011-05-03 12:30 → none |
| 31 | **Restructure Office** | 2018-05-23 06:00 A → 2018-05-23 06:00 | 2018-06-11 09:00 → 2018-06-08 17:00 (-3d) |  | 3d → 0.5d | baseline start 2011-04-20 06:00 → none; baseline finish 2011-05-11 17:00 → none |
| 32 | Erect New Walls |  |  |  | 4d → 1d | baseline start 2011-04-20 06:00 → none; baseline finish 2011-04-26 07:00 → none |
| 33 | Gyprock, Plaster & Finish |  |  |  | 4d → 1d | baseline start 2011-04-26 07:00 → none; baseline finish 2011-04-30 10:00 → none |
| 34 | Install Network Points |  |  |  | 2.5d → 0.5d | resources IT Consultant → IT Consultant; Network Cable & Points [0.1%]; baseline start 2011-05-03 12:30 → none; baseline finish 2011-05-04 10:30 → none |
| 35 | Install Phone Connections |  |  |  | 2.5d → 0.5d | resources Telecommunications consultant → Telecommunications consultant; PABX & Points [0.1%]; baseline start 2011-05-03 12:30 → none; baseline finish 2011-05-03 17:00 → none |
| 36 | Re-Paint |  |  |  | 2d → 0d | baseline start 2011-05-04 06:00 → none; baseline finish 2011-05-06 07:00 → none |
| 37 | Carpet |  |  |  | 3d → 0d | baseline start 2011-05-07 07:00 → none; baseline finish 2011-05-07 15:00 → none |
| 38 | Install New Furniture |  |  |  | 3d → 0d | resources Labourer → Labourer; Furniture [0.1%]; baseline start 2011-05-09 06:00 → none; baseline finish 2011-05-11 07:00 → none |
| 39 | Install New PCs |  |  |  | 3d → 0.5d | resources IT Consultant → IT Consultant; Computers [0.1%]; baseline start 2011-05-11 09:00 → none; baseline finish 2011-05-11 17:00 → none |
| 40 | Refit Office Complete | 2018-06-11 09:00 A → 2018-06-08 17:00 (-3d) | 2018-06-11 09:00 A → 2018-06-08 17:00 (-3d) | 100% → 0% | none → 0.5d | baseline start 2011-05-11 17:00 → none; baseline finish 2011-05-11 17:00 → none |
| 41 | **Office Move** |  |  |  |  | baseline start 2011-04-29 12:30 → none; baseline finish 2011-05-16 17:00 → none |
| 42 | Order packing boxes |  |  |  |  | baseline start 2011-04-29 12:30 → none; baseline finish 2011-04-29 14:30 → none |
| 43 | Staff Pack |  |  |  |  | baseline start 2011-05-12 09:00 → none; baseline finish 2011-05-12 12:30 → none |
| 44 | Staff Move |  |  |  |  | baseline start 2011-05-12 12:30 → none; baseline finish 2011-05-14 11:00 → none |
| 45 | Office Move Complete |  |  |  |  | baseline start 2011-05-16 17:00 → none; baseline finish 2011-05-16 17:00 → none |

## Version 6 (saved 2018-01-08, file Office Renovation Multi Cost Rates - complete.mpp)

Last finish stays 2018-06-14.

Changed:

| ID | Task | Other |
| --- | --- | --- |
| 13 | Submit Project Plan & Costs to Management | resources Project Manager; Management; Airfare [0.1%]; Travel Allowance [0.1%] → Project Manager; Management |
| 25 | Select & Order New PABX | resources Project Manager; PABX & Points [0.1%] → Project Manager |
| 34 | Install Network Points | resources IT Consultant; Network Cable & Points [0.1%] → IT Consultant |
| 35 | Install Phone Connections | resources Telecommunications consultant; PABX & Points [0.1%] → Telecommunications consultant |
| 38 | Install New Furniture | resources Labourer; Furniture [0.1%] → Labourer |
| 39 | Install New PCs | resources IT Consultant; Computers [0.1%] → IT Consultant |

## Version 7 (saved 2018-01-08, file Tables - completed.mpp)

Last finish stays 2018-06-14.

Changed:

| ID | Task | Other |
| --- | --- | --- |
| 1 | **Planning & Research** | baseline start none → 2011-04-04 09:00; baseline finish none → 2011-04-14 12:00 |
| 2 | Develop Requirements Documentation | baseline start none → 2011-04-04 09:00; baseline finish none → 2011-04-04 17:00 |
| 3 | Fit-Out Consultant Research | baseline start none → 2011-04-05 09:00; baseline finish none → 2011-04-05 12:30 |
| 4 | Telecommunications Consultant Research | baseline start none → 2011-04-05 12:30; baseline finish none → 2011-04-05 17:00 |
| 5 | IT Network Contractor Research | baseline start none → 2011-04-06 09:00; baseline finish none → 2011-04-06 12:30 |
| 6 | Building Contractors Research | baseline start none → 2011-04-06 12:30; baseline finish none → 2011-04-06 17:00 |
| 7 | Submit Requirements to Resources & Request Quotes | baseline start none → 2011-04-07 09:00; baseline finish none → 2011-04-07 11:00 |
| 8 | Quotes Received | baseline start none → 2011-04-14 11:00; baseline finish none → 2011-04-14 12:00 |
| 9 | Planning & Research Complete | baseline start none → 2011-04-14 12:00; baseline finish none → 2011-04-14 12:00 |
| 10 | **Management Approval** | baseline start none → 2011-04-14 12:00; baseline finish none → 2011-04-15 15:00 |
| 11 | Consolidate Quotes and develop proposal | baseline start none → 2011-04-14 12:00; baseline finish none → 2011-04-15 12:00 |
| 12 | Develop Project Plan & Durations | baseline start none → 2011-04-15 12:00; baseline finish none → 2011-04-15 13:00 |
| 13 | Submit Project Plan & Costs to Management | baseline start none → 2011-04-15 14:00; baseline finish none → 2011-04-15 15:00 |
| 14 | Management Approval Received | baseline start none → 2011-04-15 15:00; baseline finish none → 2011-04-15 15:00 |
| 15 | **Refit Office** | baseline start none → 2011-04-15 15:00; baseline finish none → 2011-05-11 17:00 |
| 16 | Appoint Resources | baseline start none → 2011-04-15 15:00; baseline finish none → 2011-04-15 17:00 |
| 17 | Staff Briefing | baseline start none → 2011-04-18 09:00; baseline finish none → 2011-04-18 10:00 |
| 18 | **Fit-Out Consultations** | baseline start none → 2011-04-18 10:00; baseline finish none → 2011-04-19 09:30 |
| 19 | Office Space / Structure Plan | baseline start none → 2011-04-18 10:00; baseline finish none → 2011-04-18 14:30 |
| 20 | Select & Order Carpet | baseline start none → 2011-04-18 14:30; baseline finish none → 2011-04-18 15:30 |
| 21 | Select & Order Paint | baseline start none → 2011-04-18 15:30; baseline finish none → 2011-04-18 16:30 |
| 22 | Select & Order Office Furniture | baseline start none → 2011-04-18 16:30; baseline finish none → 2011-04-19 09:30 |
| 23 | **Telecommuncations Consultations** | baseline start none → 2011-04-19 09:30; baseline finish none → 2011-04-19 15:00 |
| 24 | Design Telephone Access Points Map | baseline start none → 2011-04-19 09:30; baseline finish none → 2011-04-19 13:00 |
| 25 | Select & Order New PABX | baseline start none → 2011-04-19 14:00; baseline finish none → 2011-04-19 15:00 |
| 26 | **IT Networking Consultations** | baseline start none → 2011-04-19 15:00; baseline finish none → 2011-05-03 12:30 |
| 27 | Design Network Access Points Map | baseline start none → 2011-04-19 15:00; baseline finish none → 2011-04-20 10:30 |
| 28 | Select & Order New PCs | baseline start none → 2011-04-20 10:30; baseline finish none → 2011-04-20 11:30 |
| 29 | New PCs Arrive | baseline start none → 2011-04-29 11:30; baseline finish none → 2011-04-29 12:30 |
| 30 | Configure SOE on PCs | baseline start none → 2011-04-29 12:30; baseline finish none → 2011-05-03 12:30 |
| 31 | **Restructure Office** | baseline start none → 2011-04-20 06:00; baseline finish none → 2011-05-11 17:00 |
| 32 | Erect New Walls | baseline start none → 2011-04-20 06:00; baseline finish none → 2011-04-26 07:00 |
| 33 | Gyprock, Plaster & Finish | baseline start none → 2011-04-26 07:00; baseline finish none → 2011-04-30 10:00 |
| 34 | Install Network Points | baseline start none → 2011-05-03 12:30; baseline finish none → 2011-05-04 10:30 |
| 35 | Install Phone Connections | baseline start none → 2011-05-03 12:30; baseline finish none → 2011-05-03 17:00 |
| 36 | Re-Paint | baseline start none → 2011-05-04 06:00; baseline finish none → 2011-05-06 07:00 |
| 37 | Carpet | baseline start none → 2011-05-07 07:00; baseline finish none → 2011-05-07 15:00 |
| 38 | Install New Furniture | baseline start none → 2011-05-09 06:00; baseline finish none → 2011-05-11 07:00 |
| 39 | Install New PCs | baseline start none → 2011-05-11 09:00; baseline finish none → 2011-05-11 17:00 |
| 40 | Refit Office Complete | baseline start none → 2011-05-11 17:00; baseline finish none → 2011-05-11 17:00 |
| 41 | **Office Move** | baseline start none → 2011-04-29 12:30; baseline finish none → 2011-05-16 17:00 |
| 42 | Order packing boxes | baseline start none → 2011-04-29 12:30; baseline finish none → 2011-04-29 14:30 |
| 43 | Staff Pack | baseline start none → 2011-05-12 09:00; baseline finish none → 2011-05-12 12:30 |
| 44 | Staff Move | baseline start none → 2011-05-12 12:30; baseline finish none → 2011-05-14 11:00 |
| 45 | Office Move Complete | baseline start none → 2011-05-16 17:00; baseline finish none → 2011-05-16 17:00 |

## Version 8 (saved 2018-01-08, file Scheduling Options - Complete.mpp)

Last finish 2018-06-14 → 2018-06-25 (+11d). Complete tasks 0 → 1.

Changed:

| ID | Task | Start | Finish | Duration | Complete | Total float | Predecessors | Other |
| --- | --- | --- | --- | --- | --- | --- | --- | --- |
| 1 | **Planning & Research** |  | 2018-05-17 12:00 → 2018-05-17 16:00 | 8.43d → 7.75d |  | 0.5d → 5.12d |  |  |
| 2 | Develop Requirements Documentation |  | 2018-05-07 17:00 → 2018-05-08 10:00 (+1d) |  |  | 0.5d → 5.12d |  |  |
| 3 | Fit-Out Consultant Research | 2018-05-08 09:00 → 2018-05-08 10:00 | 2018-05-08 12:30 → 2018-05-08 15:00 |  |  | 0.5d → 5.12d |  |  |
| 4 | Telecommunications Consultant Research | 2018-05-08 12:30 → 2018-05-08 15:00 | 2018-05-08 17:00 → 2018-05-09 11:00 (+1d) |  |  | 0.5d → 5.12d |  |  |
| 5 | IT Network Contractor Research | 2018-05-09 09:00 → 2018-05-09 11:00 | 2018-05-09 12:30 → 2018-05-09 16:00 |  |  | 0.5d → 5.12d |  |  |
| 6 | Building Contractors Research | 2018-05-09 12:30 → 2018-05-09 16:00 | 2018-05-09 17:00 → 2018-05-10 12:00 (+1d) |  |  | 0.5d → 5.12d |  |  |
| 7 | Submit Requirements to Resources & Request Quotes | 2018-05-10 09:00 → 2018-05-10 12:00 | 2018-05-10 11:00 → 2018-05-10 15:00 |  |  | 0.5d → 5.12d |  |  |
| 8 | Quotes Received | 2018-05-17 11:00 → 2018-05-17 15:00 | 2018-05-17 12:00 → 2018-05-17 16:00 |  |  | 0.5d → 5.12d | 7FS+5d → 7FS+4.38d |  |
| 9 | Planning & Research Complete | 2018-05-17 12:00 → 2018-05-17 16:00 | 2018-05-17 12:00 → 2018-05-17 16:00 |  |  | 0.5d → 5.12d |  |  |
| 10 | **Management Approval** | 2018-05-17 12:00 → 2018-05-17 16:00 | 2018-05-21 10:30 → 2018-05-22 12:00 (+1d) | 1.79d → 2.25d |  | 0.5d → 5.12d |  |  |
| 11 | Consolidate Quotes and develop proposal | 2018-05-17 12:00 → 2018-05-17 16:00 | 2018-05-18 16:30 → 2018-05-22 10:00 (+4d) | 1.5d → 2d |  | 0.5d → 5.12d |  |  |
| 12 | Develop Project Plan & Durations | 2018-05-18 16:30 → 2018-05-22 10:00 (+4d) | 2018-05-21 09:30 → 2018-05-22 11:00 (+1d) |  |  | 0.5d → 5.12d |  |  |
| 13 | Submit Project Plan & Costs to Management | 2018-05-21 09:30 → 2018-05-22 11:00 (+1d) | 2018-05-21 10:30 → 2018-05-22 12:00 (+1d) |  |  | 0.5d → 5.12d |  |  |
| 14 | Management Approval Received | 2018-05-21 10:30 → 2018-05-22 12:00 (+1d) | 2018-05-21 10:30 → 2018-05-22 12:00 (+1d) |  |  | 0.5d → 5.12d |  |  |
| 15 | **Refit Office** | 2018-05-21 10:30 → 2018-05-22 12:00 A (+1d) | 2018-06-08 17:00 → 2018-06-15 10:00 (+7d) | 14.79d → 15.5d |  | 0.5d → 5.25d |  |  |
| 16 | Appoint Resources | 2018-05-21 10:30 → 2018-05-22 12:00 (+1d) | 2018-05-21 12:30 → 2018-05-22 15:00 (+1d) |  |  | 0.5d → 5.12d |  |  |
| 17 | Staff Briefing | 2018-05-21 12:30 → 2018-05-22 15:00 (+1d) | 2018-05-21 14:30 → 2018-05-22 16:00 (+1d) |  |  | 0.5d → 5.12d |  |  |
| 18 | **Fit-Out Consultations** | 2018-05-21 14:30 → 2018-05-22 16:00 (+1d) | 2018-05-22 13:00 → 2018-05-23 16:00 (+1d) | 0.93d → 0.88d |  | 0.5d → 5.12d |  |  |
| 19 | Office Space / Structure Plan | 2018-05-21 14:30 → 2018-05-22 16:00 (+1d) | 2018-05-22 10:00 → 2018-05-23 12:00 (+1d) |  |  | 0.5d → 5.12d |  |  |
| 20 | Select & Order Carpet | 2018-05-22 10:00 → 2018-05-23 12:00 (+1d) | 2018-05-22 11:00 → 2018-05-23 13:00 (+1d) |  |  | 0.5d → 5.12d |  |  |
| 21 | Select & Order Paint | 2018-05-22 11:00 → 2018-05-23 14:00 (+1d) | 2018-05-22 12:00 → 2018-05-23 15:00 (+1d) |  |  | 0.5d → 5.12d |  |  |
| 22 | Select & Order Office Furniture | 2018-05-22 12:00 → 2018-05-23 15:00 (+1d) | 2018-05-22 13:00 → 2018-05-23 16:00 (+1d) |  |  | 0.5d → 5.12d |  |  |
| 23 | **Telecommuncations Consultations** | 2018-05-22 14:00 → 2018-05-23 16:00 (+1d) | 2018-05-23 10:30 → 2018-05-24 13:00 (+1d) | 0.64d → 0.62d |  | 0.5d → 5.12d |  |  |
| 24 | Design Telephone Access Points Map | 2018-05-22 14:00 → 2018-05-23 16:00 (+1d) | 2018-05-23 09:30 → 2018-05-24 12:00 (+1d) |  |  | 0.5d → 5.12d |  |  |
| 25 | Select & Order New PABX | 2018-05-23 09:30 → 2018-05-24 12:00 (+1d) | 2018-05-23 10:30 → 2018-05-24 13:00 (+1d) |  |  | 0.5d → 5.12d |  |  |
| 26 | **IT Networking Consultations** | 2018-05-23 10:30 → 2018-05-24 14:00 (+1d) | 2018-05-31 17:00 → 2018-06-04 13:00 (+4d) | 6.79d → 6.12d |  | 0.5d → 5.12d |  |  |
| 27 | Design Network Access Points Map | 2018-05-23 10:30 → 2018-05-24 14:00 (+1d) | 2018-05-23 15:00 → 2018-05-25 10:00 (+2d) |  |  | 0.5d → 5.12d |  |  |
| 28 | Select & Order New PCs | 2018-05-23 15:00 → 2018-05-25 10:00 (+2d) | 2018-05-23 16:00 → 2018-05-25 11:00 (+2d) |  |  | 0.5d → 5.12d |  |  |
| 29 | New PCs Arrive | 2018-05-30 16:00 → 2018-06-01 11:00 (+2d) | 2018-05-30 17:00 → 2018-06-01 12:00 (+2d) |  |  | 0.5d → 5.12d | 28FS+5d → 28FS+4.38d |  |
| 30 | Configure SOE on PCs | 2018-05-31 09:00 → 2018-06-01 12:00 (+1d) | 2018-05-31 17:00 → 2018-06-04 13:00 (+4d) |  |  | 0.5d → 5.12d |  |  |
| 31 | **Restructure Office** | 2018-05-23 06:00 → 2018-05-24 06:00 A (+1d) | 2018-06-08 17:00 → 2018-06-15 10:00 (+7d) | 13d → 14.12d |  | 0.5d → 5.25d |  |  |
| 32 | Erect New Walls | 2018-05-23 06:00 → 2018-05-24 06:00 (+1d) | 2018-05-25 07:00 → 2018-05-26 08:00 (+1d) |  |  | 1d → 7d |  |  |
| 33 | Gyprock, Plaster & Finish | 2018-05-25 07:00 → 2018-05-26 08:00 (+1d) | 2018-05-29 08:00 → 2018-05-30 08:00 (+1d) |  |  | 1d → 7d |  |  |
| 34 | Install Network Points | 2018-06-01 09:00 → 2018-06-04 14:00 (+3d) | 2018-06-01 15:00 → 2018-06-05 11:00 (+4d) |  |  | 0.5d → 5.12d |  |  |
| 35 | Install Phone Connections | 2018-06-01 09:00 → 2018-06-04 14:00 (+3d) | 2018-06-01 12:30 → 2018-06-05 10:00 (+4d) |  |  | 0.5d → 5.12d |  |  |
| 36 | Re-Paint | 2018-06-02 07:00 → 2018-06-06 06:00 (+4d) | 2018-06-02 15:00 → 2018-06-08 08:00 (+6d) |  |  | 0d → 4.38d |  |  |
| 37 | Carpet | 2018-06-04 06:00 → 2018-06-09 08:00 (+5d) | 2018-06-06 07:00 → 2018-06-11 08:00 (+5d) |  |  | 0d → 4.38d |  |  |
| 38 | Install New Furniture | 2018-06-06 07:00 → 2018-06-11 08:00 (+5d) | 2018-06-08 08:00 → 2018-06-14 07:00 (+6d) |  |  | 0d → 5.25d |  |  |
| 39 | Install New PCs | 2018-06-08 09:00 → 2018-06-14 09:00 (+6d) | 2018-06-08 17:00 → 2018-06-15 10:00 (+7d) |  |  | 0.5d → 5.25d |  |  |
| 40 | Refit Office Complete | 2018-06-08 17:00 → 2018-06-15 10:00 A (+7d) | 2018-06-08 17:00 → 2018-06-15 10:00 A (+7d) |  | 0% → 100% | 0.5d → none |  |  |
| 41 | **Office Move** | 2018-05-31 09:00 → 2018-06-01 12:00 (+1d) | 2018-06-14 07:00 → 2018-06-25 10:00 (+11d) | 10d → 13.75d |  |  |  |  |
| 42 | Order packing boxes | 2018-05-31 09:00 → 2018-06-01 12:00 (+1d) | 2018-05-31 10:00 → 2018-06-01 13:00 (+1d) |  |  | 7.36d → 11.25d |  |  |
| 43 | Staff Pack | 2018-06-11 09:00 → 2018-06-18 09:00 (+7d) | 2018-06-11 12:30 → 2018-06-18 13:00 (+7d) |  |  | 0.5d → none |  |  |
| 44 | Staff Move | 2018-06-11 12:30 → 2018-06-21 09:00 (+10d) | 2018-06-14 07:00 → 2018-06-25 10:00 (+11d) | 2d → 1.88d |  | 0d → none |  | resources Staff [2000%]; Labourer → Staff [2000%] |
| 45 | Office Move Complete | 2018-06-14 07:00 → 2018-06-25 09:00 (+11d) | 2018-06-14 07:00 → 2018-06-25 09:00 (+11d) |  |  | 0d → none |  |  |

## Version 9 (saved 2018-01-08, file Resource Calendars - completed.mpp)

Last finish 2018-06-25 → 2018-07-05 (+10d). Complete tasks 1 → 0.

Changed:

| ID | Task | Start | Finish | Duration | Complete | Total float | Predecessors | Other |
| --- | --- | --- | --- | --- | --- | --- | --- | --- |
| 1 | **Planning & Research** | 2018-05-07 09:00 → 2018-05-07 | 2018-05-17 16:00 → 2018-05-28 (+11d) | 7.75d → 15.5d |  | 5.12d → -1.43d |  | baseline start 2011-04-04 09:00 → none; baseline finish 2011-04-14 12:00 → none |
| 2 | Develop Requirements Documentation | 2018-05-07 09:00 → 2018-05-07 | 2018-05-08 10:00 → 2018-05-07 (-1d) |  |  | 5.12d → -1.43d |  | baseline start 2011-04-04 09:00 → none; baseline finish 2011-04-04 17:00 → none |
| 3 | Fit-Out Consultant Research | 2018-05-08 10:00 → 2018-05-08 | 2018-05-08 15:00 → 2018-05-09 (+1d) | 0.5d → 2d |  | 5.12d → -1.43d |  | resources Project Manager → none; baseline start 2011-04-05 09:00 → none; baseline finish 2011-04-05 12:30 → none |
| 4 | Telecommunications Consultant Research | 2018-05-08 15:00 → 2018-05-10 (+2d) | 2018-05-09 11:00 → 2018-05-11 (+2d) | 0.5d → 2d |  | 5.12d → -1.43d |  | resources Project Manager → none; baseline start 2011-04-05 12:30 → none; baseline finish 2011-04-05 17:00 → none |
| 5 | IT Network Contractor Research | 2018-05-09 11:00 → 2018-05-14 (+5d) | 2018-05-09 16:00 → 2018-05-15 (+6d) | 0.5d → 2d |  | 5.12d → -1.43d |  | resources Project Manager → none; baseline start 2011-04-06 09:00 → none; baseline finish 2011-04-06 12:30 → none |
| 6 | Building Contractors Research | 2018-05-09 16:00 → 2018-05-16 (+7d) | 2018-05-10 12:00 → 2018-05-17 (+7d) | 0.5d → 2d |  | 5.12d → -1.43d |  | resources Project Manager → none; baseline start 2011-04-06 12:30 → none; baseline finish 2011-04-06 17:00 → none |
| 7 | Submit Requirements to Resources & Request Quotes | 2018-05-10 12:00 → 2018-05-18 (+8d) | 2018-05-10 15:00 → 2018-05-18 (+8d) | 2h → 1d |  | 5.12d → -1.43d |  | resources Project Manager → none; baseline start 2011-04-07 09:00 → none; baseline finish 2011-04-07 11:00 → none |
| 8 | Quotes Received | 2018-05-17 15:00 → 2018-05-28 (+11d) | 2018-05-17 16:00 → 2018-05-28 (+11d) | 1h → 0.5d |  | 5.12d → -1.43d | 7FS+4.38d → 7FS+5d | resources Project Manager → none; baseline start 2011-04-14 11:00 → none; baseline finish 2011-04-14 12:00 → none |
| 9 | Planning & Research Complete | 2018-05-17 16:00 → 2018-05-28 (+11d) | 2018-05-17 16:00 → 2018-05-28 (+11d) |  |  | 5.12d → -1.43d |  | baseline start 2011-04-14 12:00 → none; baseline finish 2011-04-14 12:00 → none |
| 10 | **Management Approval** | 2018-05-17 16:00 → 2018-05-28 (+11d) | 2018-05-22 12:00 → 2018-06-01 (+10d) | 2.25d → 4.14d |  | 5.12d → -1.43d |  | baseline start 2011-04-14 12:00 → none; baseline finish 2011-04-15 15:00 → none |
| 11 | Consolidate Quotes and develop proposal | 2018-05-17 16:00 → 2018-05-28 (+11d) | 2018-05-22 10:00 → 2018-05-30 (+8d) |  |  | 5.12d → -1.43d |  | resources Project Manager → none; baseline start 2011-04-14 12:00 → none; baseline finish 2011-04-15 12:00 → none |
| 12 | Develop Project Plan & Durations | 2018-05-22 10:00 → 2018-05-30 (+8d) | 2018-05-22 11:00 → 2018-06-01 (+10d) | 1h → 2d |  | 5.12d → -1.43d |  | resources Project Manager → none; baseline start 2011-04-15 12:00 → none; baseline finish 2011-04-15 13:00 → none |
| 13 | Submit Project Plan & Costs to Management | 2018-05-22 11:00 → 2018-06-01 (+10d) | 2018-05-22 12:00 → 2018-06-01 (+10d) |  |  | 5.12d → -1.43d |  | resources Project Manager; Management → none; baseline start 2011-04-15 14:00 → none; baseline finish 2011-04-15 15:00 → none |
| 14 | Management Approval Received | 2018-05-22 12:00 → 2018-06-01 (+10d) | 2018-05-22 12:00 → 2018-06-01 (+10d) |  |  | 5.12d → -1.43d |  | baseline start 2011-04-15 15:00 → none; baseline finish 2011-04-15 15:00 → none |
| 15 | **Refit Office** | 2018-05-22 12:00 A → 2018-06-01 (+10d) | 2018-06-15 10:00 → 2018-07-03 (+18d) | 15.5d → 21.64d |  | 5.25d → -1.43d |  | baseline start 2011-04-15 15:00 → none; baseline finish 2011-05-11 17:00 → none |
| 16 | Appoint Resources | 2018-05-22 12:00 → 2018-06-01 (+10d) | 2018-05-22 15:00 → 2018-06-04 (+13d) | 2h → 1d |  | 5.12d → -1.43d |  | resources Project Manager → none; baseline start 2011-04-15 15:00 → none; baseline finish 2011-04-15 17:00 → none |
| 17 | Staff Briefing | 2018-05-22 15:00 → 2018-06-04 (+13d) | 2018-05-22 16:00 → 2018-06-04 (+13d) |  |  | 5.12d → -1.43d |  | resources Project Manager; Staff [700%] → none; baseline start 2011-04-18 09:00 → none; baseline finish 2011-04-18 10:00 → none |
| 18 | **Fit-Out Consultations** | 2018-05-22 16:00 → 2018-06-04 (+13d) | 2018-05-23 16:00 → 2018-06-07 (+15d) | 0.88d → 2.5d |  | 5.12d → -1.43d |  | baseline start 2011-04-18 10:00 → none; baseline finish 2011-04-19 09:30 → none |
| 19 | Office Space / Structure Plan | 2018-05-22 16:00 → 2018-06-04 (+13d) | 2018-05-23 12:00 → 2018-06-05 (+13d) | 0.5d → 1d |  | 5.12d → -1.43d |  | resources Fit-out Consultant; Project Manager → none; baseline start 2011-04-18 10:00 → none; baseline finish 2011-04-18 14:30 → none |
| 20 | Select & Order Carpet | 2018-05-23 12:00 → 2018-06-05 (+13d) | 2018-05-23 13:00 → 2018-06-06 (+14d) | 1h → 0.5d |  | 5.12d → -1.43d |  | resources Fit-out Consultant; Project Manager → none; baseline start 2011-04-18 14:30 → none; baseline finish 2011-04-18 15:30 → none |
| 21 | Select & Order Paint | 2018-05-23 14:00 → 2018-06-06 (+14d) | 2018-05-23 15:00 → 2018-06-06 (+14d) | 1h → 0.5d |  | 5.12d → -1.43d |  | resources Fit-out Consultant; Project Manager → none; baseline start 2011-04-18 15:30 → none; baseline finish 2011-04-18 16:30 → none |
| 22 | Select & Order Office Furniture | 2018-05-23 15:00 → 2018-06-06 (+14d) | 2018-05-23 16:00 → 2018-06-07 (+15d) | 1h → 0.5d |  | 5.12d → -1.43d |  | resources Fit-out Consultant; Project Manager → none; baseline start 2011-04-18 16:30 → none; baseline finish 2011-04-19 09:30 → none |
| 23 | **Telecommuncations Consultations** | 2018-05-23 16:00 → 2018-06-07 (+15d) | 2018-05-24 13:00 → 2018-06-11 (+18d) | 0.62d → 2d |  | 5.12d → 17.71d |  | baseline start 2011-04-19 09:30 → none; baseline finish 2011-04-19 15:00 → none |
| 24 | Design Telephone Access Points Map | 2018-05-23 16:00 → 2018-06-07 (+15d) | 2018-05-24 12:00 → 2018-06-08 (+15d) | 0.5d → 1d |  | 5.12d → 17.71d |  | resources Project Manager; Telecommunications consultant → none; baseline start 2011-04-19 09:30 → none; baseline finish 2011-04-19 13:00 → none |
| 25 | Select & Order New PABX | 2018-05-24 12:00 → 2018-06-08 (+15d) | 2018-05-24 13:00 → 2018-06-11 (+18d) | 1h → 1d |  | 5.12d → 17.71d |  | resources Project Manager → none; baseline start 2011-04-19 14:00 → none; baseline finish 2011-04-19 15:00 → none |
| 26 | **IT Networking Consultations** | 2018-05-24 14:00 → 2018-06-07 (+14d) | 2018-06-04 13:00 → 2018-06-19 (+15d) | 6.12d → 8.14d |  | 5.12d → -1.43d |  | baseline start 2011-04-19 15:00 → none; baseline finish 2011-05-03 12:30 → none |
| 27 | Design Network Access Points Map | 2018-05-24 14:00 → 2018-06-07 (+14d) | 2018-05-25 10:00 → 2018-06-08 (+14d) | 0.5d → 1d |  | 5.12d → -1.43d | 22, 25 → 22 | resources IT Consultant; Project Manager → none; baseline start 2011-04-19 15:00 → none; baseline finish 2011-04-20 10:30 → none |
| 28 | Select & Order New PCs | 2018-05-25 10:00 → 2018-06-08 (+14d) | 2018-05-25 11:00 → 2018-06-11 (+17d) | 1h → 1d |  | 5.12d → -1.43d |  | resources Project Manager → none; baseline start 2011-04-20 10:30 → none; baseline finish 2011-04-20 11:30 → none |
| 29 | New PCs Arrive | 2018-06-01 11:00 → 2018-06-18 (+17d) | 2018-06-01 12:00 → 2018-06-18 (+17d) |  |  | 5.12d → -1.43d | 28FS+4.38d → 28FS+5d | resources Project Manager → none; baseline start 2011-04-29 11:30 → none; baseline finish 2011-04-29 12:30 → none |
| 30 | Configure SOE on PCs | 2018-06-01 12:00 → 2018-06-18 (+17d) | 2018-06-04 13:00 → 2018-06-19 (+15d) |  |  | 5.12d → -1.43d |  | resources IT Consultant → none; baseline start 2011-04-29 12:30 → none; baseline finish 2011-05-03 12:30 → none |
| 31 | **Restructure Office** | 2018-05-24 06:00 A → 2018-06-20 (+27d) | 2018-06-15 10:00 → 2018-07-03 (+18d) | 14.12d → 9.29d |  | 5.25d → -2d |  | baseline start 2011-04-20 06:00 → none; baseline finish 2011-05-11 17:00 → none |
| 32 | Erect New Walls | 2018-05-24 06:00 → 2018-06-20 (+27d) | 2018-05-26 08:00 → 2018-06-22 (+27d) |  |  | 7d → -2d | 22 → 30 | baseline start 2011-04-20 06:00 → none; baseline finish 2011-04-26 07:00 → none |
| 33 | Gyprock, Plaster & Finish | 2018-05-26 08:00 → 2018-06-22 (+27d) | 2018-05-30 08:00 → 2018-06-23 (+24d) | 14h → 7h |  | 7d → -2d |  | resources Plasterer → Plasterer [200%]; baseline start 2011-04-26 07:00 → none; baseline finish 2011-04-30 10:00 → none |
| 34 | Install Network Points | 2018-06-04 14:00 → 2018-06-26 (+22d) | 2018-06-05 11:00 → 2018-06-26 (+21d) |  |  | 5.12d → -0.29d | 33FS+1ed, 30 → 33FS+1d | resources IT Consultant → none; baseline start 2011-05-03 12:30 → none; baseline finish 2011-05-04 10:30 → none |
| 35 | Install Phone Connections | 2018-06-04 14:00 → 2018-06-26 (+22d) | 2018-06-05 10:00 → 2018-06-26 (+21d) | 0.5d → 2h |  | 5.12d → -0.29d |  | resources Telecommunications consultant → none; baseline start 2011-05-03 12:30 → none; baseline finish 2011-05-03 17:00 → none |
| 36 | Re-Paint | 2018-06-06 06:00 → 2018-06-26 (+20d) | 2018-06-08 08:00 → 2018-06-27 (+19d) |  |  | 4.38d → -0.29d |  | resources Paint [100 Litre]; Painter → none; baseline start 2011-05-04 06:00 → none; baseline finish 2011-05-06 07:00 → none |
| 37 | Carpet | 2018-06-09 08:00 → 2018-06-28 (+19d) | 2018-06-11 08:00 → 2018-06-29 (+18d) |  |  | 4.38d → -0.29d | 36FS+1ed → 36FS+1d | resources Carpet [100 Lin Metre]; Carpet Contractor → none; baseline start 2011-05-07 07:00 → none; baseline finish 2011-05-07 15:00 → none |
| 38 | Install New Furniture | 2018-06-11 08:00 → 2018-06-29 (+18d) | 2018-06-14 07:00 → 2018-07-02 (+18d) |  |  | 5.25d → -0.29d |  | resources Labourer → none; baseline start 2011-05-09 06:00 → none; baseline finish 2011-05-11 07:00 → none |
| 39 | Install New PCs | 2018-06-14 09:00 → 2018-07-02 (+18d) | 2018-06-15 10:00 → 2018-07-03 (+18d) |  |  | 5.25d → -0.29d |  | resources IT Consultant → none; baseline start 2011-05-11 09:00 → none; baseline finish 2011-05-11 17:00 → none |
| 40 | Refit Office Complete | 2018-06-15 10:00 A → 2018-07-03 (+18d) | 2018-06-15 10:00 A → 2018-07-03 (+18d) |  | 100% → 0% | none → -0.29d |  | baseline start 2011-05-11 17:00 → none; baseline finish 2011-05-11 17:00 → none |
| 41 | **Office Move** | 2018-06-01 12:00 → 2018-07-02 (+31d) | 2018-06-25 10:00 → 2018-07-05 (+10d) | 13.75d → 3d |  |  |  | baseline start 2011-04-29 12:30 → none; baseline finish 2011-05-16 17:00 → none |
| 42 | Order packing boxes | 2018-06-01 12:00 → 2018-07-02 (+31d) | 2018-06-01 13:00 → 2018-07-02 (+31d) |  |  | 11.25d → 2.57d | 29 → 38 | resources Project Manager → none; baseline start 2011-04-29 12:30 → none; baseline finish 2011-04-29 14:30 → none |
| 43 | Staff Pack | 2018-06-18 09:00 → 2018-07-02 (+14d) | 2018-06-18 13:00 → 2018-07-02 (+14d) | 0.5d → 1d |  |  | 40, 42 → 40 | resources Project Manager; Staff [2000%] → none; baseline start 2011-05-12 09:00 → none; baseline finish 2011-05-12 12:30 → none |
| 44 | Staff Move | 2018-06-21 09:00 → 2018-07-03 (+12d) | 2018-06-25 10:00 → 2018-07-03 (+8d) | 1.88d → 1d |  |  |  | resources Staff [2000%] → none; baseline start 2011-05-12 12:30 → none; baseline finish 2011-05-14 11:00 → none |
| 45 | Office Move Complete | 2018-06-25 09:00 → 2018-07-05 (+10d) | 2018-06-25 09:00 → 2018-07-05 (+10d) |  |  |  |  | baseline start 2011-05-16 17:00 → none; baseline finish 2011-05-16 17:00 → none |
