# Earned Value complete

How a schedule from MS Project changed from version to version. A marks actual dates.

## Version 1 (data date 2025-06-02, saved 2024-12-19, file Comparison Version 2.mpp)

| ID | Task | Duration | Start | Finish | Predecessors | Total float |
| --- | --- | --- | --- | --- | --- | --- |
| 1 | Planning Stage | 6w | 2025-04-07 | 2025-05-16 |  | 0d |
| 2 | Footings | 3d | 2025-05-19 | 2025-05-21 | 1 | 0d |
| 3 | External Plumbing | 1d | 2025-05-22 | 2025-05-22 | 2 | 0d |
| 4 | Pour foundation slab | 1d | 2025-05-23 | 2025-05-23 | 3 | 0d |
| 5 | Slab down | 0d | 2025-05-24 | 2025-05-24 | 4FS+24eh | 0d |
| 6 | Erect house frame | 5d | 2025-05-26 | 2025-05-30 | 5 | 0d |
| 7 | Roofing tiles | 3d | 2025-06-02 | 2025-06-04 | 6 | 0d |
| 8 | Brick Walls | 5d | 2025-06-05 | 2025-06-11 | 7 | 0d |
| 9 | Fit Windows & Doors | 2d | 2025-06-12 | 2025-06-13 | 8 | 0d |
| 10 | Electrical Cables | 1d | 2025-06-16 | 2025-06-16 | 9 | 0d |
| 11 | Internal Plumbing | 1d | 2025-06-16 | 2025-06-16 | 10SS | 0d |
| 12 | Plaster Walls | 5d | 2025-06-17 | 2025-06-23 | 11 | 0d |
| 13 | Internal Doors and Trim | 4d | 2025-06-24 | 2025-06-27 | 12 | 0d |
| 14 | Install Kitchen | 2d | 2025-06-30 | 2025-07-01 | 13 | 0d |
| 15 | Install Bathroom | 2d | 2025-06-30 | 2025-07-01 | 14SS | 0d |
| 16 | Final Electrical Fittings | 2d | 2025-07-02 | 2025-07-03 | 15 | 0d |
| 17 | Final Plumbing Fittings | 2d | 2025-07-02 | 2025-07-03 | 16SS | 0d |
| 18 | Paint | 5d | 2025-07-04 | 2025-07-10 | 17 | 0d |
| 19 | Lock up | 0d | 2025-07-10 | 2025-07-10 | 18 | 0d |

## Version 2 (saved 2024-12-19, file Comparison Version 1.mpp)

Last finish stays 2025-07-10.

Changed:

| ID | Task | Other |
| --- | --- | --- |
| 1 | Planning Stage | baseline start 2011-04-04 → none; baseline finish 2011-05-13 → none |
| 2 | Footings | baseline start 2011-05-16 → none; baseline finish 2011-05-18 → none |
| 3 | External Plumbing | baseline start 2011-05-19 → none; baseline finish 2011-05-19 → none |
| 4 | Pour foundation slab | baseline start 2011-05-20 → none; baseline finish 2011-05-20 → none |
| 5 | Slab down | baseline start 2011-05-21 → none; baseline finish 2011-05-21 → none |
| 6 | Erect house frame | baseline start 2011-05-23 → none; baseline finish 2011-05-27 → none |
| 7 | Roofing tiles | baseline start 2011-05-30 → none; baseline finish 2011-06-01 → none |
| 8 | Brick Walls | baseline start 2011-06-02 → none; baseline finish 2011-06-08 → none |
| 9 | Fit Windows & Doors | baseline start 2011-06-09 → none; baseline finish 2011-06-10 → none |
| 10 | Electrical Cables | baseline start 2011-06-13 → none; baseline finish 2011-06-13 → none |
| 11 | Internal Plumbing | baseline start 2011-06-13 → none; baseline finish 2011-06-13 → none |
| 12 | Plaster Walls | baseline start 2011-06-14 → none; baseline finish 2011-06-20 → none |
| 13 | Internal Doors and Trim | baseline start 2011-06-21 → none; baseline finish 2011-06-24 → none |
| 14 | Install Kitchen | baseline start 2011-06-27 → none; baseline finish 2011-06-28 → none |
| 15 | Install Bathroom | baseline start 2011-06-27 → none; baseline finish 2011-06-28 → none |
| 16 | Final Electrical Fittings | baseline start 2011-06-29 → none; baseline finish 2011-06-30 → none |
| 17 | Final Plumbing Fittings | baseline start 2011-06-29 → none; baseline finish 2011-06-30 → none |
| 18 | Paint | baseline start 2011-07-01 → none; baseline finish 2011-07-07 → none |
| 19 | Lock up | baseline start 2011-07-07 → none; baseline finish 2011-07-07 → none |

## Version 3 (saved 2024-12-19, file Project A.mpp)

Last finish 2025-07-10 → 2025-07-03 (-7d).

Added:

| ID | Task | Duration | Start | Finish | Predecessors |
| --- | --- | --- | --- | --- | --- |
| 1 | Architectural Plans | 2w | 2025-04-07 | 2025-04-18 |  |
| 2 | Council approval | 1d | 2025-04-21 | 2025-04-21 | 1 |
| 3 | Site preparation | 3d | 2025-05-12 | 2025-05-14 | 2FS+14d |

Removed: 5 Slab down; 19 Lock up

Changed:

| ID | Task | Start | Finish | Duration | Total float | Predecessors | Other |
| --- | --- | --- | --- | --- | --- | --- | --- |
| 4 | Delivery of Materials | 2025-04-07 → 2025-05-12 (+35d) | 2025-05-16 → 2025-05-12 (-4d) | 6w → 1d | 0d → 38d | none → 3SS | was named Planning Stage; resources Architect → none |
| 5 | Lay Foundations | 2025-05-19 → 2025-05-15 (-4d) | 2025-05-21 → 2025-05-16 (-5d) | 3d → 2d |  | 4 → 3 | was named Footings; resources Concrete subcontractor → none |
| 6 | External Plumbing | 2025-05-22 → 2025-05-19 (-3d) | 2025-05-22 → 2025-05-19 (-3d) |  |  |  | resources Plumbing subcontractor → none |
| 7 | Pour foundation slab | 2025-05-23 → 2025-05-20 (-3d) | 2025-05-23 → 2025-05-20 (-3d) |  |  |  | resources Concrete subcontractor → none |
| 8 | Erect house frame | 2025-05-26 → 2025-05-21 (-5d) | 2025-05-30 → 2025-05-23 (-7d) | 5d → 3d |  | Slab down → 7 | resources Carpenters [300%]; Labourers [200%] → none |
| 9 | Roofing tiles | 2025-06-02 → 2025-05-26 (-7d) | 2025-06-04 → 2025-05-28 (-7d) |  |  |  | resources Roofing subcontractor → none |
| 10 | Brick Walls | 2025-06-05 → 2025-05-29 (-7d) | 2025-06-11 → 2025-06-04 (-7d) |  |  |  | resources Bricklayers [300%] → none |
| 11 | Fit Windows & Doors | 2025-06-12 → 2025-06-05 (-7d) | 2025-06-13 → 2025-06-06 (-7d) |  |  |  | resources Carpenters → none |
| 12 | Electrical Cables | 2025-06-16 → 2025-06-09 (-7d) | 2025-06-16 → 2025-06-09 (-7d) |  |  |  | resources Electrician → none |
| 13 | Internal Plumbing | 2025-06-16 → 2025-06-09 (-7d) | 2025-06-16 → 2025-06-09 (-7d) |  |  |  | resources Plumbing subcontractor → none |
| 14 | Plaster Walls | 2025-06-17 → 2025-06-10 (-7d) | 2025-06-23 → 2025-06-16 (-7d) |  |  |  | resources Plasterer → none |
| 15 | Internal Doors and Trim | 2025-06-24 → 2025-06-17 (-7d) | 2025-06-27 → 2025-06-20 (-7d) |  |  |  | resources Carpenters → none |
| 16 | Install Kitchen | 2025-06-30 → 2025-06-23 (-7d) | 2025-07-01 → 2025-06-24 (-7d) |  |  |  | resources Cabinetmaker [200%]; Plumber → none |
| 17 | Install Bathroom | 2025-06-30 → 2025-06-23 (-7d) | 2025-07-01 → 2025-06-24 (-7d) |  |  |  | resources Plumber; Tiler → none |
| 18 | Final Electrical Fittings | 2025-07-02 → 2025-06-25 (-7d) | 2025-07-03 → 2025-06-26 (-7d) |  |  |  | resources Electrician → none |
| 19 | Final Plumbing Fittings | 2025-07-02 → 2025-06-25 (-7d) | 2025-07-03 → 2025-06-26 (-7d) |  |  |  | resources Plumber → none |
| 20 | Paint | 2025-07-04 → 2025-06-27 (-7d) | 2025-07-10 → 2025-07-03 (-7d) |  |  |  | resources Painters [200%] → none |

## Version 4 (saved 2024-12-19, file Project B.mpp)

Last finish 2025-07-03 → 2025-07-10 (+7d).

Changed:

| ID | Task | Start | Finish |
| --- | --- | --- | --- |
| 1 | Architectural Plans | 2025-04-07 → 2025-04-14 (+7d) | 2025-04-18 → 2025-04-25 (+7d) |
| 2 | Council approval | 2025-04-21 → 2025-04-28 (+7d) | 2025-04-21 → 2025-04-28 (+7d) |
| 3 | Site preparation | 2025-05-12 → 2025-05-19 (+7d) | 2025-05-14 → 2025-05-21 (+7d) |
| 4 | Delivery of Materials | 2025-05-12 → 2025-05-19 (+7d) | 2025-05-12 → 2025-05-19 (+7d) |
| 5 | Lay Foundations | 2025-05-15 → 2025-05-22 (+7d) | 2025-05-16 → 2025-05-23 (+7d) |
| 6 | External Plumbing | 2025-05-19 → 2025-05-26 (+7d) | 2025-05-19 → 2025-05-26 (+7d) |
| 7 | Pour foundation slab | 2025-05-20 → 2025-05-27 (+7d) | 2025-05-20 → 2025-05-27 (+7d) |
| 8 | Erect house frame | 2025-05-21 → 2025-05-28 (+7d) | 2025-05-23 → 2025-05-30 (+7d) |
| 9 | Roofing tiles | 2025-05-26 → 2025-06-02 (+7d) | 2025-05-28 → 2025-06-04 (+7d) |
| 10 | Brick Walls | 2025-05-29 → 2025-06-05 (+7d) | 2025-06-04 → 2025-06-11 (+7d) |
| 11 | Fit Windows & Doors | 2025-06-05 → 2025-06-12 (+7d) | 2025-06-06 → 2025-06-13 (+7d) |
| 12 | Electrical Cables | 2025-06-09 → 2025-06-16 (+7d) | 2025-06-09 → 2025-06-16 (+7d) |
| 13 | Internal Plumbing | 2025-06-09 → 2025-06-16 (+7d) | 2025-06-09 → 2025-06-16 (+7d) |
| 14 | Plaster Walls | 2025-06-10 → 2025-06-17 (+7d) | 2025-06-16 → 2025-06-23 (+7d) |
| 15 | Internal Doors and Trim | 2025-06-17 → 2025-06-24 (+7d) | 2025-06-20 → 2025-06-27 (+7d) |
| 16 | Install Kitchen | 2025-06-23 → 2025-06-30 (+7d) | 2025-06-24 → 2025-07-01 (+7d) |
| 17 | Install Bathroom | 2025-06-23 → 2025-06-30 (+7d) | 2025-06-24 → 2025-07-01 (+7d) |
| 18 | Final Electrical Fittings | 2025-06-25 → 2025-07-02 (+7d) | 2025-06-26 → 2025-07-03 (+7d) |
| 19 | Final Plumbing Fittings | 2025-06-25 → 2025-07-02 (+7d) | 2025-06-26 → 2025-07-03 (+7d) |
| 20 | Paint | 2025-06-27 → 2025-07-04 (+7d) | 2025-07-03 → 2025-07-10 (+7d) |

## Version 5 (saved 2024-12-19, file Project D.mpp)

Last finish 2025-07-10 → 2025-07-24 (+14d).

Changed:

| ID | Task | Start | Finish |
| --- | --- | --- | --- |
| 1 | Architectural Plans | 2025-04-14 → 2025-04-28 (+14d) | 2025-04-25 → 2025-05-09 (+14d) |
| 2 | Council approval | 2025-04-28 → 2025-05-12 (+14d) | 2025-04-28 → 2025-05-12 (+14d) |
| 3 | Site preparation | 2025-05-19 → 2025-06-02 (+14d) | 2025-05-21 → 2025-06-04 (+14d) |
| 4 | Delivery of Materials | 2025-05-19 → 2025-06-02 (+14d) | 2025-05-19 → 2025-06-02 (+14d) |
| 5 | Lay Foundations | 2025-05-22 → 2025-06-05 (+14d) | 2025-05-23 → 2025-06-06 (+14d) |
| 6 | External Plumbing | 2025-05-26 → 2025-06-09 (+14d) | 2025-05-26 → 2025-06-09 (+14d) |
| 7 | Pour foundation slab | 2025-05-27 → 2025-06-10 (+14d) | 2025-05-27 → 2025-06-10 (+14d) |
| 8 | Erect house frame | 2025-05-28 → 2025-06-11 (+14d) | 2025-05-30 → 2025-06-13 (+14d) |
| 9 | Roofing tiles | 2025-06-02 → 2025-06-16 (+14d) | 2025-06-04 → 2025-06-18 (+14d) |
| 10 | Brick Walls | 2025-06-05 → 2025-06-19 (+14d) | 2025-06-11 → 2025-06-25 (+14d) |
| 11 | Fit Windows & Doors | 2025-06-12 → 2025-06-26 (+14d) | 2025-06-13 → 2025-06-27 (+14d) |
| 12 | Electrical Cables | 2025-06-16 → 2025-06-30 (+14d) | 2025-06-16 → 2025-06-30 (+14d) |
| 13 | Internal Plumbing | 2025-06-16 → 2025-06-30 (+14d) | 2025-06-16 → 2025-06-30 (+14d) |
| 14 | Plaster Walls | 2025-06-17 → 2025-07-01 (+14d) | 2025-06-23 → 2025-07-07 (+14d) |
| 15 | Internal Doors and Trim | 2025-06-24 → 2025-07-08 (+14d) | 2025-06-27 → 2025-07-11 (+14d) |
| 16 | Install Kitchen | 2025-06-30 → 2025-07-14 (+14d) | 2025-07-01 → 2025-07-15 (+14d) |
| 17 | Install Bathroom | 2025-06-30 → 2025-07-14 (+14d) | 2025-07-01 → 2025-07-15 (+14d) |
| 18 | Final Electrical Fittings | 2025-07-02 → 2025-07-16 (+14d) | 2025-07-03 → 2025-07-17 (+14d) |
| 19 | Final Plumbing Fittings | 2025-07-02 → 2025-07-16 (+14d) | 2025-07-03 → 2025-07-17 (+14d) |
| 20 | Paint | 2025-07-04 → 2025-07-18 (+14d) | 2025-07-10 → 2025-07-24 (+14d) |

## Version 6 (saved 2024-12-19, file Project C.mpp)

Last finish 2025-07-24 → 2025-07-17 (-7d).

Changed:

| ID | Task | Start | Finish |
| --- | --- | --- | --- |
| 1 | Architectural Plans | 2025-04-28 → 2025-04-21 (-7d) | 2025-05-09 → 2025-05-02 (-7d) |
| 2 | Council approval | 2025-05-12 → 2025-05-05 (-7d) | 2025-05-12 → 2025-05-05 (-7d) |
| 3 | Site preparation | 2025-06-02 → 2025-05-26 (-7d) | 2025-06-04 → 2025-05-28 (-7d) |
| 4 | Delivery of Materials | 2025-06-02 → 2025-05-26 (-7d) | 2025-06-02 → 2025-05-26 (-7d) |
| 5 | Lay Foundations | 2025-06-05 → 2025-05-29 (-7d) | 2025-06-06 → 2025-05-30 (-7d) |
| 6 | External Plumbing | 2025-06-09 → 2025-06-02 (-7d) | 2025-06-09 → 2025-06-02 (-7d) |
| 7 | Pour foundation slab | 2025-06-10 → 2025-06-03 (-7d) | 2025-06-10 → 2025-06-03 (-7d) |
| 8 | Erect house frame | 2025-06-11 → 2025-06-04 (-7d) | 2025-06-13 → 2025-06-06 (-7d) |
| 9 | Roofing tiles | 2025-06-16 → 2025-06-09 (-7d) | 2025-06-18 → 2025-06-11 (-7d) |
| 10 | Brick Walls | 2025-06-19 → 2025-06-12 (-7d) | 2025-06-25 → 2025-06-18 (-7d) |
| 11 | Fit Windows & Doors | 2025-06-26 → 2025-06-19 (-7d) | 2025-06-27 → 2025-06-20 (-7d) |
| 12 | Electrical Cables | 2025-06-30 → 2025-06-23 (-7d) | 2025-06-30 → 2025-06-23 (-7d) |
| 13 | Internal Plumbing | 2025-06-30 → 2025-06-23 (-7d) | 2025-06-30 → 2025-06-23 (-7d) |
| 14 | Plaster Walls | 2025-07-01 → 2025-06-24 (-7d) | 2025-07-07 → 2025-06-30 (-7d) |
| 15 | Internal Doors and Trim | 2025-07-08 → 2025-07-01 (-7d) | 2025-07-11 → 2025-07-04 (-7d) |
| 16 | Install Kitchen | 2025-07-14 → 2025-07-07 (-7d) | 2025-07-15 → 2025-07-08 (-7d) |
| 17 | Install Bathroom | 2025-07-14 → 2025-07-07 (-7d) | 2025-07-15 → 2025-07-08 (-7d) |
| 18 | Final Electrical Fittings | 2025-07-16 → 2025-07-09 (-7d) | 2025-07-17 → 2025-07-10 (-7d) |
| 19 | Final Plumbing Fittings | 2025-07-16 → 2025-07-09 (-7d) | 2025-07-17 → 2025-07-10 (-7d) |
| 20 | Paint | 2025-07-18 → 2025-07-11 (-7d) | 2025-07-24 → 2025-07-17 (-7d) |
