# CKM Office Renovation

How a schedule from MS Project changed from version to version. A marks actual dates.

## Version 1 (saved 2024-12-19, file Advanced Tracking.mpp)

| ID | WBS | Task | Duration | Start | Finish | Predecessors | Total float | Constraint |
| --- | --- | --- | --- | --- | --- | --- | --- | --- |
| 1 | 1 | **Planning & Research** | 15.5d | 2025-04-07 | 2025-05-01 |  | 0.57d |  |
| 2 |  | Develop Requirements Documentation | 1d | 2025-04-07 | 2025-04-07 |  | 0.57d |  |
| 3 |  | Fit-Out Consultant Research | 2d | 2025-04-08 | 2025-04-09 | 2 | 0.57d |  |
| 4 |  | Telecommunications Consultant Research | 2d | 2025-04-10 | 2025-04-11 | 3 | 0.57d |  |
| 5 |  | IT Network Contractor Research | 2d | 2025-04-14 | 2025-04-15 | 4 | 0.57d |  |
| 6 |  | Building Contractors Research | 2d | 2025-04-16 | 2025-04-17 | 5 | 0.57d |  |
| 7 |  | Submit Requirements to Resources & Request Quotes | 1d | 2025-04-22 | 2025-04-22 | 6 | 0.57d |  |
| 8 |  | Quotes Received | 0.5d | 2025-05-01 | 2025-05-01 | 7FS+5d | 0.57d |  |
| 9 |  | Planning & Research Complete | 0d | 2025-05-01 | 2025-05-01 | 8 | 0.57d |  |
| 10 | 2 | **Management Approval** | 4.14d | 2025-05-01 | 2025-05-08 |  | 0.57d |  |
| 11 |  | Consolidate Quotes and develop proposal | 2d | 2025-05-01 | 2025-05-06 | 9 | 0.57d |  |
| 12 |  | Develop Project Plan & Durations | 2d | 2025-05-06 | 2025-05-08 | 11 | 0.57d |  |
| 13 |  | Submit Project Plan & Costs to Management | 1h | 2025-05-08 | 2025-05-08 | 12 | 0.57d |  |
| 14 |  | Management Approval Received | 0d | 2025-05-08 | 2025-05-08 | 13 | 0.57d |  |
| 15 | 3 | **Refit Office** | 26.36d | 2025-05-08 | 2025-06-14 |  | 0.57d |  |
| 16 |  | Appoint Resources | 1d | 2025-05-08 | 2025-05-09 | 14 | 0.57d |  |
| 17 |  | Staff Briefing | 1h | 2025-05-09 | 2025-05-09 | 16 | 0.57d |  |
| 18 | 3.3 | **Fit-Out Consultations** | 2.5d | 2025-05-09 | 2025-05-14 |  | 0.57d |  |
| 19 |  | Office Space / Structure Plan | 1d | 2025-05-09 | 2025-05-12 | 17 | 0.57d |  |
| 20 |  | Select & Order Carpet | 0.5d | 2025-05-12 | 2025-05-13 | 19 | 0.57d |  |
| 21 |  | Select & Order Paint | 0.5d | 2025-05-13 | 2025-05-13 | 20 | 0.57d |  |
| 22 |  | Select & Order Office Furniture | 0.5d | 2025-05-13 | 2025-05-14 | 21 | 0.57d |  |
| 23 | 3.4 | **Telecommuncations Consultations** | 2d | 2025-05-14 | 2025-05-16 |  | 0.57d |  |
| 24 |  | Design Telephone Access Points Map | 1d | 2025-05-14 | 2025-05-15 | 22 | 0.57d |  |
| 25 |  | Select & Order New PABX | 1d | 2025-05-15 | 2025-05-16 | 24 | 0.57d |  |
| 26 | 3.5 | **IT Networking Consultations** | 9.14d | 2025-05-16 | 2025-05-29 |  | 0.57d |  |
| 27 |  | Design Network Access Points Map | 2d | 2025-05-16 | 2025-05-20 | 25 | 0.57d |  |
| 28 |  | Select & Order New PCs | 1d | 2025-05-20 | 2025-05-21 | 27 | 0.57d |  |
| 29 |  | New PCs Arrive | 1h | 2025-05-28 | 2025-05-28 | 28FS+5d | 0.57d |  |
| 30 |  | Configure SOE on PCs | 1d | 2025-05-28 | 2025-05-29 | 29 | 0.57d |  |
| 31 | 3.6 | **Restructure Office** | 11d | 2025-05-30 | 2025-06-14 |  | 0d |  |
| 32 |  | Erect New Walls | 7h | 2025-05-30 | 2025-05-31 | 30 | 0d |  |
| 33 |  | Gyprock, Plaster & Finish | 14h | 2025-05-31 | 2025-06-05 | 32 | 0d |  |
| 34 |  | Install Network Points | 5h | 2025-06-06 | 2025-06-06 | 33FS+1d | 0.71d |  |
| 35 |  | Install Phone Connections | 2h | 2025-06-06 | 2025-06-06 | 34SS | 0.71d |  |
| 36 |  | Re-Paint | 1d | 2025-06-07 | 2025-06-07 | 35 | 0d |  |
| 37 |  | Carpet | 1d | 2025-06-10 | 2025-06-12 | 36FS+1d | 2d |  |
| 38 |  | Install New Furniture | 1d | 2025-06-12 | 2025-06-14 | 37 | 0d |  |
| 39 |  | Install New PCs | 1d | 2025-06-13 | 2025-06-14 | 38FF | 1d |  |
| 40 |  | Refit Office Complete | 0d | 2025-06-14 | 2025-06-14 | 39 | 1d |  |
| 41 | 4 | **Office Move** | 5d | 2025-06-16 | 2025-06-21 |  | 0d |  |
| 42 |  | Order packing boxes | 1h | 2025-06-16 | 2025-06-16 | 38 | 0.86d |  |
| 43 |  | Staff Pack | 1d | 2025-06-16 | 2025-06-17 | 40, 42 | 0.86d |  |
| 44 |  | Staff Move | 3d | 2025-06-17 | 2025-06-21 | 43 | 0d |  |
| 45 |  | Office Move Complete | 0d | 2025-06-21 | 2025-06-21 | 44 | 0d | finish no later than 2025-06-25 |

## Version 2 (saved 2024-12-19, file Bar Styles.mpp)

Last finish 2025-06-21 → 2025-06-05 (-16d).

Changed:

| ID | Task | Start | Finish | Duration | Total float | Predecessors | Other |
| --- | --- | --- | --- | --- | --- | --- | --- |
| 2 | Develop Requirements Documentation |  |  |  | 0.57d → -2d |  | resources Project Manager → none |
| 3 | Fit-Out Consultant Research |  |  |  | 0.57d → -2d |  | resources Project Manager → none |
| 4 | Telecommunications Consultant Research |  |  |  | 0.57d → -2d |  | resources Project Manager → none |
| 5 | IT Network Contractor Research |  |  |  | 0.57d → -2d |  | resources Project Manager → none |
| 6 | Building Contractors Research |  |  |  | 0.57d → -2d |  | resources Project Manager → none |
| 7 | Submit Requirements to Resources & Request Quotes |  |  |  | 0.57d → -2d |  | resources Project Manager → none |
| 8 | Quotes Received |  |  |  | 0.57d → -2d |  | resources Project Manager → none |
| 11 | Consolidate Quotes and develop proposal |  |  |  | 0.57d → -2d |  | resources Project Manager → none |
| 12 | Develop Project Plan & Durations |  |  |  | 0.57d → -2d |  | resources Project Manager → none |
| 13 | Submit Project Plan & Costs to Management |  |  |  | 0.57d → -2d |  | resources Management; Project Manager → none |
| 15 | **Refit Office** |  | 2025-06-14 → 2025-06-05 (-9d) | 26.36d → 20.07d | 0.57d → -2d |  |  |
| 16 | Appoint Resources |  |  |  | 0.57d → -2d |  | resources Project Manager → none |
| 17 | Staff Briefing |  |  |  | 0.57d → -2d |  | resources Project Manager; Staff [700%] → none |
| 19 | Office Space / Structure Plan |  |  |  | 0.57d → -2d |  | resources Fit-out Consultant; Project Manager → none |
| 20 | Select & Order Carpet |  |  |  | 0.57d → -2d |  | resources Fit-out Consultant; Project Manager → none |
| 21 | Select & Order Paint |  |  |  | 0.57d → -2d |  | resources Fit-out Consultant; Project Manager → none |
| 22 | Select & Order Office Furniture |  |  |  | 0.57d → -2d |  | resources Fit-out Consultant; Project Manager → none |
| 24 | Design Telephone Access Points Map |  |  |  | 0.57d → 14.43d |  | resources Project Manager; Telecommunications consultant → none |
| 25 | Select & Order New PABX |  |  |  | 0.57d → 14.43d |  | resources Project Manager → none |
| 26 | **IT Networking Consultations** | 2025-05-16 → 2025-05-14 (-2d) | 2025-05-29 → 2025-05-26 (-3d) | 9.14d → 8.14d | 0.57d → -2d |  |  |
| 27 | Design Network Access Points Map | 2025-05-16 → 2025-05-14 (-2d) | 2025-05-20 → 2025-05-15 (-5d) | 2d → 1d | 0.57d → -2d | 25 → 22 | resources IT Consultant; Project Manager → none |
| 28 | Select & Order New PCs | 2025-05-20 → 2025-05-15 (-5d) | 2025-05-21 → 2025-05-16 (-5d) |  | 0.57d → -2d |  | resources Project Manager → none |
| 29 | New PCs Arrive | 2025-05-28 → 2025-05-23 (-5d) | 2025-05-28 → 2025-05-23 (-5d) |  | 0.57d → -2d |  | resources Project Manager → none |
| 30 | Configure SOE on PCs | 2025-05-28 → 2025-05-23 (-5d) | 2025-05-29 → 2025-05-26 (-3d) |  | 0.57d → -2d |  | resources IT Consultant → none |
| 31 | **Restructure Office** | 2025-05-30 → 2025-05-26 (-4d) | 2025-06-14 → 2025-06-05 (-9d) | 11d → 8.29d | 0d → -2d |  |  |
| 32 | Erect New Walls | 2025-05-30 → 2025-05-26 (-4d) | 2025-05-31 → 2025-05-27 (-4d) |  | 0d → -2d |  | resources Carpenter [200%] → none |
| 33 | Gyprock, Plaster & Finish | 2025-05-31 → 2025-05-27 (-4d) | 2025-06-05 → 2025-05-28 (-8d) | 14h → 7h | 0d → -2d |  | resources Plasterer → none |
| 34 | Install Network Points | 2025-06-06 → 2025-05-29 (-8d) | 2025-06-06 → 2025-05-30 (-7d) |  | 0.71d → -2d |  | resources IT Consultant → none |
| 35 | Install Phone Connections | 2025-06-06 → 2025-05-29 (-8d) | 2025-06-06 → 2025-05-29 (-8d) |  | 0.71d → -2d |  | resources Telecommunications consultant → none |
| 36 | Re-Paint | 2025-06-07 → 2025-05-29 (-9d) | 2025-06-07 → 2025-05-30 (-8d) |  | 0d → -2d |  | resources Painter; Paint [100 Litre] → none |
| 37 | Carpet | 2025-06-10 → 2025-06-02 (-8d) | 2025-06-12 → 2025-06-03 (-9d) |  | 2d → -2d |  | resources Carpet Contractor; Carpet [100 Lin Metre] → none |
| 38 | Install New Furniture | 2025-06-12 → 2025-06-03 (-9d) | 2025-06-14 → 2025-06-04 (-10d) |  | 0d → -2d |  | resources Labourer → none |
| 39 | Install New PCs | 2025-06-13 → 2025-06-04 (-9d) | 2025-06-14 → 2025-06-05 (-9d) |  | 1d → -2d | 38FF → 38 | resources IT Consultant → none |
| 40 | Refit Office Complete | 2025-06-14 → 2025-06-05 (-9d) | 2025-06-14 → 2025-06-05 (-9d) |  | 1d → -2d |  |  |
| 41 | **Office Move** | 2025-06-16 → 2025-05-29 (-18d) | 2025-06-21 → 2025-06-03 (-18d) | 5d → 3d |  |  |  |
| 42 | Order packing boxes | 2025-06-16 → 2025-05-29 (-18d) | 2025-06-16 → 2025-05-29 (-18d) |  | 0.86d → none |  | resources Project Manager → none |
| 43 | Staff Pack | 2025-06-16 → 2025-05-30 (-17d) | 2025-06-17 → 2025-06-02 (-15d) |  | 0.86d → none | 40, 42 → 40 | resources Project Manager; Staff [2000%] → none |
| 44 | Staff Move | 2025-06-17 → 2025-06-02 (-15d) | 2025-06-21 → 2025-06-03 (-18d) | 3d → 1d | 0d → none |  | resources Staff [2000%]; Labourer → none |
| 45 | Office Move Complete | 2025-06-21 → 2025-06-03 (-18d) | 2025-06-21 → 2025-06-03 (-18d) |  | 0d → none |  | constraint finish no later than 2025-06-25 → none |

## Version 3 (saved 2024-12-19, file Entering Progress.mpp)

Last finish 2025-06-05 → 2025-06-23 (+18d).

Changed:

| ID | Task | Start | Finish | Duration | Total float | Predecessors | Other |
| --- | --- | --- | --- | --- | --- | --- | --- |
| 1 | **Planning & Research** |  |  |  | -2d → -2.43d |  | baseline start none → 2022-04-04; baseline finish none → 2022-04-25 |
| 2 | Develop Requirements Documentation |  |  |  | -2d → -2.43d |  | resources none → Project Manager; baseline start none → 2022-04-04; baseline finish none → 2022-04-04 |
| 3 | Fit-Out Consultant Research |  |  |  | -2d → -2.43d |  | resources none → Project Manager; baseline start none → 2022-04-05; baseline finish none → 2022-04-06 |
| 4 | Telecommunications Consultant Research |  |  |  | -2d → -2.43d |  | resources none → Project Manager; baseline start none → 2022-04-07; baseline finish none → 2022-04-08 |
| 5 | IT Network Contractor Research |  |  |  | -2d → -2.43d |  | resources none → Project Manager; baseline start none → 2022-04-11; baseline finish none → 2022-04-12 |
| 6 | Building Contractors Research |  |  |  | -2d → -2.43d |  | resources none → Project Manager; baseline start none → 2022-04-13; baseline finish none → 2022-04-14 |
| 7 | Submit Requirements to Resources & Request Quotes |  |  |  | -2d → -2.43d |  | resources none → Project Manager; baseline start none → 2022-04-15; baseline finish none → 2022-04-15 |
| 8 | Quotes Received |  |  |  | -2d → -2.43d |  | resources none → Project Manager; baseline start none → 2022-04-25; baseline finish none → 2022-04-25 |
| 9 | Planning & Research Complete |  |  |  | -2d → -2.43d |  | baseline start none → 2022-04-25; baseline finish none → 2022-04-25 |
| 10 | **Management Approval** |  |  |  | -2d → -2.43d |  | baseline start none → 2022-04-25; baseline finish none → 2022-04-29 |
| 11 | Consolidate Quotes and develop proposal |  |  |  | -2d → -2.43d |  | resources none → Project Manager; baseline start none → 2022-04-25; baseline finish none → 2022-04-27 |
| 12 | Develop Project Plan & Durations |  |  |  | -2d → -2.43d |  | resources none → Project Manager; baseline start none → 2022-04-27; baseline finish none → 2022-04-29 |
| 13 | Submit Project Plan & Costs to Management |  |  |  | -2d → -2.43d |  | resources none → Management; Project Manager; baseline start none → 2022-04-29; baseline finish none → 2022-04-29 |
| 14 | Management Approval Received |  |  |  | -2d → -2.43d |  | baseline start none → 2022-04-29; baseline finish none → 2022-04-29 |
| 15 | **Refit Office** |  | 2025-06-05 → 2025-06-16 (+11d) | 20.07d → 27.36d | -2d → -2.43d |  | baseline start none → 2022-04-29; baseline finish none → 2022-06-07 |
| 16 | Appoint Resources |  |  |  | -2d → -2.43d |  | resources none → Project Manager; baseline start none → 2022-04-29; baseline finish none → 2022-05-02 |
| 17 | Staff Briefing |  |  |  | -2d → -2.43d |  | resources none → Project Manager; Staff [700%]; baseline start none → 2022-05-02; baseline finish none → 2022-05-02 |
| 18 | **Fit-Out Consultations** |  |  |  | -2d → -2.43d |  | baseline start none → 2022-05-02; baseline finish none → 2022-05-05 |
| 19 | Office Space / Structure Plan |  |  |  | -2d → -2.43d |  | resources none → Fit-out Consultant; Project Manager; baseline start none → 2022-05-02; baseline finish none → 2022-05-03 |
| 20 | Select & Order Carpet |  |  |  | -2d → -2.43d |  | resources none → Fit-out Consultant; Project Manager; baseline start none → 2022-05-03; baseline finish none → 2022-05-04 |
| 21 | Select & Order Paint |  |  |  | -2d → -2.43d |  | resources none → Fit-out Consultant; Project Manager; baseline start none → 2022-05-04; baseline finish none → 2022-05-04 |
| 22 | Select & Order Office Furniture |  |  |  | -2d → -2.43d |  | resources none → Fit-out Consultant; Project Manager; baseline start none → 2022-05-04; baseline finish none → 2022-05-05 |
| 23 | **Telecommuncations Consultations** |  |  |  | 14.43d → -2.43d |  | baseline start none → 2022-05-05; baseline finish none → 2022-05-09 |
| 24 | Design Telephone Access Points Map |  |  |  | 14.43d → -2.43d |  | resources none → Project Manager; Telecommunications consultant; baseline start none → 2022-05-05; baseline finish none → 2022-05-06 |
| 25 | Select & Order New PABX |  |  |  | 14.43d → -2.43d |  | resources none → Project Manager; baseline start none → 2022-05-06; baseline finish none → 2022-05-09 |
| 26 | **IT Networking Consultations** | 2025-05-14 → 2025-05-16 (+2d) | 2025-05-26 → 2025-05-29 (+3d) | 8.14d → 9.14d | -2d → -2.43d |  | baseline start none → 2022-05-09; baseline finish none → 2022-05-20 |
| 27 | Design Network Access Points Map | 2025-05-14 → 2025-05-16 (+2d) | 2025-05-15 → 2025-05-20 (+5d) | 1d → 2d | -2d → -2.43d | 22 → 25 | resources none → IT Consultant; Project Manager; baseline start none → 2022-05-09; baseline finish none → 2022-05-11 |
| 28 | Select & Order New PCs | 2025-05-15 → 2025-05-20 (+5d) | 2025-05-16 → 2025-05-21 (+5d) |  | -2d → -2.43d |  | resources none → Project Manager; baseline start none → 2022-05-11; baseline finish none → 2022-05-12 |
| 29 | New PCs Arrive | 2025-05-23 → 2025-05-28 (+5d) | 2025-05-23 → 2025-05-28 (+5d) |  | -2d → -2.43d |  | resources none → Project Manager; baseline start none → 2022-05-19; baseline finish none → 2022-05-19 |
| 30 | Configure SOE on PCs | 2025-05-23 → 2025-05-28 (+5d) | 2025-05-26 → 2025-05-29 (+3d) |  | -2d → -2.43d |  | resources none → IT Consultant; baseline start none → 2022-05-19; baseline finish none → 2022-05-20 |
| 31 | **Restructure Office** | 2025-05-26 → 2025-05-30 (+4d) | 2025-06-05 → 2025-06-16 (+11d) | 8.29d → 12d | -2d → -3d |  | baseline start none → 2022-05-21; baseline finish none → 2022-06-07 |
| 32 | Erect New Walls | 2025-05-26 → 2025-05-30 (+4d) | 2025-05-27 → 2025-05-31 (+4d) |  | -2d → -3d |  | resources none → Carpenter [200%]; baseline start none → 2022-05-21; baseline finish none → 2022-05-21 |
| 33 | Gyprock, Plaster & Finish | 2025-05-27 → 2025-05-31 (+4d) | 2025-05-28 → 2025-06-05 (+8d) | 7h → 14h | -2d → -3d |  | resources none → Plasterer; baseline start none → 2022-05-23; baseline finish none → 2022-05-27 |
| 34 | Install Network Points | 2025-05-29 → 2025-06-06 (+8d) | 2025-05-30 → 2025-06-06 (+7d) |  | -2d → -2.29d |  | resources none → IT Consultant; baseline start none → 2022-05-30; baseline finish none → 2022-05-30 |
| 35 | Install Phone Connections | 2025-05-29 → 2025-06-06 (+8d) | 2025-05-29 → 2025-06-06 (+8d) |  | -2d → -2.29d |  | resources none → Telecommunications consultant; baseline start none → 2022-05-30; baseline finish none → 2022-05-30 |
| 36 | Re-Paint | 2025-05-29 → 2025-06-07 (+9d) | 2025-05-30 → 2025-06-07 (+8d) |  | -2d → -3d |  | resources none → Painter; Paint [100 Litre]; baseline start none → 2022-05-31; baseline finish none → 2022-06-02 |
| 37 | Carpet | 2025-06-02 → 2025-06-10 (+8d) | 2025-06-03 → 2025-06-12 (+9d) |  |  |  | resources none → Carpet Contractor; Carpet [100 Lin Metre]; baseline start none → 2022-06-03; baseline finish none → 2022-06-04 |
| 38 | Install New Furniture | 2025-06-03 → 2025-06-12 (+9d) | 2025-06-04 → 2025-06-14 (+10d) |  |  |  | resources none → Labourer; baseline start none → 2022-06-04; baseline finish none → 2022-06-07 |
| 39 | Install New PCs | 2025-06-04 → 2025-06-16 (+12d) | 2025-06-05 → 2025-06-16 (+11d) |  |  |  | resources none → IT Consultant; baseline start none → 2022-06-07; baseline finish none → 2022-06-07 |
| 40 | Refit Office Complete | 2025-06-05 → 2025-06-16 (+11d) | 2025-06-05 → 2025-06-16 (+11d) |  |  |  | baseline start none → 2022-06-07; baseline finish none → 2022-06-07 |
| 41 | **Office Move** | 2025-05-29 → 2025-06-16 (+18d) | 2025-06-03 → 2025-06-23 (+20d) | 3d → 5d | 0d → -1.14d |  | baseline start none → 2022-06-07; baseline finish none → 2022-06-14 |
| 42 | Order packing boxes | 2025-05-29 → 2025-06-16 (+18d) | 2025-05-29 → 2025-06-16 (+18d) |  | none → -1.14d |  | resources none → Project Manager; baseline start none → 2022-06-07; baseline finish none → 2022-06-07 |
| 43 | Staff Pack | 2025-05-30 → 2025-06-17 (+18d) | 2025-06-02 → 2025-06-17 (+15d) |  | none → -2d | 40 → 40, 42 | resources none → Project Manager; Staff [2000%]; baseline start none → 2022-06-08; baseline finish none → 2022-06-08 |
| 44 | Staff Move | 2025-06-02 → 2025-06-18 (+16d) | 2025-06-03 → 2025-06-23 (+20d) | 1d → 3.57d | none → -2d |  | resources none → Staff [2000%]; Labourer; baseline start none → 2022-06-09; baseline finish none → 2022-06-14 |
| 45 | Office Move Complete | 2025-06-03 → 2025-06-23 (+20d) | 2025-06-03 → 2025-06-23 (+20d) |  | none → 0d |  | constraint none → finish no later than 2025-06-27; baseline start none → 2022-06-14; baseline finish none → 2022-06-14 |

## Version 4 (saved 2024-12-19, file Export Mapping.mpp)

Last finish 2025-06-23 → 2025-06-06 (-17d). Complete tasks 0 → 20.

Changed:

| ID | Task | Start | Finish | Duration | Complete | Total float | Predecessors | Other |
| --- | --- | --- | --- | --- | --- | --- | --- | --- |
| 1 | **Planning & Research** | 2025-04-07 A | 2025-05-01 → 2025-04-28 A (-3d) | 15.5d → 12.5d | 0% → 100% | -2.43d → none |  | baseline start 2022-04-04 → 2025-04-07; baseline finish 2022-04-25 → 2025-04-28 |
| 2 | Develop Requirements Documentation | 2025-04-07 A | 2025-04-07 A |  | 0% → 100% | -2.43d → none |  | baseline start 2022-04-04 → 2025-04-07; baseline finish 2022-04-04 → 2025-04-07 |
| 3 | Fit-Out Consultant Research | 2025-04-08 A | 2025-04-09 A |  | 0% → 100% | -2.43d → none |  | baseline start 2022-04-05 → 2025-04-08; baseline finish 2022-04-06 → 2025-04-09 |
| 4 | Telecommunications Consultant Research | 2025-04-10 A | 2025-04-11 A |  | 0% → 100% | -2.43d → none |  | baseline start 2022-04-07 → 2025-04-10; baseline finish 2022-04-08 → 2025-04-11 |
| 5 | IT Network Contractor Research | 2025-04-14 A | 2025-04-15 A |  | 0% → 100% | -2.43d → none |  | baseline start 2022-04-11 → 2025-04-14; baseline finish 2022-04-12 → 2025-04-15 |
| 6 | Building Contractors Research | 2025-04-16 A | 2025-04-17 A |  | 0% → 100% | -2.43d → none |  | baseline start 2022-04-13 → 2025-04-16; baseline finish 2022-04-14 → 2025-04-17 |
| 7 | Submit Requirements to Resources & Request Quotes | 2025-04-22 → 2025-04-18 A (-4d) | 2025-04-22 → 2025-04-18 A (-4d) |  | 0% → 100% | -2.43d → none |  | baseline start 2022-04-15 → 2025-04-18; baseline finish 2022-04-15 → 2025-04-18 |
| 8 | Quotes Received | 2025-05-01 → 2025-04-28 A (-3d) | 2025-05-01 → 2025-04-28 A (-3d) |  | 0% → 100% | -2.43d → none |  | baseline start 2022-04-25 → 2025-04-28; baseline finish 2022-04-25 → 2025-04-28 |
| 9 | Planning & Research Complete | 2025-05-01 → 2025-04-28 A (-3d) | 2025-05-01 → 2025-04-28 A (-3d) |  | 0% → 100% | -2.43d → none |  | baseline start 2022-04-25 → 2025-04-28; baseline finish 2022-04-25 → 2025-04-28 |
| 10 | **Management Approval** | 2025-05-01 → 2025-04-28 A (-3d) | 2025-05-08 → 2025-05-02 A (-6d) |  | 0% → 100% | -2.43d → none |  | baseline start 2022-04-25 → 2025-04-28; baseline finish 2022-04-29 → 2025-05-02 |
| 11 | Consolidate Quotes and develop proposal | 2025-05-01 → 2025-04-28 A (-3d) | 2025-05-06 → 2025-04-30 A (-6d) |  | 0% → 100% | -2.43d → none |  | baseline start 2022-04-25 → 2025-04-28; baseline finish 2022-04-27 → 2025-04-30 |
| 12 | Develop Project Plan & Durations | 2025-05-06 → 2025-04-30 A (-6d) | 2025-05-08 → 2025-05-02 A (-6d) |  | 0% → 100% | -2.43d → none |  | baseline start 2022-04-27 → 2025-04-30; baseline finish 2022-04-29 → 2025-05-02 |
| 13 | Submit Project Plan & Costs to Management | 2025-05-08 → 2025-05-02 A (-6d) | 2025-05-08 → 2025-05-02 A (-6d) |  | 0% → 100% | -2.43d → none |  | resources Management; Project Manager → Project Manager; Management; baseline start 2022-04-29 → 2025-05-02; baseline finish 2022-04-29 → 2025-05-02 |
| 14 | Management Approval Received | 2025-05-08 → 2025-05-02 A (-6d) | 2025-05-08 → 2025-05-02 A (-6d) |  | 0% → 100% | -2.43d → none |  | baseline start 2022-04-29 → 2025-05-02; baseline finish 2022-04-29 → 2025-05-02 |
| 15 | **Refit Office** | 2025-05-08 → 2025-05-02 A (-6d) | 2025-06-16 → 2025-06-04 (-12d) | 27.36d → 22.36d | 0% → 37% | -2.43d → 2d |  | baseline start 2022-04-29 → 2025-05-02; baseline finish 2022-06-07 → 2025-06-04 |
| 16 | Appoint Resources | 2025-05-08 → 2025-05-02 A (-6d) | 2025-05-09 → 2025-05-05 A (-4d) |  | 0% → 100% | -2.43d → none |  | resources Project Manager → Project Manager; Admin Assistant; baseline start 2022-04-29 → 2025-05-02; baseline finish 2022-05-02 → 2025-05-05 |
| 17 | Staff Briefing | 2025-05-09 → 2025-05-05 A (-4d) | 2025-05-09 → 2025-05-05 A (-4d) |  | 0% → 100% | -2.43d → none |  | resources Project Manager; Staff [700%] → Staff [500%]; baseline start 2022-05-02 → 2025-05-05; baseline finish 2022-05-02 → 2025-05-05 |
| 18 | **Fit-Out Consultations** | 2025-05-09 → 2025-05-05 A (-4d) | 2025-05-14 → 2025-05-08 A (-6d) | 2.5d → 2.29d | 0% → 100% | -2.43d → none |  | baseline start 2022-05-02 → 2025-05-05; baseline finish 2022-05-05 → 2025-05-08 |
| 19 | Office Space / Structure Plan | 2025-05-09 → 2025-05-05 A (-4d) | 2025-05-12 → 2025-05-06 A (-6d) |  | 0% → 100% | -2.43d → none |  | resources Fit-out Consultant; Project Manager → Project Manager; Fit-out Consultant; baseline start 2022-05-02 → 2025-05-05; baseline finish 2022-05-03 → 2025-05-06 |
| 20 | Select & Order Carpet | 2025-05-12 → 2025-05-06 A (-6d) | 2025-05-13 → 2025-05-07 A (-6d) |  | 0% → 100% | -2.43d → none |  | resources Fit-out Consultant; Project Manager → Project Manager; Fit-out Consultant; baseline start 2022-05-03 → 2025-05-06; baseline finish 2022-05-04 → 2025-05-07 |
| 21 | Select & Order Paint | 2025-05-13 → 2025-05-07 A (-6d) | 2025-05-13 → 2025-05-07 A (-6d) |  | 0% → 100% | -2.43d → none |  | resources Fit-out Consultant; Project Manager → Project Manager; Fit-out Consultant; baseline start 2022-05-04 → 2025-05-07; baseline finish 2022-05-04 → 2025-05-07 |
| 22 | Select & Order Office Furniture | 2025-05-13 → 2025-05-07 A (-6d) | 2025-05-14 → 2025-05-08 A (-6d) |  | 0% → 100% | -2.43d → none |  | resources Fit-out Consultant; Project Manager → Project Manager; Fit-out Consultant; baseline start 2022-05-04 → 2025-05-07; baseline finish 2022-05-05 → 2025-05-08 |
| 23 | **Telecommuncations Consultations** | 2025-05-14 → 2025-05-08 A (-6d) | 2025-05-16 → 2025-05-09 (-7d) | 2d → 1.5d | 0% → 67% | -2.43d → 20.21d |  | baseline start 2022-05-05 → 2025-05-08; baseline finish 2022-05-09 → 2025-05-09 |
| 24 | Design Telephone Access Points Map | 2025-05-14 → 2025-05-08 A (-6d) | 2025-05-15 → 2025-05-09 A (-6d) |  | 0% → 100% | -2.43d → none |  | resources Project Manager; Telecommunications consultant → Telecommunications consultant; baseline start 2022-05-05 → 2025-05-08; baseline finish 2022-05-06 → 2025-05-09 |
| 25 | Select & Order New PABX | 2025-05-15 → 2025-05-09 (-6d) | 2025-05-16 → 2025-05-09 (-7d) | 1d → 0.5d |  | -2.43d → 20.21d |  | resources Project Manager → Telecommunications consultant; Admin Assistant; baseline start 2022-05-06 → 2025-05-09; baseline finish 2022-05-09 → 2025-05-09 |
| 26 | **IT Networking Consultations** | 2025-05-16 → 2025-05-08 A (-8d) | 2025-05-29 → 2025-05-20 (-9d) | 9.14d → 8.14d | 0% → 32% | -2.43d → 1.57d |  | baseline start 2022-05-09 → 2025-05-08; baseline finish 2022-05-20 → 2025-05-20 |
| 27 | Design Network Access Points Map | 2025-05-16 → 2025-05-08 A (-8d) | 2025-05-20 → 2025-05-09 A (-11d) | 2d → 1d | 0% → 100% | -2.43d → none | 25 → 22 | resources IT Consultant; Project Manager → IT Consultant; baseline start 2022-05-09 → 2025-05-08; baseline finish 2022-05-11 → 2025-05-09 |
| 28 | Select & Order New PCs | 2025-05-20 → 2025-05-09 (-11d) | 2025-05-21 → 2025-05-12 (-9d) |  |  | -2.43d → 1.57d |  | resources Project Manager → IT Consultant; baseline start 2022-05-11 → 2025-05-09; baseline finish 2022-05-12 → 2025-05-12 |
| 29 | New PCs Arrive | 2025-05-28 → 2025-05-19 (-9d) | 2025-05-28 → 2025-05-19 (-9d) |  |  | -2.43d → 1.57d |  | resources Project Manager → IT Consultant; baseline start 2022-05-19 → 2025-05-19; baseline finish 2022-05-19 → 2025-05-19 |
| 30 | Configure SOE on PCs | 2025-05-28 → 2025-05-19 (-9d) | 2025-05-29 → 2025-05-20 (-9d) |  |  | -2.43d → 1.57d |  | baseline start 2022-05-19 → 2025-05-19; baseline finish 2022-05-20 → 2025-05-20 |
| 31 | **Restructure Office** | 2025-05-30 → 2025-05-21 (-9d) | 2025-06-16 → 2025-06-04 (-12d) | 12d → 11d |  | -3d → 0d |  | baseline start 2022-05-21 → 2025-05-21; baseline finish 2022-06-07 → 2025-06-04 |
| 32 | Erect New Walls | 2025-05-30 → 2025-05-21 (-9d) | 2025-05-31 → 2025-05-23 (-8d) |  |  | -3d → 1d |  | resources Carpenter [200%] → Labourer; Carpenter [200%]; baseline start 2022-05-21 → 2025-05-21; baseline finish 2022-05-21 → 2025-05-23 |
| 33 | Gyprock, Plaster & Finish | 2025-05-31 → 2025-05-23 (-8d) | 2025-06-05 → 2025-05-24 (-12d) | 14h → 7h |  | -3d → 0d |  | baseline start 2022-05-23 → 2025-05-23; baseline finish 2022-05-27 → 2025-05-24 |
| 34 | Install Network Points | 2025-06-06 → 2025-05-27 (-10d) | 2025-06-06 → 2025-05-27 (-10d) |  |  | -2.29d → 0.71d |  | resources IT Consultant → Telecommunications consultant; baseline start 2022-05-30 → 2025-05-27; baseline finish 2022-05-30 → 2025-05-27 |
| 35 | Install Phone Connections | 2025-06-06 → 2025-05-27 (-10d) | 2025-06-06 → 2025-05-27 (-10d) |  |  | -2.29d → 0.71d |  | baseline start 2022-05-30 → 2025-05-27; baseline finish 2022-05-30 → 2025-05-27 |
| 36 | Re-Paint | 2025-06-07 → 2025-05-28 (-10d) | 2025-06-07 → 2025-05-30 (-8d) |  |  | -3d → 0d |  | resources Painter; Paint [100 Litre] → Painter; baseline start 2022-05-31 → 2025-05-28; baseline finish 2022-06-02 → 2025-05-30 |
| 37 | Carpet | 2025-06-10 → 2025-05-31 (-10d) | 2025-06-12 → 2025-05-31 (-12d) |  |  | -2d → 0d |  | resources Carpet Contractor; Carpet [100 Lin Metre] → Carpet Contractor; baseline start 2022-06-03 → 2025-05-31; baseline finish 2022-06-04 → 2025-05-31 |
| 38 | Install New Furniture | 2025-06-12 → 2025-06-02 (-10d) | 2025-06-14 → 2025-06-04 (-10d) |  |  | -2d → 0d |  | baseline start 2022-06-04 → 2025-06-02; baseline finish 2022-06-07 → 2025-06-04 |
| 39 | Install New PCs | 2025-06-16 → 2025-06-04 (-12d) | 2025-06-16 → 2025-06-04 (-12d) |  |  | -2d → 0d |  | baseline start 2022-06-07 → 2025-06-04; baseline finish 2022-06-07 → 2025-06-04 |
| 40 | Refit Office Complete | 2025-06-16 → 2025-06-04 (-12d) | 2025-06-16 → 2025-06-04 (-12d) |  |  | -2d → 0d |  | baseline start 2022-06-07 → 2025-06-04; baseline finish 2022-06-07 → 2025-06-04 |
| 41 | **Office Move** | 2025-06-16 → 2025-06-04 (-12d) | 2025-06-23 → 2025-06-06 (-17d) | 5d → 3d |  | -1.14d → 0d |  | baseline start 2022-06-07 → 2025-06-04; baseline finish 2022-06-14 → 2025-06-06 |
| 42 | Order packing boxes | 2025-06-16 → 2025-06-04 (-12d) | 2025-06-16 → 2025-06-04 (-12d) |  |  | -1.14d → 2.86d |  | resources Project Manager → Admin Assistant; baseline start 2022-06-07 → 2025-06-04; baseline finish 2022-06-07 → 2025-06-04 |
| 43 | Staff Pack | 2025-06-17 → 2025-06-05 (-12d) | 2025-06-17 → 2025-06-05 (-12d) |  |  | -2d → 0d | 40, 42 → 40 | resources Project Manager; Staff [2000%] → Staff [1000%]; baseline start 2022-06-08 → 2025-06-05; baseline finish 2022-06-08 → 2025-06-05 |
| 44 | Staff Move | 2025-06-18 → 2025-06-06 (-12d) | 2025-06-23 → 2025-06-06 (-17d) | 3.57d → 1d |  | -2d → 0d |  | resources Staff [2000%]; Labourer → Staff [1000%]; baseline start 2022-06-09 → 2025-06-06; baseline finish 2022-06-14 → 2025-06-06 |
| 45 | Office Move Complete | 2025-06-23 → 2025-06-06 (-17d) | 2025-06-23 → 2025-06-06 (-17d) |  |  |  |  | constraint finish no later than 2025-06-27 → none; baseline start 2022-06-14 → 2025-06-06; baseline finish 2022-06-14 → 2025-06-06 |

## Version 5 (saved 2024-12-19, file Filters.mpp)

Last finish 2025-06-06 → 2025-05-22 (-15d). Complete tasks 20 → 33.

Changed:

| ID | Task | Start | Finish | Duration | Complete | Total float | Predecessors | Other |
| --- | --- | --- | --- | --- | --- | --- | --- | --- |
| 1 | **Planning & Research** | 2025-04-07 A → 2025-04-07 09:00 A | 2025-04-28 A → 2025-04-17 12:00 A (-11d) | 12.5d → 8.43d |  |  |  | baseline start 2025-04-07 → 2025-04-07 09:00; baseline finish 2025-04-28 → 2025-04-17 12:00 |
| 2 | Develop Requirements Documentation | 2025-04-07 A → 2025-04-07 09:00 A | 2025-04-07 A → 2025-04-07 17:00 A |  |  |  |  | baseline start 2025-04-07 → 2025-04-07 09:00; baseline finish 2025-04-07 → 2025-04-07 17:00 |
| 3 | Fit-Out Consultant Research | 2025-04-08 A → 2025-04-08 09:00 A | 2025-04-09 A → 2025-04-08 12:30 A (-1d) | 2d → 0.5d |  |  |  | baseline start 2025-04-08 → 2025-04-08 09:00; baseline finish 2025-04-09 → 2025-04-08 12:30 |
| 4 | Telecommunications Consultant Research | 2025-04-10 A → 2025-04-08 12:30 A (-2d) | 2025-04-11 A → 2025-04-08 17:00 A (-3d) | 2d → 0.5d |  |  |  | baseline start 2025-04-10 → 2025-04-08 12:30; baseline finish 2025-04-11 → 2025-04-08 17:00 |
| 5 | IT Network Contractor Research | 2025-04-14 A → 2025-04-09 09:00 A (-5d) | 2025-04-15 A → 2025-04-09 12:30 A (-6d) | 2d → 0.5d |  |  |  | baseline start 2025-04-14 → 2025-04-09 09:00; baseline finish 2025-04-15 → 2025-04-09 12:30 |
| 6 | Building Contractors Research | 2025-04-16 A → 2025-04-09 12:30 A (-7d) | 2025-04-17 A → 2025-04-09 17:00 A (-8d) | 2d → 0.5d |  |  |  | baseline start 2025-04-16 → 2025-04-09 12:30; baseline finish 2025-04-17 → 2025-04-09 17:00 |
| 7 | Submit Requirements to Resources & Request Quotes | 2025-04-18 A → 2025-04-10 09:00 A (-8d) | 2025-04-18 A → 2025-04-10 11:00 A (-8d) | 1d → 2h |  |  |  | baseline start 2025-04-18 → 2025-04-10 09:00; baseline finish 2025-04-18 → 2025-04-10 11:00 |
| 8 | Quotes Received | 2025-04-28 A → 2025-04-17 11:00 A (-11d) | 2025-04-28 A → 2025-04-17 12:00 A (-11d) | 0.5d → 1h |  |  |  | baseline start 2025-04-28 → 2025-04-17 11:00; baseline finish 2025-04-28 → 2025-04-17 12:00 |
| 9 | Planning & Research Complete | 2025-04-28 A → 2025-04-17 12:00 A (-11d) | 2025-04-28 A → 2025-04-17 12:00 A (-11d) |  |  |  |  | baseline start 2025-04-28 → 2025-04-17 12:00; baseline finish 2025-04-28 → 2025-04-17 12:00 |
| 10 | **Management Approval** | 2025-04-28 A → 2025-04-17 12:00 A (-11d) | 2025-05-02 A → 2025-04-23 10:30 A (-9d) | 4.14d → 1.79d |  |  |  | baseline start 2025-04-28 → 2025-04-17 12:00; baseline finish 2025-05-02 → 2025-04-23 10:30 |
| 11 | Consolidate Quotes and develop proposal | 2025-04-28 A → 2025-04-17 12:00 A (-11d) | 2025-04-30 A → 2025-04-22 16:30 A (-8d) | 2d → 1.5d |  |  |  | baseline start 2025-04-28 → 2025-04-17 12:00; baseline finish 2025-04-30 → 2025-04-22 16:30 |
| 12 | Develop Project Plan & Durations | 2025-04-30 A → 2025-04-22 16:30 A (-8d) | 2025-05-02 A → 2025-04-23 09:30 A (-9d) | 2d → 1h |  |  |  | baseline start 2025-04-30 → 2025-04-22 16:30; baseline finish 2025-05-02 → 2025-04-23 09:30 |
| 13 | Submit Project Plan & Costs to Management | 2025-05-02 A → 2025-04-23 09:30 A (-9d) | 2025-05-02 A → 2025-04-23 10:30 A (-9d) |  |  |  |  | baseline start 2025-05-02 → 2025-04-23 09:30; baseline finish 2025-05-02 → 2025-04-23 10:30 |
| 14 | Management Approval Received | 2025-05-02 A → 2025-04-23 10:30 A (-9d) | 2025-05-02 A → 2025-04-23 10:30 A (-9d) |  |  |  |  | baseline start 2025-05-02 → 2025-04-23 10:30; baseline finish 2025-05-02 → 2025-04-23 10:30 |
| 15 | **Refit Office** | 2025-05-02 A → 2025-04-23 10:30 A (-9d) | 2025-06-04 → 2025-05-16 17:00 A (-19d) | 22.36d → 15.79d | 37% → 100% | 2d → none |  | baseline start 2025-05-02 → 2025-04-23 10:30; baseline finish 2025-06-04 → 2025-05-16 17:00 |
| 16 | Appoint Resources | 2025-05-02 A → 2025-04-23 10:30 A (-9d) | 2025-05-05 A → 2025-04-23 12:30 A (-12d) | 1d → 2h |  |  |  | resources Project Manager; Admin Assistant → Project Manager; baseline start 2025-05-02 → 2025-04-23 10:30; baseline finish 2025-05-05 → 2025-04-23 12:30 |
| 17 | Staff Briefing | 2025-05-05 A → 2025-04-23 12:30 A (-12d) | 2025-05-05 A → 2025-04-23 14:30 A (-12d) |  |  |  |  | resources Staff [500%] → Project Manager; Staff [700%]; baseline start 2025-05-05 → 2025-04-23 12:30; baseline finish 2025-05-05 → 2025-04-23 14:30 |
| 18 | **Fit-Out Consultations** | 2025-05-05 A → 2025-04-23 14:30 A (-12d) | 2025-05-08 A → 2025-04-24 13:00 A (-14d) | 2.29d → 0.93d |  |  |  | baseline start 2025-05-05 → 2025-04-23 14:30; baseline finish 2025-05-08 → 2025-04-24 13:00 |
| 19 | Office Space / Structure Plan | 2025-05-05 A → 2025-04-23 14:30 A (-12d) | 2025-05-06 A → 2025-04-24 10:00 A (-12d) | 1d → 0.5d |  |  |  | resources Project Manager; Fit-out Consultant → Fit-out Consultant; Project Manager; baseline start 2025-05-05 → 2025-04-23 14:30; baseline finish 2025-05-06 → 2025-04-24 10:00 |
| 20 | Select & Order Carpet | 2025-05-06 A → 2025-04-24 10:00 A (-12d) | 2025-05-07 A → 2025-04-24 11:00 A (-13d) | 0.5d → 1h |  |  |  | resources Project Manager; Fit-out Consultant → Fit-out Consultant; Project Manager; baseline start 2025-05-06 → 2025-04-24 10:00; baseline finish 2025-05-07 → 2025-04-24 11:00 |
| 21 | Select & Order Paint | 2025-05-07 A → 2025-04-24 11:00 A (-13d) | 2025-05-07 A → 2025-04-24 12:00 A (-13d) | 0.5d → 1h |  |  |  | resources Project Manager; Fit-out Consultant → Fit-out Consultant; Project Manager; baseline start 2025-05-07 → 2025-04-24 11:00; baseline finish 2025-05-07 → 2025-04-24 12:00 |
| 22 | Select & Order Office Furniture | 2025-05-07 A → 2025-04-24 12:00 A (-13d) | 2025-05-08 A → 2025-04-24 13:00 A (-14d) | 0.5d → 1h |  |  |  | resources Project Manager; Fit-out Consultant → Fit-out Consultant; Project Manager; baseline start 2025-05-07 → 2025-04-24 12:00; baseline finish 2025-05-08 → 2025-04-24 13:00 |
| 23 | **Telecommuncations Consultations** | 2025-05-08 A → 2025-04-24 14:00 A (-14d) | 2025-05-09 → 2025-04-28 10:30 A (-11d) | 1.5d → 0.64d | 67% → 100% | 20.21d → none |  | baseline start 2025-05-08 → 2025-04-24 14:00; baseline finish 2025-05-09 → 2025-04-28 10:30 |
| 24 | Design Telephone Access Points Map | 2025-05-08 A → 2025-04-24 14:00 A (-14d) | 2025-05-09 A → 2025-04-28 09:30 A (-11d) | 1d → 0.5d |  |  |  | resources Telecommunications consultant → Project Manager; Telecommunications consultant; baseline start 2025-05-08 → 2025-04-24 14:00; baseline finish 2025-05-09 → 2025-04-28 09:30 |
| 25 | Select & Order New PABX | 2025-05-09 → 2025-04-28 09:30 A (-11d) | 2025-05-09 → 2025-04-28 10:30 A (-11d) | 0.5d → 1h | 0% → 100% | 20.21d → none |  | resources Telecommunications consultant; Admin Assistant → Project Manager; baseline start 2025-05-09 → 2025-04-28 09:30; baseline finish 2025-05-09 → 2025-04-28 10:30 |
| 26 | **IT Networking Consultations** | 2025-05-08 A → 2025-04-28 10:30 A (-10d) | 2025-05-20 → 2025-05-07 17:00 A (-13d) | 8.14d → 6.79d | 32% → 100% | 1.57d → none |  | baseline start 2025-05-08 → 2025-04-28 10:30; baseline finish 2025-05-20 → 2025-05-07 17:00 |
| 27 | Design Network Access Points Map | 2025-05-08 A → 2025-04-28 10:30 A (-10d) | 2025-05-09 A → 2025-04-28 15:00 A (-11d) | 1d → 0.5d |  |  | 22 → 22, 25 | resources IT Consultant → IT Consultant; Project Manager; baseline start 2025-05-08 → 2025-04-28 10:30; baseline finish 2025-05-09 → 2025-04-28 15:00 |
| 28 | Select & Order New PCs | 2025-05-09 → 2025-04-28 15:00 A (-11d) | 2025-05-12 → 2025-04-28 16:00 A (-14d) | 1d → 1h | 0% → 100% | 1.57d → none |  | resources IT Consultant → Project Manager; baseline start 2025-05-09 → 2025-04-28 15:00; baseline finish 2025-05-12 → 2025-04-28 16:00 |
| 29 | New PCs Arrive | 2025-05-19 → 2025-05-06 16:00 A (-13d) | 2025-05-19 → 2025-05-06 17:00 A (-13d) |  | 0% → 100% | 1.57d → none |  | resources IT Consultant → Project Manager; baseline start 2025-05-19 → 2025-05-06 16:00; baseline finish 2025-05-19 → 2025-05-06 17:00 |
| 30 | Configure SOE on PCs | 2025-05-19 → 2025-05-07 09:00 A (-12d) | 2025-05-20 → 2025-05-07 17:00 A (-13d) |  | 0% → 100% | 1.57d → none |  | baseline start 2025-05-19 → 2025-05-07 09:00; baseline finish 2025-05-20 → 2025-05-07 17:00 |
| 31 | **Restructure Office** | 2025-05-21 → 2025-04-25 06:00 A (-26d) | 2025-06-04 → 2025-05-16 17:00 A (-19d) | 11d → 14d | 0% → 100% | 0d → none |  | baseline start 2025-05-21 → 2025-04-25 06:00; baseline finish 2025-06-04 → 2025-05-16 17:00 |
| 32 | Erect New Walls | 2025-05-21 → 2025-04-25 06:00 A (-26d) | 2025-05-23 → 2025-04-26 11:00 A (-27d) |  | 0% → 100% | 1d → none | 30 → 22 | resources Labourer; Carpenter [200%] → Carpenter [200%]; baseline start 2025-05-21 → 2025-04-25 06:00; baseline finish 2025-05-23 → 2025-04-26 11:00 |
| 33 | Gyprock, Plaster & Finish | 2025-05-23 → 2025-04-26 12:00 A (-27d) | 2025-05-24 → 2025-05-01 08:00 A (-23d) | 7h → 14h | 0% → 100% | 0d → none |  | baseline start 2025-05-23 → 2025-04-26 12:00; baseline finish 2025-05-24 → 2025-05-01 08:00 |
| 34 | Install Network Points | 2025-05-27 → 2025-05-08 09:00 A (-19d) | 2025-05-27 → 2025-05-08 15:00 A (-19d) |  | 0% → 100% | 0.71d → none | 33FS+1d → 33FS+1ed, 30 | resources Telecommunications consultant → IT Consultant; baseline start 2025-05-27 → 2025-05-08 09:00; baseline finish 2025-05-27 → 2025-05-08 15:00 |
| 35 | Install Phone Connections | 2025-05-27 → 2025-05-08 09:00 A (-19d) | 2025-05-27 → 2025-05-08 12:30 A (-19d) | 2h → 0.5d | 0% → 100% | 0.71d → none |  | baseline start 2025-05-27 → 2025-05-08 09:00; baseline finish 2025-05-27 → 2025-05-08 12:30 |
| 36 | Re-Paint | 2025-05-28 → 2025-05-09 06:00 A (-19d) | 2025-05-30 → 2025-05-10 11:00 A (-20d) |  | 0% → 100% | 0d → none |  | resources Painter → Paint [100 Litre]; Painter; baseline start 2025-05-28 → 2025-05-09 06:00; baseline finish 2025-05-30 → 2025-05-10 11:00 |
| 37 | Carpet | 2025-05-31 → 2025-05-12 06:00 A (-19d) | 2025-05-31 → 2025-05-14 07:00 A (-17d) |  | 0% → 100% | 0d → none | 36FS+1d → 36FS+1ed | resources Carpet Contractor → Carpet [100 Lin Metre]; Carpet Contractor; baseline start 2025-05-31 → 2025-05-12 06:00; baseline finish 2025-05-31 → 2025-05-14 07:00 |
| 38 | Install New Furniture | 2025-06-02 → 2025-05-14 07:00 A (-19d) | 2025-06-04 → 2025-05-16 08:00 A (-19d) |  | 0% → 100% | 0d → none |  | baseline start 2025-06-02 → 2025-05-14 07:00; baseline finish 2025-06-04 → 2025-05-16 08:00 |
| 39 | Install New PCs | 2025-06-04 → 2025-05-16 09:00 A (-19d) | 2025-06-04 → 2025-05-16 17:00 A (-19d) |  | 0% → 100% | 0d → none |  | baseline start 2025-06-04 → 2025-05-16 09:00; baseline finish 2025-06-04 → 2025-05-16 17:00 |
| 40 | Refit Office Complete | 2025-06-04 → 2025-05-16 17:00 A (-19d) | 2025-06-04 → 2025-05-16 17:00 A (-19d) |  | 0% → 100% | 0d → none |  | baseline start 2025-06-04 → 2025-05-16 17:00; baseline finish 2025-06-04 → 2025-05-16 17:00 |
| 41 | **Office Move** | 2025-06-04 → 2025-05-07 09:00 (-28d) | 2025-06-06 → 2025-05-22 07:00 (-15d) | 3d → 11d |  |  |  | baseline start 2025-06-04 → 2025-05-07 09:00; baseline finish 2025-06-06 → 2025-05-22 07:00 |
| 42 | Order packing boxes | 2025-06-04 → 2025-05-07 09:00 (-28d) | 2025-06-04 → 2025-05-07 10:00 (-28d) |  |  | 2.86d → 8.36d | 38 → 29 | resources Admin Assistant → Project Manager; baseline start 2025-06-04 → 2025-05-07 09:00; baseline finish 2025-06-04 → 2025-05-07 10:00 |
| 43 | Staff Pack | 2025-06-05 → 2025-05-19 09:00 (-17d) | 2025-06-05 → 2025-05-19 12:30 (-17d) | 1d → 0.5d |  | 0d → 0.5d | 40 → 40, 42 | resources Staff [1000%] → Project Manager; Staff [2000%]; baseline start 2025-06-05 → 2025-05-19 09:00; baseline finish 2025-06-05 → 2025-05-19 12:30 |
| 44 | Staff Move | 2025-06-06 → 2025-05-19 12:30 (-18d) | 2025-06-06 → 2025-05-22 07:00 (-15d) | 1d → 2d |  |  |  | resources Staff [1000%] → Staff [2000%]; Labourer; baseline start 2025-06-06 → 2025-05-19 12:30; baseline finish 2025-06-06 → 2025-05-22 07:00 |
| 45 | Office Move Complete | 2025-06-06 → 2025-05-22 07:00 (-15d) | 2025-06-06 → 2025-05-22 07:00 (-15d) |  |  |  |  | baseline start 2025-06-06 → 2025-05-22 07:00; baseline finish 2025-06-06 → 2025-05-22 07:00 |

## Version 6 (saved 2024-12-19, file Office Renovation Cost Resources.mpp)

Last finish stays 2025-05-22. Complete tasks 33 → 0.

Changed:

| ID | Task | Start | Finish | Complete | Total float | Other |
| --- | --- | --- | --- | --- | --- | --- |
| 1 | **Planning & Research** | 2025-04-07 09:00 A → 2025-04-07 09:00 | 2025-04-17 12:00 A → 2025-04-17 12:00 | 100% → 0% | none → 1.5d | baseline start 2025-04-07 09:00 → none; baseline finish 2025-04-17 12:00 → none |
| 2 | Develop Requirements Documentation | 2025-04-07 09:00 A → 2025-04-07 09:00 | 2025-04-07 17:00 A → 2025-04-07 17:00 | 100% → 0% | none → 1.5d | baseline start 2025-04-07 09:00 → none; baseline finish 2025-04-07 17:00 → none |
| 3 | Fit-Out Consultant Research | 2025-04-08 09:00 A → 2025-04-08 09:00 | 2025-04-08 12:30 A → 2025-04-08 12:30 | 100% → 0% | none → 1.5d | baseline start 2025-04-08 09:00 → none; baseline finish 2025-04-08 12:30 → none |
| 4 | Telecommunications Consultant Research | 2025-04-08 12:30 A → 2025-04-08 12:30 | 2025-04-08 17:00 A → 2025-04-08 17:00 | 100% → 0% | none → 1.5d | baseline start 2025-04-08 12:30 → none; baseline finish 2025-04-08 17:00 → none |
| 5 | IT Network Contractor Research | 2025-04-09 09:00 A → 2025-04-09 09:00 | 2025-04-09 12:30 A → 2025-04-09 12:30 | 100% → 0% | none → 1.5d | baseline start 2025-04-09 09:00 → none; baseline finish 2025-04-09 12:30 → none |
| 6 | Building Contractors Research | 2025-04-09 12:30 A → 2025-04-09 12:30 | 2025-04-09 17:00 A → 2025-04-09 17:00 | 100% → 0% | none → 1.5d | baseline start 2025-04-09 12:30 → none; baseline finish 2025-04-09 17:00 → none |
| 7 | Submit Requirements to Resources & Request Quotes | 2025-04-10 09:00 A → 2025-04-10 09:00 | 2025-04-10 11:00 A → 2025-04-10 11:00 | 100% → 0% | none → 1.5d | baseline start 2025-04-10 09:00 → none; baseline finish 2025-04-10 11:00 → none |
| 8 | Quotes Received | 2025-04-17 11:00 A → 2025-04-17 11:00 | 2025-04-17 12:00 A → 2025-04-17 12:00 | 100% → 0% | none → 1.5d | baseline start 2025-04-17 11:00 → none; baseline finish 2025-04-17 12:00 → none |
| 9 | Planning & Research Complete | 2025-04-17 12:00 A → 2025-04-17 12:00 | 2025-04-17 12:00 A → 2025-04-17 12:00 | 100% → 0% | none → 1.5d | baseline start 2025-04-17 12:00 → none; baseline finish 2025-04-17 12:00 → none |
| 10 | **Management Approval** | 2025-04-17 12:00 A → 2025-04-17 12:00 | 2025-04-23 10:30 A → 2025-04-23 10:30 | 100% → 0% | none → 1.5d | baseline start 2025-04-17 12:00 → none; baseline finish 2025-04-23 10:30 → none |
| 11 | Consolidate Quotes and develop proposal | 2025-04-17 12:00 A → 2025-04-17 12:00 | 2025-04-22 16:30 A → 2025-04-22 16:30 | 100% → 0% | none → 1.5d | baseline start 2025-04-17 12:00 → none; baseline finish 2025-04-22 16:30 → none |
| 12 | Develop Project Plan & Durations | 2025-04-22 16:30 A → 2025-04-22 16:30 | 2025-04-23 09:30 A → 2025-04-23 09:30 | 100% → 0% | none → 1.5d | baseline start 2025-04-22 16:30 → none; baseline finish 2025-04-23 09:30 → none |
| 13 | Submit Project Plan & Costs to Management | 2025-04-23 09:30 A → 2025-04-23 09:30 | 2025-04-23 10:30 A → 2025-04-23 10:30 | 100% → 0% | none → 1.5d | baseline start 2025-04-23 09:30 → none; baseline finish 2025-04-23 10:30 → none |
| 14 | Management Approval Received | 2025-04-23 10:30 A → 2025-04-23 10:30 | 2025-04-23 10:30 A → 2025-04-23 10:30 | 100% → 0% | none → 1.5d | baseline start 2025-04-23 10:30 → none; baseline finish 2025-04-23 10:30 → none |
| 15 | **Refit Office** | 2025-04-23 10:30 A → 2025-04-23 10:30 | 2025-05-16 17:00 A → 2025-05-16 17:00 | 100% → 0% | none → 0.5d | baseline start 2025-04-23 10:30 → none; baseline finish 2025-05-16 17:00 → none |
| 16 | Appoint Resources | 2025-04-23 10:30 A → 2025-04-23 10:30 | 2025-04-23 12:30 A → 2025-04-23 12:30 | 100% → 0% | none → 1.5d | baseline start 2025-04-23 10:30 → none; baseline finish 2025-04-23 12:30 → none |
| 17 | Staff Briefing | 2025-04-23 12:30 A → 2025-04-23 12:30 | 2025-04-23 14:30 A → 2025-04-23 14:30 | 100% → 0% | none → 1.5d | baseline start 2025-04-23 12:30 → none; baseline finish 2025-04-23 14:30 → none |
| 18 | **Fit-Out Consultations** | 2025-04-23 14:30 A → 2025-04-23 14:30 | 2025-04-24 13:00 A → 2025-04-24 13:00 | 100% → 0% | none → 1.5d | baseline start 2025-04-23 14:30 → none; baseline finish 2025-04-24 13:00 → none |
| 19 | Office Space / Structure Plan | 2025-04-23 14:30 A → 2025-04-23 14:30 | 2025-04-24 10:00 A → 2025-04-24 10:00 | 100% → 0% | none → 1.5d | baseline start 2025-04-23 14:30 → none; baseline finish 2025-04-24 10:00 → none |
| 20 | Select & Order Carpet | 2025-04-24 10:00 A → 2025-04-24 10:00 | 2025-04-24 11:00 A → 2025-04-24 11:00 | 100% → 0% | none → 1.5d | baseline start 2025-04-24 10:00 → none; baseline finish 2025-04-24 11:00 → none |
| 21 | Select & Order Paint | 2025-04-24 11:00 A → 2025-04-24 11:00 | 2025-04-24 12:00 A → 2025-04-24 12:00 | 100% → 0% | none → 1.5d | baseline start 2025-04-24 11:00 → none; baseline finish 2025-04-24 12:00 → none |
| 22 | Select & Order Office Furniture | 2025-04-24 12:00 A → 2025-04-24 12:00 | 2025-04-24 13:00 A → 2025-04-24 13:00 | 100% → 0% | none → 1.5d | baseline start 2025-04-24 12:00 → none; baseline finish 2025-04-24 13:00 → none |
| 23 | **Telecommuncations Consultations** | 2025-04-24 14:00 A → 2025-04-24 14:00 | 2025-04-28 10:30 A → 2025-04-28 10:30 | 100% → 0% | none → 1.5d | baseline start 2025-04-24 14:00 → none; baseline finish 2025-04-28 10:30 → none |
| 24 | Design Telephone Access Points Map | 2025-04-24 14:00 A → 2025-04-24 14:00 | 2025-04-28 09:30 A → 2025-04-28 09:30 | 100% → 0% | none → 1.5d | baseline start 2025-04-24 14:00 → none; baseline finish 2025-04-28 09:30 → none |
| 25 | Select & Order New PABX | 2025-04-28 09:30 A → 2025-04-28 09:30 | 2025-04-28 10:30 A → 2025-04-28 10:30 | 100% → 0% | none → 1.5d | baseline start 2025-04-28 09:30 → none; baseline finish 2025-04-28 10:30 → none |
| 26 | **IT Networking Consultations** | 2025-04-28 10:30 A → 2025-04-28 10:30 | 2025-05-07 17:00 A → 2025-05-07 17:00 | 100% → 0% | none → 1.5d | baseline start 2025-04-28 10:30 → none; baseline finish 2025-05-07 17:00 → none |
| 27 | Design Network Access Points Map | 2025-04-28 10:30 A → 2025-04-28 10:30 | 2025-04-28 15:00 A → 2025-04-28 15:00 | 100% → 0% | none → 1.5d | baseline start 2025-04-28 10:30 → none; baseline finish 2025-04-28 15:00 → none |
| 28 | Select & Order New PCs | 2025-04-28 15:00 A → 2025-04-28 15:00 | 2025-04-28 16:00 A → 2025-04-28 16:00 | 100% → 0% | none → 1.5d | baseline start 2025-04-28 15:00 → none; baseline finish 2025-04-28 16:00 → none |
| 29 | New PCs Arrive | 2025-05-06 16:00 A → 2025-05-06 16:00 | 2025-05-06 17:00 A → 2025-05-06 17:00 | 100% → 0% | none → 1.5d | baseline start 2025-05-06 16:00 → none; baseline finish 2025-05-06 17:00 → none |
| 30 | Configure SOE on PCs | 2025-05-07 09:00 A → 2025-05-07 09:00 | 2025-05-07 17:00 A → 2025-05-07 17:00 | 100% → 0% | none → 1.5d | baseline start 2025-05-07 09:00 → none; baseline finish 2025-05-07 17:00 → none |
| 31 | **Restructure Office** | 2025-04-25 06:00 A → 2025-04-25 06:00 | 2025-05-16 17:00 A → 2025-05-16 17:00 | 100% → 0% | none → 0.5d | baseline start 2025-04-25 06:00 → none; baseline finish 2025-05-16 17:00 → none |
| 32 | Erect New Walls | 2025-04-25 06:00 A → 2025-04-25 06:00 | 2025-04-26 11:00 A → 2025-04-26 11:00 | 100% → 0% | none → 4d | baseline start 2025-04-25 06:00 → none; baseline finish 2025-04-26 11:00 → none |
| 33 | Gyprock, Plaster & Finish | 2025-04-26 12:00 A → 2025-04-26 12:00 | 2025-05-01 08:00 A → 2025-05-01 08:00 | 100% → 0% | none → 4d | baseline start 2025-04-26 12:00 → none; baseline finish 2025-05-01 08:00 → none |
| 34 | Install Network Points | 2025-05-08 09:00 A → 2025-05-08 09:00 | 2025-05-08 15:00 A → 2025-05-08 15:00 | 100% → 0% | none → 1.5d | baseline start 2025-05-08 09:00 → none; baseline finish 2025-05-08 15:00 → none |
| 35 | Install Phone Connections | 2025-05-08 09:00 A → 2025-05-08 09:00 | 2025-05-08 12:30 A → 2025-05-08 12:30 | 100% → 0% | none → 1.5d | baseline start 2025-05-08 09:00 → none; baseline finish 2025-05-08 12:30 → none |
| 36 | Re-Paint | 2025-05-09 06:00 A → 2025-05-09 06:00 | 2025-05-10 11:00 A → 2025-05-10 11:00 | 100% → 0% | none → 0d | baseline start 2025-05-09 06:00 → none; baseline finish 2025-05-10 11:00 → none |
| 37 | Carpet | 2025-05-12 06:00 A → 2025-05-12 06:00 | 2025-05-14 07:00 A → 2025-05-14 07:00 | 100% → 0% | none → 0d | baseline start 2025-05-12 06:00 → none; baseline finish 2025-05-14 07:00 → none |
| 38 | Install New Furniture | 2025-05-14 07:00 A → 2025-05-14 07:00 | 2025-05-16 08:00 A → 2025-05-16 08:00 | 100% → 0% | none → 0d | baseline start 2025-05-14 07:00 → none; baseline finish 2025-05-16 08:00 → none |
| 39 | Install New PCs | 2025-05-16 09:00 A → 2025-05-16 09:00 | 2025-05-16 17:00 A → 2025-05-16 17:00 | 100% → 0% | none → 0.5d | baseline start 2025-05-16 09:00 → none; baseline finish 2025-05-16 17:00 → none |
| 40 | Refit Office Complete | 2025-05-16 17:00 A → 2025-05-16 17:00 | 2025-05-16 17:00 A → 2025-05-16 17:00 | 100% → 0% | none → 0.5d | baseline start 2025-05-16 17:00 → none; baseline finish 2025-05-16 17:00 → none |
| 41 | **Office Move** |  |  |  |  | baseline start 2025-05-07 09:00 → none; baseline finish 2025-05-22 07:00 → none |
| 42 | Order packing boxes |  |  |  |  | baseline start 2025-05-07 09:00 → none; baseline finish 2025-05-07 10:00 → none |
| 43 | Staff Pack |  |  |  |  | baseline start 2025-05-19 09:00 → none; baseline finish 2025-05-19 12:30 → none |
| 44 | Staff Move |  |  |  |  | baseline start 2025-05-19 12:30 → none; baseline finish 2025-05-22 07:00 → none |
| 45 | Office Move Complete |  |  |  |  | baseline start 2025-05-22 07:00 → none; baseline finish 2025-05-22 07:00 → none |

## Version 7 (saved 2024-12-19, file Reports.mpp)

Last finish 2025-05-22 → 2025-05-30 (+8d). Complete tasks 0 → 18.

Changed:

| ID | Task | Start | Finish | Duration | Complete | Total float | Other |
| --- | --- | --- | --- | --- | --- | --- | --- |
| 1 | **Planning & Research** | 2025-04-07 09:00 A | 2025-04-17 12:00 → 2025-04-23 13:00 A (+6d) | 8.43d → 12.43d | 0% → 100% | 1.5d → none | baseline start none → 2025-04-07 09:00; baseline finish none → 2025-04-23 13:00 |
| 2 | Develop Requirements Documentation | 2025-04-07 09:00 A | 2025-04-07 17:00 A |  | 0% → 100% | 1.5d → none | baseline start none → 2025-04-07 09:00; baseline finish none → 2025-04-07 17:00 |
| 3 | Fit-Out Consultant Research | 2025-04-08 09:00 A | 2025-04-08 12:30 → 2025-04-08 17:00 A | 0.5d → 1d | 0% → 100% | 1.5d → none | baseline start none → 2025-04-08 09:00; baseline finish none → 2025-04-08 17:00 |
| 4 | Telecommunications Consultant Research | 2025-04-08 12:30 → 2025-04-09 09:00 A (+1d) | 2025-04-08 17:00 → 2025-04-09 17:00 A (+1d) | 0.5d → 1d | 0% → 100% | 1.5d → none | baseline start none → 2025-04-09 09:00; baseline finish none → 2025-04-09 17:00 |
| 5 | IT Network Contractor Research | 2025-04-09 09:00 → 2025-04-10 09:00 A (+1d) | 2025-04-09 12:30 → 2025-04-10 17:00 A (+1d) | 0.5d → 1d | 0% → 100% | 1.5d → none | baseline start none → 2025-04-10 09:00; baseline finish none → 2025-04-10 17:00 |
| 6 | Building Contractors Research | 2025-04-09 12:30 → 2025-04-11 09:00 A (+2d) | 2025-04-09 17:00 → 2025-04-11 17:00 A (+2d) | 0.5d → 1d | 0% → 100% | 1.5d → none | baseline start none → 2025-04-11 09:00; baseline finish none → 2025-04-11 17:00 |
| 7 | Submit Requirements to Resources & Request Quotes | 2025-04-10 09:00 → 2025-04-14 09:00 A (+4d) | 2025-04-10 11:00 → 2025-04-14 11:00 A (+4d) |  | 0% → 100% | 1.5d → none | baseline start none → 2025-04-14 09:00; baseline finish none → 2025-04-14 11:00 |
| 8 | Quotes Received | 2025-04-17 11:00 → 2025-04-23 11:00 A (+6d) | 2025-04-17 12:00 → 2025-04-23 12:00 A (+6d) |  | 0% → 100% | 1.5d → none | baseline start none → 2025-04-23 11:00; baseline finish none → 2025-04-23 12:00 |
| 9 | Planning & Research Complete | 2025-04-17 12:00 → 2025-04-23 13:00 A (+6d) | 2025-04-17 12:00 → 2025-04-23 13:00 A (+6d) |  | 0% → 100% | 1.5d → none | baseline start none → 2025-04-23 13:00; baseline finish none → 2025-04-23 13:00 |
| 10 | **Management Approval** | 2025-04-17 12:00 → 2025-04-23 13:00 A (+6d) | 2025-04-23 10:30 → 2025-04-25 10:30 A (+2d) |  | 0% → 100% | 1.5d → none | baseline start none → 2025-04-23 13:00; baseline finish none → 2025-04-25 10:30 |
| 11 | Consolidate Quotes and develop proposal | 2025-04-17 12:00 → 2025-04-23 13:00 A (+6d) | 2025-04-22 16:30 → 2025-04-24 16:30 A (+2d) |  | 0% → 100% | 1.5d → none | baseline start none → 2025-04-23 13:00; baseline finish none → 2025-04-24 16:30 |
| 12 | Develop Project Plan & Durations | 2025-04-22 16:30 → 2025-04-24 16:30 A (+2d) | 2025-04-23 09:30 → 2025-04-25 09:30 A (+2d) |  | 0% → 100% | 1.5d → none | baseline start none → 2025-04-24 16:30; baseline finish none → 2025-04-25 09:30 |
| 13 | Submit Project Plan & Costs to Management | 2025-04-23 09:30 → 2025-04-25 09:30 A (+2d) | 2025-04-23 10:30 → 2025-04-25 10:30 A (+2d) |  | 0% → 100% | 1.5d → none | baseline start none → 2025-04-25 09:30; baseline finish none → 2025-04-25 10:30 |
| 14 | Management Approval Received | 2025-04-23 10:30 → 2025-04-25 10:30 A (+2d) | 2025-04-23 10:30 → 2025-04-25 10:30 A (+2d) |  | 0% → 100% | 1.5d → none | baseline start none → 2025-04-25 10:30; baseline finish none → 2025-04-25 10:30 |
| 15 | **Refit Office** | 2025-04-23 10:30 → 2025-04-25 10:30 A (+2d) | 2025-05-16 17:00 → 2025-05-26 17:00 (+10d) | 15.79d → 21.79d | 0% → 18% |  | baseline start none → 2025-04-25 10:30; baseline finish none → 2025-05-26 17:00 |
| 16 | Appoint Resources | 2025-04-23 10:30 → 2025-04-25 10:30 A (+2d) | 2025-04-23 12:30 → 2025-04-25 15:00 A (+2d) | 2h → 0.5d | 0% → 100% | 1.5d → none | baseline start none → 2025-04-25 10:30; baseline finish none → 2025-04-25 15:00 |
| 17 | Staff Briefing | 2025-04-23 12:30 → 2025-04-25 15:00 A (+2d) | 2025-04-23 14:30 → 2025-04-28 10:30 A (+5d) | 1h → 0.5d | 0% → 100% | 1.5d → none | baseline start none → 2025-04-25 15:00; baseline finish none → 2025-04-28 10:30 |
| 18 | **Fit-Out Consultations** | 2025-04-23 14:30 → 2025-04-28 10:30 A (+5d) | 2025-04-24 13:00 → 2025-05-01 09:30 A (+7d) | 0.93d → 2.86d | 0% → 100% | 1.5d → none | baseline start none → 2025-04-28 10:30; baseline finish none → 2025-05-01 09:30 |
| 19 | Office Space / Structure Plan | 2025-04-23 14:30 → 2025-04-28 10:30 A (+5d) | 2025-04-24 10:00 → 2025-04-29 10:30 A (+5d) | 0.5d → 1d | 0% → 100% | 1.5d → none | baseline start none → 2025-04-28 10:30; baseline finish none → 2025-04-29 10:30 |
| 20 | Select & Order Carpet | 2025-04-24 10:00 → 2025-04-30 10:30 A (+6d) | 2025-04-24 11:00 → 2025-04-30 13:30 A (+6d) | 1h → 2h | 0% → 100% | 1.5d → none | baseline start none → 2025-04-30 10:30; baseline finish none → 2025-04-30 13:30 |
| 21 | Select & Order Paint | 2025-04-24 11:00 → 2025-04-30 13:30 A (+6d) | 2025-04-24 12:00 → 2025-04-30 15:30 A (+6d) | 1h → 2h | 0% → 100% | 1.5d → none | baseline start none → 2025-04-30 13:30; baseline finish none → 2025-04-30 15:30 |
| 22 | Select & Order Office Furniture | 2025-04-24 12:00 → 2025-04-30 15:30 A (+6d) | 2025-04-24 13:00 → 2025-05-01 09:30 A (+7d) | 1h → 2h | 0% → 100% | 1.5d → none | baseline start none → 2025-04-30 15:30; baseline finish none → 2025-05-01 09:30 |
| 23 | **Telecommuncations Consultations** | 2025-04-24 14:00 → 2025-05-01 09:30 (+7d) | 2025-04-28 10:30 → 2025-05-02 09:30 (+4d) | 0.64d → 1d |  | 1.5d → 1.71d | baseline start none → 2025-05-01 09:30; baseline finish none → 2025-05-02 09:30 |
| 24 | Design Telephone Access Points Map | 2025-04-24 14:00 → 2025-05-01 09:30 (+7d) | 2025-04-28 09:30 → 2025-05-01 14:00 (+3d) |  |  | 1.5d → 1.71d | baseline start none → 2025-05-01 09:30; baseline finish none → 2025-05-01 14:00 |
| 25 | Select & Order New PABX | 2025-04-28 09:30 → 2025-05-01 14:00 (+3d) | 2025-04-28 10:30 → 2025-05-02 09:30 (+4d) | 1h → 0.5d |  | 1.5d → 1.71d | baseline start none → 2025-05-01 14:00; baseline finish none → 2025-05-02 09:30 |
| 26 | **IT Networking Consultations** | 2025-04-28 10:30 → 2025-05-02 09:30 (+4d) | 2025-05-07 17:00 → 2025-05-12 16:00 (+5d) |  |  | 1.5d → 1.71d | baseline start none → 2025-05-02 09:30; baseline finish none → 2025-05-12 16:00 |
| 27 | Design Network Access Points Map | 2025-04-28 10:30 → 2025-05-02 09:30 (+4d) | 2025-04-28 15:00 → 2025-05-02 14:00 (+4d) |  |  | 1.5d → 1.71d | baseline start none → 2025-05-02 09:30; baseline finish none → 2025-05-02 14:00 |
| 28 | Select & Order New PCs | 2025-04-28 15:00 → 2025-05-02 14:00 (+4d) | 2025-04-28 16:00 → 2025-05-02 15:00 (+4d) |  |  | 1.5d → 1.71d | baseline start none → 2025-05-02 14:00; baseline finish none → 2025-05-02 15:00 |
| 29 | New PCs Arrive | 2025-05-06 16:00 → 2025-05-09 15:00 (+3d) | 2025-05-06 17:00 → 2025-05-09 16:00 (+3d) |  |  | 1.5d → 1.71d | baseline start none → 2025-05-09 15:00; baseline finish none → 2025-05-09 16:00 |
| 30 | Configure SOE on PCs | 2025-05-07 09:00 → 2025-05-09 16:00 (+2d) | 2025-05-07 17:00 → 2025-05-12 16:00 (+5d) |  |  | 1.5d → 1.71d | baseline start none → 2025-05-09 16:00; baseline finish none → 2025-05-12 16:00 |
| 31 | **Restructure Office** | 2025-04-25 06:00 → 2025-05-02 06:00 (+7d) | 2025-05-16 17:00 → 2025-05-26 17:00 (+10d) | 14d → 17d |  |  | baseline start none → 2025-05-02 06:00; baseline finish none → 2025-05-26 17:00 |
| 32 | Erect New Walls | 2025-04-25 06:00 → 2025-05-02 06:00 (+7d) | 2025-04-26 11:00 → 2025-05-03 11:00 (+7d) |  |  | 4d → 3d | baseline start none → 2025-05-02 06:00; baseline finish none → 2025-05-03 11:00 |
| 33 | Gyprock, Plaster & Finish | 2025-04-26 12:00 → 2025-05-03 12:00 (+7d) | 2025-05-01 08:00 → 2025-05-08 08:00 (+7d) |  |  | 4d → 3d | baseline start none → 2025-05-03 12:00; baseline finish none → 2025-05-08 08:00 |
| 34 | Install Network Points | 2025-05-08 09:00 → 2025-05-12 16:00 (+4d) | 2025-05-08 15:00 → 2025-05-13 14:00 (+5d) |  |  | 1.5d → 1.71d | baseline start none → 2025-05-12 16:00; baseline finish none → 2025-05-13 14:00 |
| 35 | Install Phone Connections | 2025-05-08 09:00 → 2025-05-12 16:00 (+4d) | 2025-05-08 12:30 → 2025-05-13 11:00 (+5d) | 0.5d → 3h |  | 1.5d → 1.71d | baseline start none → 2025-05-12 16:00; baseline finish none → 2025-05-13 11:00 |
| 36 | Re-Paint | 2025-05-09 06:00 → 2025-05-14 06:00 (+5d) | 2025-05-10 11:00 → 2025-05-17 13:00 (+7d) | 1d → 2d |  |  | resources Paint [100 Litre]; Painter → Paint [1 litre]; Painter; baseline start none → 2025-05-14 06:00; baseline finish none → 2025-05-17 13:00 |
| 37 | Carpet | 2025-05-12 06:00 → 2025-05-19 06:00 (+7d) | 2025-05-14 07:00 → 2025-05-23 08:00 (+9d) | 1d → 2d |  | 0d → 1d | resources Carpet [100 Lin Metre]; Carpet Contractor → Carpet [1 lin metre]; Carpet Contractor; baseline start none → 2025-05-19 06:00; baseline finish none → 2025-05-23 08:00 |
| 38 | Install New Furniture | 2025-05-14 07:00 → 2025-05-23 08:00 (+9d) | 2025-05-16 08:00 → 2025-05-24 14:00 (+8d) |  |  |  | baseline start none → 2025-05-23 08:00; baseline finish none → 2025-05-24 14:00 |
| 39 | Install New PCs | 2025-05-16 09:00 → 2025-05-26 09:00 (+10d) | 2025-05-16 17:00 → 2025-05-26 17:00 (+10d) |  |  |  | baseline start none → 2025-05-26 09:00; baseline finish none → 2025-05-26 17:00 |
| 40 | Refit Office Complete | 2025-05-16 17:00 → 2025-05-26 17:00 (+10d) | 2025-05-16 17:00 → 2025-05-26 17:00 (+10d) |  |  |  | baseline start none → 2025-05-26 17:00; baseline finish none → 2025-05-26 17:00 |
| 41 | **Office Move** | 2025-05-07 09:00 → 2025-05-09 16:00 (+2d) | 2025-05-22 07:00 → 2025-05-30 07:00 (+8d) | 11d → 14.14d |  |  | baseline start none → 2025-05-09 16:00; baseline finish none → 2025-05-30 07:00 |
| 42 | Order packing boxes | 2025-05-07 09:00 → 2025-05-09 16:00 (+2d) | 2025-05-07 10:00 → 2025-05-09 17:00 (+2d) |  |  | 8.36d → 11.5d | resources Project Manager → Admin Assistant; baseline start none → 2025-05-09 16:00; baseline finish none → 2025-05-09 17:00 |
| 43 | Staff Pack | 2025-05-19 09:00 → 2025-05-27 09:00 (+8d) | 2025-05-19 12:30 → 2025-05-27 13:30 (+8d) |  |  |  | baseline start none → 2025-05-27 09:00; baseline finish none → 2025-05-27 13:30 |
| 44 | Staff Move | 2025-05-19 12:30 → 2025-05-27 13:30 (+8d) | 2025-05-22 07:00 → 2025-05-30 07:00 (+8d) |  |  |  | baseline start none → 2025-05-27 13:30; baseline finish none → 2025-05-30 07:00 |
| 45 | Office Move Complete | 2025-05-22 07:00 → 2025-05-30 07:00 (+8d) | 2025-05-22 07:00 → 2025-05-30 07:00 (+8d) |  |  |  | baseline start none → 2025-05-30 07:00; baseline finish none → 2025-05-30 07:00 |

## Version 8 (saved 2024-12-19, file Resource Calendars.mpp)

Last finish 2025-05-30 → 2025-06-05 (+6d). Complete tasks 18 → 0.

Changed:

| ID | Task | Start | Finish | Duration | Complete | Total float | Predecessors | Other |
| --- | --- | --- | --- | --- | --- | --- | --- | --- |
| 1 | **Planning & Research** | 2025-04-07 09:00 A → 2025-04-07 | 2025-04-23 13:00 A → 2025-04-28 (+5d) | 12.43d → 15.5d | 100% → 0% | none → 1.29d |  | baseline start 2025-04-07 09:00 → none; baseline finish 2025-04-23 13:00 → none |
| 2 | Develop Requirements Documentation | 2025-04-07 09:00 A → 2025-04-07 | 2025-04-07 17:00 A → 2025-04-07 |  | 100% → 0% | none → 1.29d |  | baseline start 2025-04-07 09:00 → none; baseline finish 2025-04-07 17:00 → none |
| 3 | Fit-Out Consultant Research | 2025-04-08 09:00 A → 2025-04-08 | 2025-04-08 17:00 A → 2025-04-09 (+1d) | 1d → 2d | 100% → 0% | none → 1.29d |  | resources Project Manager → none; baseline start 2025-04-08 09:00 → none; baseline finish 2025-04-08 17:00 → none |
| 4 | Telecommunications Consultant Research | 2025-04-09 09:00 A → 2025-04-10 (+1d) | 2025-04-09 17:00 A → 2025-04-11 (+2d) | 1d → 2d | 100% → 0% | none → 1.29d |  | resources Project Manager → none; baseline start 2025-04-09 09:00 → none; baseline finish 2025-04-09 17:00 → none |
| 5 | IT Network Contractor Research | 2025-04-10 09:00 A → 2025-04-14 (+4d) | 2025-04-10 17:00 A → 2025-04-15 (+5d) | 1d → 2d | 100% → 0% | none → 1.29d |  | resources Project Manager → none; baseline start 2025-04-10 09:00 → none; baseline finish 2025-04-10 17:00 → none |
| 6 | Building Contractors Research | 2025-04-11 09:00 A → 2025-04-16 (+5d) | 2025-04-11 17:00 A → 2025-04-17 (+6d) | 1d → 2d | 100% → 0% | none → 1.29d |  | resources Project Manager → none; baseline start 2025-04-11 09:00 → none; baseline finish 2025-04-11 17:00 → none |
| 7 | Submit Requirements to Resources & Request Quotes | 2025-04-14 09:00 A → 2025-04-18 (+4d) | 2025-04-14 11:00 A → 2025-04-18 (+4d) | 2h → 1d | 100% → 0% | none → 1.29d |  | resources Project Manager → none; baseline start 2025-04-14 09:00 → none; baseline finish 2025-04-14 11:00 → none |
| 8 | Quotes Received | 2025-04-23 11:00 A → 2025-04-28 (+5d) | 2025-04-23 12:00 A → 2025-04-28 (+5d) | 1h → 0.5d | 100% → 0% | none → 1.29d |  | resources Project Manager → none; baseline start 2025-04-23 11:00 → none; baseline finish 2025-04-23 12:00 → none |
| 9 | Planning & Research Complete | 2025-04-23 13:00 A → 2025-04-28 (+5d) | 2025-04-23 13:00 A → 2025-04-28 (+5d) |  | 100% → 0% | none → 1.29d |  | baseline start 2025-04-23 13:00 → none; baseline finish 2025-04-23 13:00 → none |
| 10 | **Management Approval** | 2025-04-23 13:00 A → 2025-04-28 (+5d) | 2025-04-25 10:30 A → 2025-05-02 (+7d) | 1.79d → 4.14d | 100% → 0% | none → 1.29d |  | baseline start 2025-04-23 13:00 → none; baseline finish 2025-04-25 10:30 → none |
| 11 | Consolidate Quotes and develop proposal | 2025-04-23 13:00 A → 2025-04-28 (+5d) | 2025-04-24 16:30 A → 2025-04-30 (+6d) | 1.5d → 2d | 100% → 0% | none → 1.29d |  | resources Project Manager → none; baseline start 2025-04-23 13:00 → none; baseline finish 2025-04-24 16:30 → none |
| 12 | Develop Project Plan & Durations | 2025-04-24 16:30 A → 2025-04-30 (+6d) | 2025-04-25 09:30 A → 2025-05-02 (+7d) | 1h → 2d | 100% → 0% | none → 1.29d |  | resources Project Manager → none; baseline start 2025-04-24 16:30 → none; baseline finish 2025-04-25 09:30 → none |
| 13 | Submit Project Plan & Costs to Management | 2025-04-25 09:30 A → 2025-05-02 (+7d) | 2025-04-25 10:30 A → 2025-05-02 (+7d) |  | 100% → 0% | none → 1.29d |  | resources Project Manager; Management → none; baseline start 2025-04-25 09:30 → none; baseline finish 2025-04-25 10:30 → none |
| 14 | Management Approval Received | 2025-04-25 10:30 A → 2025-05-02 (+7d) | 2025-04-25 10:30 A → 2025-05-02 (+7d) |  | 100% → 0% | none → 1.29d |  | baseline start 2025-04-25 10:30 → none; baseline finish 2025-04-25 10:30 → none |
| 15 | **Refit Office** | 2025-04-25 10:30 A → 2025-05-02 (+7d) | 2025-05-26 17:00 → 2025-05-30 (+4d) | 21.79d → 20.07d | 18% → 0% | 0.5d → 1.29d |  | baseline start 2025-04-25 10:30 → none; baseline finish 2025-05-26 17:00 → none |
| 16 | Appoint Resources | 2025-04-25 10:30 A → 2025-05-02 (+7d) | 2025-04-25 15:00 A → 2025-05-05 (+10d) | 0.5d → 1d | 100% → 0% | none → 1.29d |  | resources Project Manager → none; baseline start 2025-04-25 10:30 → none; baseline finish 2025-04-25 15:00 → none |
| 17 | Staff Briefing | 2025-04-25 15:00 A → 2025-05-05 (+10d) | 2025-04-28 10:30 A → 2025-05-05 (+7d) | 0.5d → 1h | 100% → 0% | none → 1.29d |  | resources Project Manager; Staff [700%] → none; baseline start 2025-04-25 15:00 → none; baseline finish 2025-04-28 10:30 → none |
| 18 | **Fit-Out Consultations** | 2025-04-28 10:30 A → 2025-05-05 (+7d) | 2025-05-01 09:30 A → 2025-05-08 (+7d) | 2.86d → 2.5d | 100% → 0% | none → 1.29d |  | baseline start 2025-04-28 10:30 → none; baseline finish 2025-05-01 09:30 → none |
| 19 | Office Space / Structure Plan | 2025-04-28 10:30 A → 2025-05-05 (+7d) | 2025-04-29 10:30 A → 2025-05-06 (+7d) |  | 100% → 0% | none → 1.29d |  | resources Fit-out Consultant; Project Manager → none; baseline start 2025-04-28 10:30 → none; baseline finish 2025-04-29 10:30 → none |
| 20 | Select & Order Carpet | 2025-04-30 10:30 A → 2025-05-06 (+6d) | 2025-04-30 13:30 A → 2025-05-07 (+7d) | 2h → 0.5d | 100% → 0% | none → 1.29d |  | resources Fit-out Consultant; Project Manager → none; baseline start 2025-04-30 10:30 → none; baseline finish 2025-04-30 13:30 → none |
| 21 | Select & Order Paint | 2025-04-30 13:30 A → 2025-05-07 (+7d) | 2025-04-30 15:30 A → 2025-05-07 (+7d) | 2h → 0.5d | 100% → 0% | none → 1.29d |  | resources Fit-out Consultant; Project Manager → none; baseline start 2025-04-30 13:30 → none; baseline finish 2025-04-30 15:30 → none |
| 22 | Select & Order Office Furniture | 2025-04-30 15:30 A → 2025-05-07 (+7d) | 2025-05-01 09:30 A → 2025-05-08 (+7d) | 2h → 0.5d | 100% → 0% | none → 1.29d |  | resources Fit-out Consultant; Project Manager → none; baseline start 2025-04-30 15:30 → none; baseline finish 2025-05-01 09:30 → none |
| 23 | **Telecommuncations Consultations** | 2025-05-01 09:30 → 2025-05-08 (+7d) | 2025-05-02 09:30 → 2025-05-12 (+10d) | 1d → 2d |  | 1.71d → 17.71d |  | baseline start 2025-05-01 09:30 → none; baseline finish 2025-05-02 09:30 → none |
| 24 | Design Telephone Access Points Map | 2025-05-01 09:30 → 2025-05-08 (+7d) | 2025-05-01 14:00 → 2025-05-09 (+8d) | 0.5d → 1d |  | 1.71d → 17.71d |  | resources Project Manager; Telecommunications consultant → none; baseline start 2025-05-01 09:30 → none; baseline finish 2025-05-01 14:00 → none |
| 25 | Select & Order New PABX | 2025-05-01 14:00 → 2025-05-09 (+8d) | 2025-05-02 09:30 → 2025-05-12 (+10d) | 0.5d → 1d |  | 1.71d → 17.71d |  | resources Project Manager → none; baseline start 2025-05-01 14:00 → none; baseline finish 2025-05-02 09:30 → none |
| 26 | **IT Networking Consultations** | 2025-05-02 09:30 → 2025-05-08 (+6d) | 2025-05-12 16:00 → 2025-05-20 (+8d) | 6.79d → 8.14d |  | 1.71d → 1.29d |  | baseline start 2025-05-02 09:30 → none; baseline finish 2025-05-12 16:00 → none |
| 27 | Design Network Access Points Map | 2025-05-02 09:30 → 2025-05-08 (+6d) | 2025-05-02 14:00 → 2025-05-09 (+7d) | 0.5d → 1d |  | 1.71d → 1.29d | 22, 25 → 22 | resources IT Consultant; Project Manager → none; baseline start 2025-05-02 09:30 → none; baseline finish 2025-05-02 14:00 → none |
| 28 | Select & Order New PCs | 2025-05-02 14:00 → 2025-05-09 (+7d) | 2025-05-02 15:00 → 2025-05-12 (+10d) | 1h → 1d |  | 1.71d → 1.29d |  | resources Project Manager → none; baseline start 2025-05-02 14:00 → none; baseline finish 2025-05-02 15:00 → none |
| 29 | New PCs Arrive | 2025-05-09 15:00 → 2025-05-19 (+10d) | 2025-05-09 16:00 → 2025-05-19 (+10d) |  |  | 1.71d → 1.29d |  | resources Project Manager → none; baseline start 2025-05-09 15:00 → none; baseline finish 2025-05-09 16:00 → none |
| 30 | Configure SOE on PCs | 2025-05-09 16:00 → 2025-05-19 (+10d) | 2025-05-12 16:00 → 2025-05-20 (+8d) |  |  | 1.71d → 1.29d |  | resources IT Consultant → none; baseline start 2025-05-09 16:00 → none; baseline finish 2025-05-12 16:00 → none |
| 31 | **Restructure Office** | 2025-05-02 06:00 → 2025-05-20 (+18d) | 2025-05-26 17:00 → 2025-05-30 (+4d) | 17d → 8.29d |  | 0.5d → 1.29d |  | baseline start 2025-05-02 06:00 → none; baseline finish 2025-05-26 17:00 → none |
| 32 | Erect New Walls | 2025-05-02 06:00 → 2025-05-20 (+18d) | 2025-05-03 11:00 → 2025-05-21 (+18d) |  |  | 3d → 1.29d | 22 → 30 | baseline start 2025-05-02 06:00 → none; baseline finish 2025-05-03 11:00 → none |
| 33 | Gyprock, Plaster & Finish | 2025-05-03 12:00 → 2025-05-21 (+18d) | 2025-05-08 08:00 → 2025-05-22 (+14d) | 14h → 7h |  | 3d → 1.29d |  | resources Plasterer → Plasterer [200%]; baseline start 2025-05-03 12:00 → none; baseline finish 2025-05-08 08:00 → none |
| 34 | Install Network Points | 2025-05-12 16:00 → 2025-05-23 (+11d) | 2025-05-13 14:00 → 2025-05-26 (+13d) |  |  | 1.71d → 1.29d | 30, 33FS+1ed → 33FS+1d | resources IT Consultant → none; baseline start 2025-05-12 16:00 → none; baseline finish 2025-05-13 14:00 → none |
| 35 | Install Phone Connections | 2025-05-12 16:00 → 2025-05-23 (+11d) | 2025-05-13 11:00 → 2025-05-23 (+10d) | 3h → 2h |  | 1.71d → 1.29d |  | resources Telecommunications consultant → none; baseline start 2025-05-12 16:00 → none; baseline finish 2025-05-13 11:00 → none |
| 36 | Re-Paint | 2025-05-14 06:00 → 2025-05-23 (+9d) | 2025-05-17 13:00 → 2025-05-26 (+9d) | 2d → 1d |  | 0d → 1.29d |  | resources Paint [1 litre]; Painter → none; baseline start 2025-05-14 06:00 → none; baseline finish 2025-05-17 13:00 → none |
| 37 | Carpet | 2025-05-19 06:00 → 2025-05-27 (+8d) | 2025-05-23 08:00 → 2025-05-28 (+5d) | 2d → 1d |  | 1d → 1.29d | 36FS+1ed → 36FS+1d | resources Carpet [1 lin metre]; Carpet Contractor → none; baseline start 2025-05-19 06:00 → none; baseline finish 2025-05-23 08:00 → none |
| 38 | Install New Furniture | 2025-05-23 08:00 → 2025-05-28 (+5d) | 2025-05-24 14:00 → 2025-05-29 (+5d) |  |  | 0d → 1.29d |  | resources Labourer → none; baseline start 2025-05-23 08:00 → none; baseline finish 2025-05-24 14:00 → none |
| 39 | Install New PCs | 2025-05-26 09:00 → 2025-05-29 (+3d) | 2025-05-26 17:00 → 2025-05-30 (+4d) |  |  | 0.5d → 1.29d |  | resources IT Consultant → none; baseline start 2025-05-26 09:00 → none; baseline finish 2025-05-26 17:00 → none |
| 40 | Refit Office Complete | 2025-05-26 17:00 → 2025-05-30 (+4d) | 2025-05-26 17:00 → 2025-05-30 (+4d) |  |  | 0.5d → 1.29d |  | baseline start 2025-05-26 17:00 → none; baseline finish 2025-05-26 17:00 → none |
| 41 | **Office Move** | 2025-05-09 16:00 → 2025-05-29 (+20d) | 2025-05-30 07:00 → 2025-06-05 (+6d) | 14.14d → 4.29d |  |  |  | baseline start 2025-05-09 16:00 → none; baseline finish 2025-05-30 07:00 → none |
| 42 | Order packing boxes | 2025-05-09 16:00 → 2025-05-29 (+20d) | 2025-05-09 17:00 → 2025-05-29 (+20d) |  |  | 11.5d → 4.14d | 29 → 38 | resources Admin Assistant → none; baseline start 2025-05-09 16:00 → none; baseline finish 2025-05-09 17:00 → none |
| 43 | Staff Pack | 2025-05-27 09:00 → 2025-06-02 (+6d) | 2025-05-27 13:30 → 2025-06-02 (+6d) | 0.5d → 1d |  | 0.5d → none | 40, 42 → 40 | resources Project Manager; Staff [2000%] → none; baseline start 2025-05-27 09:00 → none; baseline finish 2025-05-27 13:30 → none |
| 44 | Staff Move | 2025-05-27 13:30 → 2025-06-03 (+7d) | 2025-05-30 07:00 → 2025-06-03 (+4d) | 2d → 1d |  | 0d → none |  | resources Staff [2000%]; Labourer → none; baseline start 2025-05-27 13:30 → none; baseline finish 2025-05-30 07:00 → none |
| 45 | Office Move Complete | 2025-05-30 07:00 → 2025-06-05 (+6d) | 2025-05-30 07:00 → 2025-06-05 (+6d) |  |  | 0d → none |  | baseline start 2025-05-30 07:00 → none; baseline finish 2025-05-30 07:00 → none |

## Version 9 (saved 2024-12-19, file Scheduling Options.mpp)

Last finish 2025-06-05 → 2025-05-22 (-14d). Complete tasks 0 → 1.

Changed:

| ID | Task | Start | Finish | Duration | Complete | Total float | Predecessors | Other |
| --- | --- | --- | --- | --- | --- | --- | --- | --- |
| 1 | **Planning & Research** | 2025-04-07 → 2025-04-07 09:00 | 2025-04-28 → 2025-04-17 16:00 (-11d) | 15.5d → 7.75d |  | 1.29d → 0.75d |  | baseline start none → 2025-04-07 09:00; baseline finish none → 2025-04-17 16:00 |
| 2 | Develop Requirements Documentation | 2025-04-07 → 2025-04-07 09:00 | 2025-04-07 → 2025-04-08 10:00 (+1d) |  |  | 1.29d → 0.75d |  | baseline start none → 2025-04-07 09:00; baseline finish none → 2025-04-08 10:00 |
| 3 | Fit-Out Consultant Research | 2025-04-08 → 2025-04-08 10:00 | 2025-04-09 → 2025-04-08 15:00 (-1d) | 2d → 0.5d |  | 1.29d → 0.75d |  | resources none → Project Manager; baseline start none → 2025-04-08 10:00; baseline finish none → 2025-04-08 15:00 |
| 4 | Telecommunications Consultant Research | 2025-04-10 → 2025-04-08 15:00 (-2d) | 2025-04-11 → 2025-04-09 11:00 (-2d) | 2d → 0.5d |  | 1.29d → 0.75d |  | resources none → Project Manager; baseline start none → 2025-04-08 15:00; baseline finish none → 2025-04-09 11:00 |
| 5 | IT Network Contractor Research | 2025-04-14 → 2025-04-09 11:00 (-5d) | 2025-04-15 → 2025-04-09 16:00 (-6d) | 2d → 0.5d |  | 1.29d → 0.75d |  | resources none → Project Manager; baseline start none → 2025-04-09 11:00; baseline finish none → 2025-04-09 16:00 |
| 6 | Building Contractors Research | 2025-04-16 → 2025-04-09 16:00 (-7d) | 2025-04-17 → 2025-04-10 12:00 (-7d) | 2d → 0.5d |  | 1.29d → 0.75d |  | resources none → Project Manager; baseline start none → 2025-04-09 16:00; baseline finish none → 2025-04-10 12:00 |
| 7 | Submit Requirements to Resources & Request Quotes | 2025-04-18 → 2025-04-10 12:00 (-8d) | 2025-04-18 → 2025-04-10 15:00 (-8d) | 1d → 2h |  | 1.29d → 0.75d |  | resources none → Project Manager; baseline start none → 2025-04-10 12:00; baseline finish none → 2025-04-10 15:00 |
| 8 | Quotes Received | 2025-04-28 → 2025-04-17 15:00 (-11d) | 2025-04-28 → 2025-04-17 16:00 (-11d) | 0.5d → 1h |  | 1.29d → 0.75d | 7FS+5d → 7FS+4.38d | resources none → Project Manager; baseline start none → 2025-04-17 15:00; baseline finish none → 2025-04-17 16:00 |
| 9 | Planning & Research Complete | 2025-04-28 → 2025-04-17 16:00 (-11d) | 2025-04-28 → 2025-04-17 16:00 (-11d) |  |  | 1.29d → 0.75d |  | baseline start none → 2025-04-17 16:00; baseline finish none → 2025-04-17 16:00 |
| 10 | **Management Approval** | 2025-04-28 → 2025-04-17 16:00 (-11d) | 2025-05-02 → 2025-04-24 12:00 (-8d) | 4.14d → 2.25d |  | 1.29d → 0.75d |  | baseline start none → 2025-04-17 16:00; baseline finish none → 2025-04-24 12:00 |
| 11 | Consolidate Quotes and develop proposal | 2025-04-28 → 2025-04-17 16:00 (-11d) | 2025-04-30 → 2025-04-24 10:00 (-6d) |  |  | 1.29d → 0.75d |  | resources none → Project Manager; baseline start none → 2025-04-17 16:00; baseline finish none → 2025-04-24 10:00 |
| 12 | Develop Project Plan & Durations | 2025-04-30 → 2025-04-24 10:00 (-6d) | 2025-05-02 → 2025-04-24 11:00 (-8d) | 2d → 1h |  | 1.29d → 0.75d |  | resources none → Project Manager; baseline start none → 2025-04-24 10:00; baseline finish none → 2025-04-24 11:00 |
| 13 | Submit Project Plan & Costs to Management | 2025-05-02 → 2025-04-24 11:00 (-8d) | 2025-05-02 → 2025-04-24 12:00 (-8d) |  |  | 1.29d → 0.75d |  | resources none → Project Manager; Management; baseline start none → 2025-04-24 11:00; baseline finish none → 2025-04-24 12:00 |
| 14 | Management Approval Received | 2025-05-02 → 2025-04-24 12:00 (-8d) | 2025-05-02 → 2025-04-24 12:00 (-8d) |  |  | 1.29d → 0.75d |  | baseline start none → 2025-04-24 12:00; baseline finish none → 2025-04-24 12:00 |
| 15 | **Refit Office** | 2025-05-02 → 2025-04-24 12:00 A (-8d) | 2025-05-30 → 2025-05-22 10:00 (-8d) | 20.07d → 15.5d |  | 1.29d → 0d |  | baseline start none → 2025-04-24 12:00; baseline finish none → 2025-05-22 10:00 |
| 16 | Appoint Resources | 2025-05-02 → 2025-04-24 12:00 (-8d) | 2025-05-05 → 2025-04-24 15:00 (-11d) | 1d → 2h |  | 1.29d → 0.75d |  | resources none → Project Manager; baseline start none → 2025-04-24 12:00; baseline finish none → 2025-04-24 15:00 |
| 17 | Staff Briefing | 2025-05-05 → 2025-04-24 15:00 (-11d) | 2025-05-05 → 2025-04-24 16:00 (-11d) |  |  | 1.29d → 0.75d |  | resources none → Project Manager; Staff [700%]; baseline start none → 2025-04-24 15:00; baseline finish none → 2025-04-24 16:00 |
| 18 | **Fit-Out Consultations** | 2025-05-05 → 2025-04-24 16:00 (-11d) | 2025-05-08 → 2025-04-28 16:00 (-10d) | 2.5d → 0.88d |  | 1.29d → 0.75d |  | baseline start none → 2025-04-24 16:00; baseline finish none → 2025-04-28 16:00 |
| 19 | Office Space / Structure Plan | 2025-05-05 → 2025-04-24 16:00 (-11d) | 2025-05-06 → 2025-04-28 12:00 (-8d) | 1d → 0.5d |  | 1.29d → 0.75d |  | resources none → Fit-out Consultant; Project Manager; baseline start none → 2025-04-24 16:00; baseline finish none → 2025-04-28 12:00 |
| 20 | Select & Order Carpet | 2025-05-06 → 2025-04-28 12:00 (-8d) | 2025-05-07 → 2025-04-28 13:00 (-9d) | 0.5d → 1h |  | 1.29d → 0.75d |  | resources none → Fit-out Consultant; Project Manager; baseline start none → 2025-04-28 12:00; baseline finish none → 2025-04-28 13:00 |
| 21 | Select & Order Paint | 2025-05-07 → 2025-04-28 14:00 (-9d) | 2025-05-07 → 2025-04-28 15:00 (-9d) | 0.5d → 1h |  | 1.29d → 0.75d |  | resources none → Fit-out Consultant; Project Manager; baseline start none → 2025-04-28 14:00; baseline finish none → 2025-04-28 15:00 |
| 22 | Select & Order Office Furniture | 2025-05-07 → 2025-04-28 15:00 (-9d) | 2025-05-08 → 2025-04-28 16:00 (-10d) | 0.5d → 1h |  | 1.29d → 0.75d |  | resources none → Fit-out Consultant; Project Manager; baseline start none → 2025-04-28 15:00; baseline finish none → 2025-04-28 16:00 |
| 23 | **Telecommuncations Consultations** | 2025-05-08 → 2025-04-28 16:00 (-10d) | 2025-05-12 → 2025-04-29 13:00 (-13d) | 2d → 0.62d |  | 17.71d → 0.75d |  | baseline start none → 2025-04-28 16:00; baseline finish none → 2025-04-29 13:00 |
| 24 | Design Telephone Access Points Map | 2025-05-08 → 2025-04-28 16:00 (-10d) | 2025-05-09 → 2025-04-29 12:00 (-10d) | 1d → 0.5d |  | 17.71d → 0.75d |  | resources none → Project Manager; Telecommunications consultant; baseline start none → 2025-04-28 16:00; baseline finish none → 2025-04-29 12:00 |
| 25 | Select & Order New PABX | 2025-05-09 → 2025-04-29 12:00 (-10d) | 2025-05-12 → 2025-04-29 13:00 (-13d) | 1d → 1h |  | 17.71d → 0.75d |  | resources none → Project Manager; baseline start none → 2025-04-29 12:00; baseline finish none → 2025-04-29 13:00 |
| 26 | **IT Networking Consultations** | 2025-05-08 → 2025-04-29 14:00 (-9d) | 2025-05-20 → 2025-05-09 13:00 (-11d) | 8.14d → 6.12d |  | 1.29d → 0.75d |  | baseline start none → 2025-04-29 14:00; baseline finish none → 2025-05-09 13:00 |
| 27 | Design Network Access Points Map | 2025-05-08 → 2025-04-29 14:00 (-9d) | 2025-05-09 → 2025-04-30 10:00 (-9d) | 1d → 0.5d |  | 1.29d → 0.75d | 22 → 22, 25 | resources none → IT Consultant; Project Manager; baseline start none → 2025-04-29 14:00; baseline finish none → 2025-04-30 10:00 |
| 28 | Select & Order New PCs | 2025-05-09 → 2025-04-30 10:00 (-9d) | 2025-05-12 → 2025-04-30 11:00 (-12d) | 1d → 1h |  | 1.29d → 0.75d |  | resources none → Project Manager; baseline start none → 2025-04-30 10:00; baseline finish none → 2025-04-30 11:00 |
| 29 | New PCs Arrive | 2025-05-19 → 2025-05-08 11:00 (-11d) | 2025-05-19 → 2025-05-08 12:00 (-11d) |  |  | 1.29d → 0.75d | 28FS+5d → 28FS+4.38d | resources none → Project Manager; baseline start none → 2025-05-08 11:00; baseline finish none → 2025-05-08 12:00 |
| 30 | Configure SOE on PCs | 2025-05-19 → 2025-05-08 12:00 (-11d) | 2025-05-20 → 2025-05-09 13:00 (-11d) |  |  | 1.29d → 0.75d |  | resources none → IT Consultant; baseline start none → 2025-05-08 12:00; baseline finish none → 2025-05-09 13:00 |
| 31 | **Restructure Office** | 2025-05-20 → 2025-04-29 06:00 A (-21d) | 2025-05-30 → 2025-05-22 10:00 (-8d) | 8.29d → 14.12d |  | 1.29d → 0d |  | baseline start none → 2025-04-29 06:00; baseline finish none → 2025-05-22 10:00 |
| 32 | Erect New Walls | 2025-05-20 → 2025-04-29 06:00 (-21d) | 2025-05-21 → 2025-05-01 07:00 (-20d) |  |  | 1.29d → 2.62d | 30 → 22 | baseline start none → 2025-04-29 06:00; baseline finish none → 2025-05-01 07:00 |
| 33 | Gyprock, Plaster & Finish | 2025-05-21 → 2025-05-01 07:00 (-20d) | 2025-05-22 → 2025-05-05 08:00 (-17d) | 7h → 14h |  | 1.29d → 2.62d |  | resources Plasterer [200%] → Plasterer; baseline start none → 2025-05-01 07:00; baseline finish none → 2025-05-05 08:00 |
| 34 | Install Network Points | 2025-05-23 → 2025-05-09 14:00 (-14d) | 2025-05-26 → 2025-05-12 11:00 (-14d) |  |  | 1.29d → 0.75d | 33FS+1d → 33FS+1ed, 30 | resources none → IT Consultant; baseline start none → 2025-05-09 14:00; baseline finish none → 2025-05-12 11:00 |
| 35 | Install Phone Connections | 2025-05-23 → 2025-05-09 14:00 (-14d) | 2025-05-23 → 2025-05-12 10:00 (-11d) | 2h → 0.5d |  | 1.29d → 0.75d |  | resources none → Telecommunications consultant; baseline start none → 2025-05-09 14:00; baseline finish none → 2025-05-12 10:00 |
| 36 | Re-Paint | 2025-05-23 → 2025-05-13 06:00 (-10d) | 2025-05-26 → 2025-05-15 08:00 (-11d) |  |  | 1.29d → 0d |  | resources none → Paint [100 Litre]; Painter; baseline start none → 2025-05-13 06:00; baseline finish none → 2025-05-15 08:00 |
| 37 | Carpet | 2025-05-27 → 2025-05-16 08:00 (-11d) | 2025-05-28 → 2025-05-17 15:00 (-11d) |  |  | 1.29d → 0d | 36FS+1d → 36FS+1ed | resources none → Carpet [100 Lin Metre]; Carpet Contractor; baseline start none → 2025-05-16 08:00; baseline finish none → 2025-05-17 15:00 |
| 38 | Install New Furniture | 2025-05-28 → 2025-05-19 06:00 (-9d) | 2025-05-29 → 2025-05-21 08:00 (-8d) |  |  | 1.29d → 0d |  | resources none → Labourer; baseline start none → 2025-05-19 06:00; baseline finish none → 2025-05-21 08:00 |
| 39 | Install New PCs | 2025-05-29 → 2025-05-21 09:00 (-8d) | 2025-05-30 → 2025-05-22 10:00 (-8d) |  |  | 1.29d → 0d |  | resources none → IT Consultant; baseline start none → 2025-05-21 09:00; baseline finish none → 2025-05-22 10:00 |
| 40 | Refit Office Complete | 2025-05-30 → 2025-05-16 10:00 A (-14d) | 2025-05-30 → 2025-05-16 10:00 A (-14d) |  | 0% → 100% | 1.29d → none |  | baseline start none → 2025-05-16 10:00; baseline finish none → 2025-05-16 10:00 |
| 41 | **Office Move** | 2025-05-29 → 2025-05-08 12:00 (-21d) | 2025-06-05 → 2025-05-20 17:00 (-16d) | 4.29d → 7.5d |  | 0d → 1d |  | baseline start none → 2025-05-08 12:00; baseline finish none → 2025-05-20 17:00 |
| 42 | Order packing boxes | 2025-05-29 → 2025-05-08 12:00 (-21d) | 2025-05-29 → 2025-05-08 13:00 (-21d) |  |  | 4.14d → 5.88d | 38 → 29 | resources none → Project Manager; baseline start none → 2025-05-08 12:00; baseline finish none → 2025-05-08 13:00 |
| 43 | Staff Pack | 2025-06-02 → 2025-05-16 10:00 (-17d) | 2025-06-02 → 2025-05-16 15:00 (-17d) | 1d → 0.5d |  | none → 1d | 40 → 40, 42 | resources none → Project Manager; Staff [2000%]; baseline start none → 2025-05-16 10:00; baseline finish none → 2025-05-16 15:00 |
| 44 | Staff Move | 2025-06-03 → 2025-05-16 15:00 (-18d) | 2025-06-03 → 2025-05-20 17:00 (-14d) | 1d → 2d |  | none → 1d |  | resources none → Staff [2000%]; baseline start none → 2025-05-16 15:00; baseline finish none → 2025-05-20 17:00 |
| 45 | Office Move Complete | 2025-06-05 → 2025-05-20 17:00 (-16d) | 2025-06-05 → 2025-05-20 17:00 (-16d) |  |  | none → 1d |  | baseline start none → 2025-05-20 17:00; baseline finish none → 2025-05-20 17:00 |

## Version 10 (saved 2024-12-19, file Sharing Resources 1.mpp)

Last finish 2025-05-22 → 2025-05-20 (-2d). Complete tasks 1 → 0.

Changed:

| ID | Task | Start | Finish | Duration | Complete | Total float | Predecessors | Other |
| --- | --- | --- | --- | --- | --- | --- | --- | --- |
| 1 | **Planning & Research** |  | 2025-04-17 16:00 → 2025-04-22 10:00 (+5d) | 7.75d → 11.14d |  | 0.75d → -0.43d |  | baseline start 2025-04-07 09:00 → 2011-04-04 09:00; baseline finish 2025-04-17 16:00 → 2011-04-14 12:00 |
| 2 | Develop Requirements Documentation |  | 2025-04-08 10:00 → 2025-04-07 17:00 (-1d) |  |  | 0.75d → -0.43d |  | resources Project Manager → none; baseline start 2025-04-07 09:00 → 2011-04-04 09:00; baseline finish 2025-04-08 10:00 → 2011-04-04 17:00 |
| 3 | Fit-Out Consultant Research | 2025-04-08 10:00 → 2025-04-08 09:00 | 2025-04-08 15:00 → 2025-04-08 17:00 | 0.5d → 1d |  | 0.75d → -0.43d |  | resources Project Manager → none; baseline start 2025-04-08 10:00 → 2011-04-05 09:00; baseline finish 2025-04-08 15:00 → 2011-04-05 12:30 |
| 4 | Telecommunications Consultant Research | 2025-04-08 15:00 → 2025-04-09 09:00 (+1d) | 2025-04-09 11:00 → 2025-04-09 17:00 | 0.5d → 1d |  | 0.75d → -0.43d |  | resources Project Manager → none; baseline start 2025-04-08 15:00 → 2011-04-05 12:30; baseline finish 2025-04-09 11:00 → 2011-04-05 17:00 |
| 5 | IT Network Contractor Research | 2025-04-09 11:00 → 2025-04-10 09:00 (+1d) | 2025-04-09 16:00 → 2025-04-10 17:00 (+1d) | 0.5d → 1d |  | 0.75d → -0.43d |  | resources Project Manager → none; baseline start 2025-04-09 11:00 → 2011-04-06 09:00; baseline finish 2025-04-09 16:00 → 2011-04-06 12:30 |
| 6 | Building Contractors Research | 2025-04-09 16:00 → 2025-04-11 09:00 (+2d) | 2025-04-10 12:00 → 2025-04-11 17:00 (+1d) | 0.5d → 1d |  | 0.75d → -0.43d |  | resources Project Manager → none; baseline start 2025-04-09 16:00 → 2011-04-06 12:30; baseline finish 2025-04-10 12:00 → 2011-04-06 17:00 |
| 7 | Submit Requirements to Resources & Request Quotes | 2025-04-10 12:00 → 2025-04-14 09:00 (+4d) | 2025-04-10 15:00 → 2025-04-14 17:00 (+4d) | 2h → 1d |  | 0.75d → -0.43d |  | resources Project Manager → none; baseline start 2025-04-10 12:00 → 2011-04-07 09:00; baseline finish 2025-04-10 15:00 → 2011-04-07 11:00 |
| 8 | Quotes Received | 2025-04-17 15:00 → 2025-04-22 09:00 (+5d) | 2025-04-17 16:00 → 2025-04-22 10:00 (+5d) |  |  | 0.75d → -0.43d | 7FS+4.38d → 7FS+5d | resources Project Manager → none; baseline start 2025-04-17 15:00 → 2011-04-14 11:00; baseline finish 2025-04-17 16:00 → 2011-04-14 12:00 |
| 9 | Planning & Research Complete | 2025-04-17 16:00 → 2025-04-22 10:00 (+5d) | 2025-04-17 16:00 → 2025-04-22 10:00 (+5d) |  |  | 0.75d → -0.43d |  | baseline start 2025-04-17 16:00 → 2011-04-14 12:00; baseline finish 2025-04-17 16:00 → 2011-04-14 12:00 |
| 10 | **Management Approval** | 2025-04-17 16:00 → 2025-04-22 10:00 (+5d) | 2025-04-24 12:00 → 2025-04-28 10:00 (+4d) | 2.25d → 4d |  | 0.75d → -0.43d |  | baseline start 2025-04-17 16:00 → 2011-04-14 12:00; baseline finish 2025-04-24 12:00 → 2011-04-15 15:00 |
| 11 | Consolidate Quotes and develop proposal | 2025-04-17 16:00 → 2025-04-22 10:00 (+5d) |  |  |  | 0.75d → -0.43d |  | resources Project Manager → none; baseline start 2025-04-17 16:00 → 2011-04-14 12:00; baseline finish 2025-04-24 10:00 → 2011-04-15 12:00 |
| 12 | Develop Project Plan & Durations |  | 2025-04-24 11:00 → 2025-04-25 10:00 (+1d) | 1h → 1d |  | 0.75d → -0.43d |  | resources Project Manager → none; baseline start 2025-04-24 10:00 → 2011-04-15 12:00; baseline finish 2025-04-24 11:00 → 2011-04-15 13:00 |
| 13 | Submit Project Plan & Costs to Management | 2025-04-24 11:00 → 2025-04-25 10:00 (+1d) | 2025-04-24 12:00 → 2025-04-28 10:00 (+4d) | 1h → 1d |  | 0.75d → -0.43d |  | resources Project Manager; Management → none; baseline start 2025-04-24 11:00 → 2011-04-15 14:00; baseline finish 2025-04-24 12:00 → 2011-04-15 15:00 |
| 14 | Management Approval Received | 2025-04-24 12:00 → 2025-04-28 10:00 (+4d) | 2025-04-24 12:00 → 2025-04-28 10:00 (+4d) |  |  | 0.75d → -0.43d |  | baseline start 2025-04-24 12:00 → 2011-04-15 15:00; baseline finish 2025-04-24 12:00 → 2011-04-15 15:00 |
| 15 | **Refit Office** | 2025-04-24 12:00 A → 2025-04-28 10:00 (+4d) | 2025-05-22 10:00 → 2025-05-16 12:00 (-6d) | 15.5d → 14.29d |  | 0d → -0.93d |  | baseline start 2025-04-24 12:00 → 2011-04-15 15:00; baseline finish 2025-05-22 10:00 → 2011-05-11 17:00 |
| 16 | Appoint Resources | 2025-04-24 12:00 → 2025-04-28 10:00 (+4d) | 2025-04-24 15:00 → 2025-04-28 12:00 (+4d) |  |  | 0.75d → -0.43d |  | resources Project Manager → none; baseline start 2025-04-24 12:00 → 2011-04-15 15:00; baseline finish 2025-04-24 15:00 → 2011-04-15 17:00 |
| 17 | Staff Briefing | 2025-04-24 15:00 → 2025-04-28 13:00 (+4d) | 2025-04-24 16:00 → 2025-04-28 14:00 (+4d) |  |  | 0.75d → -0.43d |  | resources Project Manager; Staff [700%] → none; baseline start 2025-04-24 15:00 → 2011-04-18 09:00; baseline finish 2025-04-24 16:00 → 2011-04-18 10:00 |
| 18 | **Fit-Out Consultations** | 2025-04-24 16:00 → 2025-04-28 14:00 (+4d) | 2025-04-28 16:00 → 2025-04-29 13:30 (+1d) | 0.88d → 0.93d |  | 0.75d → -0.43d |  | baseline start 2025-04-24 16:00 → 2011-04-18 10:00; baseline finish 2025-04-28 16:00 → 2011-04-19 09:30 |
| 19 | Office Space / Structure Plan | 2025-04-24 16:00 → 2025-04-28 14:00 (+4d) | 2025-04-28 12:00 → 2025-04-29 09:30 (+1d) |  |  | 0.75d → -0.43d |  | resources Fit-out Consultant; Project Manager → none; baseline start 2025-04-24 16:00 → 2011-04-18 10:00; baseline finish 2025-04-28 12:00 → 2011-04-18 14:30 |
| 20 | Select & Order Carpet | 2025-04-28 12:00 → 2025-04-29 09:30 (+1d) | 2025-04-28 13:00 → 2025-04-29 10:30 (+1d) |  |  | 0.75d → -0.43d |  | resources Fit-out Consultant; Project Manager → none; baseline start 2025-04-28 12:00 → 2011-04-18 14:30; baseline finish 2025-04-28 13:00 → 2011-04-18 15:30 |
| 21 | Select & Order Paint | 2025-04-28 14:00 → 2025-04-29 10:30 (+1d) | 2025-04-28 15:00 → 2025-04-29 11:30 (+1d) |  |  | 0.75d → -0.43d |  | resources Fit-out Consultant; Project Manager → none; baseline start 2025-04-28 14:00 → 2011-04-18 15:30; baseline finish 2025-04-28 15:00 → 2011-04-18 16:30 |
| 22 | Select & Order Office Furniture | 2025-04-28 15:00 → 2025-04-29 11:30 (+1d) | 2025-04-28 16:00 → 2025-04-29 13:30 (+1d) |  |  | 0.75d → -0.43d |  | resources Fit-out Consultant; Project Manager → none; baseline start 2025-04-28 15:00 → 2011-04-18 16:30; baseline finish 2025-04-28 16:00 → 2011-04-19 09:30 |
| 23 | **Telecommuncations Consultations** | 2025-04-28 16:00 → 2025-04-29 13:30 (+1d) | 2025-04-29 13:00 → 2025-04-30 10:00 (+1d) | 0.62d → 0.64d |  | 0.75d → -0.43d |  | baseline start 2025-04-28 16:00 → 2011-04-19 09:30; baseline finish 2025-04-29 13:00 → 2011-04-19 15:00 |
| 24 | Design Telephone Access Points Map | 2025-04-28 16:00 → 2025-04-29 13:30 (+1d) | 2025-04-29 12:00 → 2025-04-29 17:00 |  |  | 0.75d → -0.43d |  | resources Project Manager; Telecommunications consultant → none; baseline start 2025-04-28 16:00 → 2011-04-19 09:30; baseline finish 2025-04-29 12:00 → 2011-04-19 13:00 |
| 25 | Select & Order New PABX | 2025-04-29 12:00 → 2025-04-30 09:00 (+1d) | 2025-04-29 13:00 → 2025-04-30 10:00 (+1d) |  |  | 0.75d → -0.43d |  | resources Project Manager → none; baseline start 2025-04-29 12:00 → 2011-04-19 14:00; baseline finish 2025-04-29 13:00 → 2011-04-19 15:00 |
| 26 | **IT Networking Consultations** | 2025-04-29 14:00 → 2025-04-30 10:00 (+1d) | 2025-05-09 13:00 → 2025-05-08 16:30 (-1d) | 6.12d → 6.79d |  | 0.75d → -0.43d |  | baseline start 2025-04-29 14:00 → 2011-04-19 15:00; baseline finish 2025-05-09 13:00 → 2011-05-03 12:30 |
| 27 | Design Network Access Points Map | 2025-04-29 14:00 → 2025-04-30 10:00 (+1d) | 2025-04-30 10:00 → 2025-04-30 14:30 |  |  | 0.75d → -0.43d |  | resources IT Consultant; Project Manager → none; baseline start 2025-04-29 14:00 → 2011-04-19 15:00; baseline finish 2025-04-30 10:00 → 2011-04-20 10:30 |
| 28 | Select & Order New PCs | 2025-04-30 10:00 → 2025-04-30 14:30 | 2025-04-30 11:00 → 2025-04-30 15:30 |  |  | 0.75d → -0.43d |  | resources Project Manager → none; baseline start 2025-04-30 10:00 → 2011-04-20 10:30; baseline finish 2025-04-30 11:00 → 2011-04-20 11:30 |
| 29 | New PCs Arrive | 2025-05-08 11:00 → 2025-05-07 15:30 (-1d) | 2025-05-08 12:00 → 2025-05-07 16:30 (-1d) |  |  | 0.75d → -0.43d | 28FS+4.38d → 28FS+5d | resources Project Manager → none; baseline start 2025-05-08 11:00 → 2011-04-29 11:30; baseline finish 2025-05-08 12:00 → 2011-04-29 12:30 |
| 30 | Configure SOE on PCs | 2025-05-08 12:00 → 2025-05-07 16:30 (-1d) | 2025-05-09 13:00 → 2025-05-08 16:30 (-1d) |  |  | 0.75d → -0.43d |  | resources IT Consultant → none; baseline start 2025-05-08 12:00 → 2011-04-29 12:30; baseline finish 2025-05-09 13:00 → 2011-05-03 12:30 |
| 31 | **Restructure Office** | 2025-04-29 06:00 A → 2025-04-29 13:30 | 2025-05-22 10:00 → 2025-05-16 12:00 (-6d) | 14.12d → 12.93d |  | 0d → -0.93d |  | baseline start 2025-04-29 06:00 → 2011-04-20 06:00; baseline finish 2025-05-22 10:00 → 2011-05-11 17:00 |
| 32 | Erect New Walls | 2025-04-29 06:00 → 2025-04-29 13:30 | 2025-05-01 07:00 → 2025-04-30 13:30 (-1d) |  |  | 2.62d → 3d |  | resources Carpenter [200%] → none; baseline start 2025-04-29 06:00 → 2011-04-20 06:00; baseline finish 2025-05-01 07:00 → 2011-04-26 07:00 |
| 33 | Gyprock, Plaster & Finish | 2025-05-01 07:00 → 2025-04-30 13:30 (-1d) | 2025-05-05 08:00 → 2025-05-02 13:30 (-3d) |  |  | 2.62d → 3d |  | resources Plasterer → none; baseline start 2025-05-01 07:00 → 2011-04-26 07:00; baseline finish 2025-05-05 08:00 → 2011-04-30 10:00 |
| 34 | Install Network Points | 2025-05-09 14:00 → 2025-05-08 16:30 (-1d) | 2025-05-12 11:00 → 2025-05-09 14:30 (-3d) |  |  | 0.75d → -0.43d | 33FS+1ed, 30 → 33FS+1d, 30 | resources IT Consultant → none; baseline start 2025-05-09 14:00 → 2011-05-03 12:30; baseline finish 2025-05-12 11:00 → 2011-05-04 10:30 |
| 35 | Install Phone Connections | 2025-05-09 14:00 → 2025-05-08 16:30 (-1d) | 2025-05-12 10:00 → 2025-05-09 12:00 (-3d) |  |  | 0.75d → -0.43d |  | resources Telecommunications consultant → none; baseline start 2025-05-09 14:00 → 2011-05-03 12:30; baseline finish 2025-05-12 10:00 → 2011-05-03 17:00 |
| 36 | Re-Paint | 2025-05-13 06:00 → 2025-05-09 13:00 (-4d) | 2025-05-15 08:00 → 2025-05-12 12:00 (-3d) |  |  | 0d → -0.43d |  | resources Paint [100 Litre]; Painter → none; baseline start 2025-05-13 06:00 → 2011-05-04 06:00; baseline finish 2025-05-15 08:00 → 2011-05-06 07:00 |
| 37 | Carpet | 2025-05-16 08:00 → 2025-05-13 13:00 (-3d) | 2025-05-17 15:00 → 2025-05-14 12:00 (-3d) |  |  | 0d → -0.93d |  | resources Carpet [100 Lin Metre]; Carpet Contractor → none; baseline start 2025-05-16 08:00 → 2011-05-07 07:00; baseline finish 2025-05-17 15:00 → 2011-05-07 15:00 |
| 38 | Install New Furniture | 2025-05-19 06:00 → 2025-05-14 13:00 (-5d) | 2025-05-21 08:00 → 2025-05-15 12:00 (-6d) |  |  | 0d → -0.93d |  | resources Labourer → none; baseline start 2025-05-19 06:00 → 2011-05-09 06:00; baseline finish 2025-05-21 08:00 → 2011-05-11 07:00 |
| 39 | Install New PCs | 2025-05-21 09:00 → 2025-05-15 13:00 (-6d) | 2025-05-22 10:00 → 2025-05-16 12:00 (-6d) |  |  | 0d → -0.93d |  | resources IT Consultant → none; baseline start 2025-05-21 09:00 → 2011-05-11 09:00; baseline finish 2025-05-22 10:00 → 2011-05-11 17:00 |
| 40 | Refit Office Complete | 2025-05-16 10:00 A → 2025-05-16 12:00 | 2025-05-16 10:00 A → 2025-05-16 12:00 |  | 100% → 0% | none → -0.93d |  | baseline start 2025-05-16 10:00 → 2011-05-11 17:00; baseline finish 2025-05-16 10:00 → 2011-05-11 17:00 |
| 41 | **Office Move** | 2025-05-08 12:00 → 2025-05-07 16:30 (-1d) | 2025-05-20 17:00 → 2025-05-20 16:30 | 7.5d → 9d |  | 1d → -0.93d |  | baseline start 2025-05-08 12:00 → 2011-04-29 12:30; baseline finish 2025-05-20 17:00 → 2011-05-16 17:00 |
| 42 | Order packing boxes | 2025-05-08 12:00 → 2025-05-07 16:30 (-1d) | 2025-05-08 13:00 → 2025-05-08 09:30 |  |  | 5.88d → 5.43d |  | resources Project Manager → none; baseline start 2025-05-08 12:00 → 2011-04-29 12:30; baseline finish 2025-05-08 13:00 → 2011-04-29 14:30 |
| 43 | Staff Pack | 2025-05-16 10:00 → 2025-05-16 13:00 | 2025-05-16 15:00 → 2025-05-16 16:30 |  |  | 1d → -0.93d |  | resources Project Manager; Staff [2000%] → none; baseline start 2025-05-16 10:00 → 2011-05-12 09:00; baseline finish 2025-05-16 15:00 → 2011-05-12 12:30 |
| 44 | Staff Move | 2025-05-16 15:00 → 2025-05-16 16:30 | 2025-05-20 17:00 → 2025-05-20 16:30 |  |  | 1d → -0.93d |  | resources Staff [2000%] → none; baseline start 2025-05-16 15:00 → 2011-05-12 12:30; baseline finish 2025-05-20 17:00 → 2011-05-14 11:00 |
| 45 | Office Move Complete | 2025-05-20 17:00 → 2025-05-20 08:00 | 2025-05-20 17:00 → 2025-05-20 08:00 |  |  | 1d → 0d |  | constraint none → must finish on 2025-05-20 08:00; baseline start 2025-05-20 17:00 → 2011-05-16 17:00; baseline finish 2025-05-20 17:00 → 2011-05-16 17:00 |

## Version 11 (saved 2024-12-19, file Sharing Resources 2.mpp)

Last finish 2025-05-20 → 2025-05-28 (+8d).

Changed:

| ID | Task | Start | Finish | Duration | Total float | Other |
| --- | --- | --- | --- | --- | --- | --- |
| 1 | **Planning & Research** | 2025-04-07 09:00 → 2025-04-14 09:00 (+7d) | 2025-04-22 10:00 → 2025-04-28 12:00 (+6d) | 11.14d → 10.43d | -0.43d → -1.29d |  |
| 2 | Develop Requirements Documentation | 2025-04-07 09:00 → 2025-04-14 09:00 (+7d) | 2025-04-07 17:00 → 2025-04-14 17:00 (+7d) |  | -0.43d → -1.29d |  |
| 3 | Fit-Out Consultant Research | 2025-04-08 09:00 → 2025-04-15 09:00 (+7d) | 2025-04-08 17:00 → 2025-04-15 17:00 (+7d) |  | -0.43d → -1.29d |  |
| 4 | Telecommunications Consultant Research | 2025-04-09 09:00 → 2025-04-16 09:00 (+7d) | 2025-04-09 17:00 → 2025-04-16 17:00 (+7d) |  | -0.43d → -1.29d |  |
| 5 | IT Network Contractor Research | 2025-04-10 09:00 → 2025-04-17 09:00 (+7d) | 2025-04-10 17:00 → 2025-04-17 17:00 (+7d) |  | -0.43d → -1.29d |  |
| 6 | Building Contractors Research | 2025-04-11 09:00 → 2025-04-18 09:00 (+7d) | 2025-04-11 17:00 → 2025-04-18 17:00 (+7d) |  | -0.43d → -1.29d |  |
| 7 | Submit Requirements to Resources & Request Quotes | 2025-04-14 09:00 → 2025-04-21 09:00 (+7d) | 2025-04-14 17:00 → 2025-04-21 11:00 (+7d) | 1d → 2h | -0.43d → -1.29d |  |
| 8 | Quotes Received | 2025-04-22 09:00 → 2025-04-28 11:00 (+6d) | 2025-04-22 10:00 → 2025-04-28 12:00 (+6d) |  | -0.43d → -1.29d |  |
| 9 | Planning & Research Complete | 2025-04-22 10:00 → 2025-04-28 12:00 (+6d) | 2025-04-22 10:00 → 2025-04-28 12:00 (+6d) |  | -0.43d → -1.29d |  |
| 10 | **Management Approval** | 2025-04-22 10:00 → 2025-04-28 13:00 (+6d) | 2025-04-28 10:00 → 2025-05-02 12:00 (+4d) |  | -0.43d → -1.29d |  |
| 11 | Consolidate Quotes and develop proposal | 2025-04-22 10:00 → 2025-04-28 13:00 (+6d) | 2025-04-24 10:00 → 2025-04-30 12:00 (+6d) |  | -0.43d → -1.29d |  |
| 12 | Develop Project Plan & Durations | 2025-04-24 10:00 → 2025-04-30 13:00 (+6d) | 2025-04-25 10:00 → 2025-05-01 12:00 (+6d) |  | -0.43d → -1.29d |  |
| 13 | Submit Project Plan & Costs to Management | 2025-04-25 10:00 → 2025-05-01 13:00 (+6d) | 2025-04-28 10:00 → 2025-05-02 12:00 (+4d) |  | -0.43d → -1.29d |  |
| 14 | Management Approval Received | 2025-04-28 10:00 → 2025-05-02 12:00 (+4d) | 2025-04-28 10:00 → 2025-05-02 12:00 (+4d) |  | -0.43d → -1.29d |  |
| 15 | **Refit Office** | 2025-04-28 10:00 → 2025-05-02 13:00 (+4d) | 2025-05-16 12:00 → 2025-05-26 11:00 (+10d) | 14.29d → 15.86d | -0.93d → -1.79d |  |
| 16 | Appoint Resources | 2025-04-28 10:00 → 2025-05-02 13:00 (+4d) | 2025-04-28 12:00 → 2025-05-05 12:00 (+7d) | 2h → 1d | -0.43d → -1.29d |  |
| 17 | Staff Briefing | 2025-04-28 13:00 → 2025-05-05 13:00 (+7d) | 2025-04-28 14:00 → 2025-05-06 12:00 (+8d) | 1h → 1d | -0.43d → -1.29d |  |
| 18 | **Fit-Out Consultations** | 2025-04-28 14:00 → 2025-05-06 13:00 (+8d) | 2025-04-29 13:30 → 2025-05-07 11:30 (+8d) |  | -0.43d → -1.29d |  |
| 19 | Office Space / Structure Plan | 2025-04-28 14:00 → 2025-05-06 13:00 (+8d) | 2025-04-29 09:30 → 2025-05-06 16:30 (+7d) |  | -0.43d → -1.29d |  |
| 20 | Select & Order Carpet | 2025-04-29 09:30 → 2025-05-06 16:30 (+7d) | 2025-04-29 10:30 → 2025-05-07 09:30 (+8d) |  | -0.43d → -1.29d |  |
| 21 | Select & Order Paint | 2025-04-29 10:30 → 2025-05-07 09:30 (+8d) | 2025-04-29 11:30 → 2025-05-07 10:30 (+8d) |  | -0.43d → -1.29d |  |
| 22 | Select & Order Office Furniture | 2025-04-29 11:30 → 2025-05-07 10:30 (+8d) | 2025-04-29 13:30 → 2025-05-07 11:30 (+8d) |  | -0.43d → -1.29d |  |
| 23 | **Telecommuncations Consultations** | 2025-04-29 13:30 → 2025-05-07 11:30 (+8d) | 2025-04-30 10:00 → 2025-05-07 17:00 (+7d) |  | -0.43d → -1.29d |  |
| 24 | Design Telephone Access Points Map | 2025-04-29 13:30 → 2025-05-07 11:30 (+8d) | 2025-04-29 17:00 → 2025-05-07 16:00 (+8d) |  | -0.43d → -1.29d |  |
| 25 | Select & Order New PABX | 2025-04-30 09:00 → 2025-05-07 16:00 (+7d) | 2025-04-30 10:00 → 2025-05-07 17:00 (+7d) |  | -0.43d → -1.29d |  |
| 26 | **IT Networking Consultations** | 2025-04-30 10:00 → 2025-05-08 09:00 (+8d) | 2025-05-08 16:30 → 2025-05-16 15:30 (+8d) |  | -0.43d → -1.29d |  |
| 27 | Design Network Access Points Map | 2025-04-30 10:00 → 2025-05-08 09:00 (+8d) | 2025-04-30 14:30 → 2025-05-08 13:30 (+8d) |  | -0.43d → -1.29d |  |
| 28 | Select & Order New PCs | 2025-04-30 14:30 → 2025-05-08 13:30 (+8d) | 2025-04-30 15:30 → 2025-05-08 14:30 (+8d) |  | -0.43d → -1.29d |  |
| 29 | New PCs Arrive | 2025-05-07 15:30 → 2025-05-15 14:30 (+8d) | 2025-05-07 16:30 → 2025-05-15 15:30 (+8d) |  | -0.43d → -1.29d |  |
| 30 | Configure SOE on PCs | 2025-05-07 16:30 → 2025-05-15 15:30 (+8d) | 2025-05-08 16:30 → 2025-05-16 15:30 (+8d) |  | -0.43d → -1.29d |  |
| 31 | **Restructure Office** | 2025-04-29 13:30 → 2025-05-07 11:30 (+8d) | 2025-05-16 12:00 → 2025-05-26 11:00 (+10d) |  | -0.93d → -1.79d |  |
| 32 | Erect New Walls | 2025-04-29 13:30 → 2025-05-07 11:30 (+8d) | 2025-04-30 13:30 → 2025-05-08 11:30 (+8d) |  | 3d → 2.14d |  |
| 33 | Gyprock, Plaster & Finish | 2025-04-30 13:30 → 2025-05-08 11:30 (+8d) | 2025-05-02 13:30 → 2025-05-12 11:30 (+10d) |  | 3d → 2.14d |  |
| 34 | Install Network Points | 2025-05-08 16:30 → 2025-05-16 15:30 (+8d) | 2025-05-09 14:30 → 2025-05-19 13:30 (+10d) |  | -0.43d → -1.29d |  |
| 35 | Install Phone Connections | 2025-05-08 16:30 → 2025-05-16 15:30 (+8d) | 2025-05-09 12:00 → 2025-05-19 11:00 (+10d) |  | -0.43d → -1.29d |  |
| 36 | Re-Paint | 2025-05-09 13:00 → 2025-05-19 11:00 (+10d) | 2025-05-12 12:00 → 2025-05-20 11:00 (+8d) |  | -0.43d → -1.29d |  |
| 37 | Carpet | 2025-05-13 13:00 → 2025-05-21 11:00 (+8d) | 2025-05-14 12:00 → 2025-05-22 11:00 (+8d) |  | -0.93d → -1.79d |  |
| 38 | Install New Furniture | 2025-05-14 13:00 → 2025-05-22 11:00 (+8d) | 2025-05-15 12:00 → 2025-05-23 11:00 (+8d) |  | -0.93d → -1.79d |  |
| 39 | Install New PCs | 2025-05-15 13:00 → 2025-05-23 11:00 (+8d) | 2025-05-16 12:00 → 2025-05-26 11:00 (+10d) |  | -0.93d → -1.79d |  |
| 40 | Refit Office Complete | 2025-05-16 12:00 → 2025-05-26 11:00 (+10d) | 2025-05-16 12:00 → 2025-05-26 11:00 (+10d) |  | -0.93d → -1.79d |  |
| 41 | **Office Move** | 2025-05-07 16:30 → 2025-05-15 15:30 (+8d) | 2025-05-20 16:30 → 2025-05-28 15:30 (+8d) |  | -0.93d → -1.79d |  |
| 42 | Order packing boxes | 2025-05-07 16:30 → 2025-05-15 15:30 (+8d) | 2025-05-08 09:30 → 2025-05-15 16:30 (+7d) |  | 5.43d → 4.57d |  |
| 43 | Staff Pack | 2025-05-16 13:00 → 2025-05-26 11:00 (+10d) | 2025-05-16 16:30 → 2025-05-26 15:30 (+10d) |  | -0.93d → -1.79d |  |
| 44 | Staff Move | 2025-05-16 16:30 → 2025-05-26 15:30 (+10d) | 2025-05-20 16:30 → 2025-05-28 15:30 (+8d) |  | -0.93d → -1.79d |  |
| 45 | Office Move Complete | 2025-05-20 08:00 → 2025-05-27 08:00 (+7d) | 2025-05-20 08:00 → 2025-05-27 08:00 (+7d) |  | 0d → -1.79d | constraint must finish on 2025-05-20 08:00 → must finish on 2025-05-27 08:00 |

## Version 12 (saved 2024-12-19, file Tables.mpp)

Last finish 2025-05-28 → 2025-05-31 (+3d).

Changed:

| ID | Task | Start | Finish | Duration | Total float | Other |
| --- | --- | --- | --- | --- | --- | --- |
| 1 | **Planning & Research** | 2025-04-14 09:00 → 2025-04-07 (-7d) | 2025-04-28 12:00 → 2025-04-22 (-6d) | 10.43d → 12d | -1.29d → 0d | baseline start 2011-04-04 09:00 → 2011-04-04; baseline finish 2011-04-14 12:00 → 2011-04-14 |
| 2 | Develop Requirements Documentation | 2025-04-14 09:00 → 2025-04-07 (-7d) | 2025-04-14 17:00 → 2025-04-07 (-7d) |  | -1.29d → 0d | resources none → Project Manager; baseline start 2011-04-04 09:00 → 2011-04-04; baseline finish 2011-04-04 17:00 → 2011-04-04 |
| 3 | Fit-Out Consultant Research | 2025-04-15 09:00 → 2025-04-08 (-7d) | 2025-04-15 17:00 → 2025-04-08 (-7d) |  | -1.29d → 0d | resources none → Project Manager; baseline start 2011-04-05 09:00 → 2011-04-05; baseline finish 2011-04-05 12:30 → 2011-04-05 |
| 4 | Telecommunications Consultant Research | 2025-04-16 09:00 → 2025-04-09 (-7d) | 2025-04-16 17:00 → 2025-04-09 (-7d) |  | -1.29d → 0d | resources none → Project Manager; baseline start 2011-04-05 12:30 → 2011-04-05; baseline finish 2011-04-05 17:00 → 2011-04-05 |
| 5 | IT Network Contractor Research | 2025-04-17 09:00 → 2025-04-10 (-7d) | 2025-04-17 17:00 → 2025-04-10 (-7d) |  | -1.29d → 0d | resources none → Project Manager; baseline start 2011-04-06 09:00 → 2011-04-06; baseline finish 2011-04-06 12:30 → 2011-04-06 |
| 6 | Building Contractors Research | 2025-04-18 09:00 → 2025-04-11 (-7d) | 2025-04-18 17:00 → 2025-04-11 (-7d) |  | -1.29d → 0d | resources none → Project Manager; baseline start 2011-04-06 12:30 → 2011-04-06; baseline finish 2011-04-06 17:00 → 2011-04-06 |
| 7 | Submit Requirements to Resources & Request Quotes | 2025-04-21 09:00 → 2025-04-14 (-7d) | 2025-04-21 11:00 → 2025-04-14 (-7d) | 2h → 1d | -1.29d → 0d | resources none → Project Manager; baseline start 2011-04-07 09:00 → 2011-04-07; baseline finish 2011-04-07 11:00 → 2011-04-07 |
| 8 | Quotes Received | 2025-04-28 11:00 → 2025-04-22 (-6d) | 2025-04-28 12:00 → 2025-04-22 (-6d) | 1h → 1d | -1.29d → 0d | resources none → Project Manager; baseline start 2011-04-14 11:00 → 2011-04-14; baseline finish 2011-04-14 12:00 → 2011-04-14 |
| 9 | Planning & Research Complete | 2025-04-28 12:00 → 2025-04-22 (-6d) | 2025-04-28 12:00 → 2025-04-22 (-6d) |  | -1.29d → 0d | baseline start 2011-04-14 12:00 → 2011-04-14; baseline finish 2011-04-14 12:00 → 2011-04-14 |
| 10 | **Management Approval** | 2025-04-28 13:00 → 2025-04-23 (-5d) | 2025-05-02 12:00 → 2025-04-28 (-4d) | 4d → 3.5d | -1.29d → 0d | baseline start 2011-04-14 12:00 → 2011-04-14; baseline finish 2011-04-15 15:00 → 2011-04-15 |
| 11 | Consolidate Quotes and develop proposal | 2025-04-28 13:00 → 2025-04-23 (-5d) | 2025-04-30 12:00 → 2025-04-24 (-6d) | 2d → 1.5d | -1.29d → 0d | resources none → Project Manager; baseline start 2011-04-14 12:00 → 2011-04-14; baseline finish 2011-04-15 12:00 → 2011-04-15 |
| 12 | Develop Project Plan & Durations | 2025-04-30 13:00 → 2025-04-24 (-6d) | 2025-05-01 12:00 → 2025-04-25 (-6d) |  | -1.29d → 0d | resources none → Project Manager; baseline start 2011-04-15 12:00 → 2011-04-15; baseline finish 2011-04-15 13:00 → 2011-04-15 |
| 13 | Submit Project Plan & Costs to Management | 2025-05-01 13:00 → 2025-04-25 (-6d) | 2025-05-02 12:00 → 2025-04-28 (-4d) |  | -1.29d → 0d | resources none → Project Manager; Management; baseline start 2011-04-15 14:00 → 2011-04-15; baseline finish 2011-04-15 15:00 → 2011-04-15 |
| 14 | Management Approval Received | 2025-05-02 12:00 → 2025-04-28 (-4d) | 2025-05-02 12:00 → 2025-04-28 (-4d) |  | -1.29d → 0d | baseline start 2011-04-15 15:00 → 2011-04-15; baseline finish 2011-04-15 15:00 → 2011-04-15 |
| 15 | **Refit Office** | 2025-05-02 13:00 → 2025-04-28 (-4d) | 2025-05-26 11:00 → 2025-05-28 (+2d) | 15.86d → 22.5d | -1.79d → 0d | baseline start 2011-04-15 15:00 → 2011-04-15; baseline finish 2011-05-11 17:00 → 2011-05-11 |
| 16 | Appoint Resources | 2025-05-02 13:00 → 2025-04-28 (-4d) | 2025-05-05 12:00 → 2025-04-29 (-6d) |  | -1.29d → 0d | resources none → Project Manager; baseline start 2011-04-15 15:00 → 2011-04-15; baseline finish 2011-04-15 17:00 → 2011-04-15 |
| 17 | Staff Briefing | 2025-05-05 13:00 → 2025-04-29 (-6d) | 2025-05-06 12:00 → 2025-04-30 (-6d) |  | -1.29d → 0d | resources none → Project Manager; Staff [700%]; baseline start 2011-04-18 09:00 → 2011-04-18; baseline finish 2011-04-18 10:00 → 2011-04-18 |
| 18 | **Fit-Out Consultations** | 2025-05-06 13:00 → 2025-04-30 (-6d) | 2025-05-07 11:30 → 2025-05-06 (-1d) | 0.93d → 4d | -1.29d → 0d | baseline start 2011-04-18 10:00 → 2011-04-18; baseline finish 2011-04-19 09:30 → 2011-04-19 |
| 19 | Office Space / Structure Plan | 2025-05-06 13:00 → 2025-04-30 (-6d) | 2025-05-06 16:30 → 2025-05-01 (-5d) | 0.5d → 1d | -1.29d → 0d | resources none → Fit-out Consultant; Project Manager; baseline start 2011-04-18 10:00 → 2011-04-18; baseline finish 2011-04-18 14:30 → 2011-04-18 |
| 20 | Select & Order Carpet | 2025-05-06 16:30 → 2025-05-01 (-5d) | 2025-05-07 09:30 → 2025-05-02 (-5d) | 1h → 1d | -1.29d → 0d | resources none → Fit-out Consultant; Project Manager; baseline start 2011-04-18 14:30 → 2011-04-18; baseline finish 2011-04-18 15:30 → 2011-04-18 |
| 21 | Select & Order Paint | 2025-05-07 09:30 → 2025-05-02 (-5d) | 2025-05-07 10:30 → 2025-05-05 (-2d) | 1h → 1d | -1.29d → 0d | resources none → Fit-out Consultant; Project Manager; baseline start 2011-04-18 15:30 → 2011-04-18; baseline finish 2011-04-18 16:30 → 2011-04-18 |
| 22 | Select & Order Office Furniture | 2025-05-07 10:30 → 2025-05-05 (-2d) | 2025-05-07 11:30 → 2025-05-06 (-1d) | 1h → 1d | -1.29d → 0d | resources none → Fit-out Consultant; Project Manager; baseline start 2011-04-18 16:30 → 2011-04-18; baseline finish 2011-04-19 09:30 → 2011-04-19 |
| 23 | **Telecommuncations Consultations** | 2025-05-07 11:30 → 2025-05-06 (-1d) | 2025-05-07 17:00 → 2025-05-07 | 0.64d → 1.5d | -1.29d → 0d | baseline start 2011-04-19 09:30 → 2011-04-19; baseline finish 2011-04-19 15:00 → 2011-04-19 |
| 24 | Design Telephone Access Points Map | 2025-05-07 11:30 → 2025-05-06 (-1d) | 2025-05-07 16:00 → 2025-05-06 (-1d) |  | -1.29d → 0d | resources none → Project Manager; Telecommunications consultant; baseline start 2011-04-19 09:30 → 2011-04-19; baseline finish 2011-04-19 13:00 → 2011-04-19 |
| 25 | Select & Order New PABX | 2025-05-07 16:00 → 2025-05-07 | 2025-05-07 17:00 → 2025-05-07 | 1h → 1d | -1.29d → 0d | resources none → Project Manager; baseline start 2011-04-19 14:00 → 2011-04-19; baseline finish 2011-04-19 15:00 → 2011-04-19 |
| 26 | **IT Networking Consultations** | 2025-05-08 09:00 → 2025-05-08 | 2025-05-16 15:30 → 2025-05-20 (+4d) | 6.79d → 8.5d | -1.29d → 0d | baseline start 2011-04-19 15:00 → 2011-04-19; baseline finish 2011-05-03 12:30 → 2011-05-03 |
| 27 | Design Network Access Points Map | 2025-05-08 09:00 → 2025-05-08 | 2025-05-08 13:30 → 2025-05-08 |  | -1.29d → 0d | resources none → IT Consultant; Project Manager; baseline start 2011-04-19 15:00 → 2011-04-19; baseline finish 2011-04-20 10:30 → 2011-04-20 |
| 28 | Select & Order New PCs | 2025-05-08 13:30 → 2025-05-08 | 2025-05-08 14:30 → 2025-05-09 (+1d) | 1h → 1d | -1.29d → 0d | resources none → Project Manager; baseline start 2011-04-20 10:30 → 2011-04-20; baseline finish 2011-04-20 11:30 → 2011-04-20 |
| 29 | New PCs Arrive | 2025-05-15 14:30 → 2025-05-16 (+1d) | 2025-05-15 15:30 → 2025-05-19 (+4d) | 1h → 1d | -1.29d → 0d | resources none → Project Manager; baseline start 2011-04-29 11:30 → 2011-04-29; baseline finish 2011-04-29 12:30 → 2011-04-29 |
| 30 | Configure SOE on PCs | 2025-05-15 15:30 → 2025-05-19 (+4d) | 2025-05-16 15:30 → 2025-05-20 (+4d) |  | -1.29d → 0d | resources none → IT Consultant; baseline start 2011-04-29 12:30 → 2011-04-29; baseline finish 2011-05-03 12:30 → 2011-05-03 |
| 31 | **Restructure Office** | 2025-05-07 11:30 → 2025-05-07 | 2025-05-26 11:00 → 2025-05-28 (+2d) | 12.93d → 16d | -1.79d → 0.5d | baseline start 2011-04-20 06:00 → 2011-04-20; baseline finish 2011-05-11 17:00 → 2011-05-11 |
| 32 | Erect New Walls | 2025-05-07 11:30 → 2025-05-07 | 2025-05-08 11:30 → 2025-05-09 (+1d) |  | 2.14d → 4d | resources none → Carpenter [200%]; baseline start 2011-04-20 06:00 → 2011-04-20; baseline finish 2011-04-26 07:00 → 2011-04-26 |
| 33 | Gyprock, Plaster & Finish | 2025-05-08 11:30 → 2025-05-09 (+1d) | 2025-05-12 11:30 → 2025-05-13 (+1d) |  | 2.14d → 4d | resources none → Plasterer; baseline start 2011-04-26 07:00 → 2011-04-26; baseline finish 2011-04-30 10:00 → 2011-04-30 |
| 34 | Install Network Points | 2025-05-16 15:30 → 2025-05-20 (+4d) | 2025-05-19 13:30 → 2025-05-21 (+2d) |  | -1.29d → 0d | resources none → IT Consultant; baseline start 2011-05-03 12:30 → 2011-05-03; baseline finish 2011-05-04 10:30 → 2011-05-04 |
| 35 | Install Phone Connections | 2025-05-16 15:30 → 2025-05-20 (+4d) | 2025-05-19 11:00 → 2025-05-20 (+1d) |  | -1.29d → 0d | resources none → Telecommunications consultant; baseline start 2011-05-03 12:30 → 2011-05-03; baseline finish 2011-05-03 17:00 → 2011-05-03 |
| 36 | Re-Paint | 2025-05-19 11:00 → 2025-05-21 (+2d) | 2025-05-20 11:00 → 2025-05-23 (+3d) |  | -1.29d → 0d | resources none → Paint [100 Litre]; Painter; baseline start 2011-05-04 06:00 → 2011-05-04; baseline finish 2011-05-06 07:00 → 2011-05-06 |
| 37 | Carpet | 2025-05-21 11:00 → 2025-05-24 (+3d) | 2025-05-22 11:00 → 2025-05-24 (+2d) |  | -1.79d → 0d | resources none → Carpet [100 Lin Metre]; Carpet Contractor; baseline start 2011-05-07 07:00 → 2011-05-07; baseline finish 2011-05-07 15:00 → 2011-05-07 |
| 38 | Install New Furniture | 2025-05-22 11:00 → 2025-05-26 (+4d) | 2025-05-23 11:00 → 2025-05-28 (+5d) |  | -1.79d → 0d | resources none → Labourer; baseline start 2011-05-09 06:00 → 2011-05-09; baseline finish 2011-05-11 07:00 → 2011-05-11 |
| 39 | Install New PCs | 2025-05-23 11:00 → 2025-05-28 (+5d) | 2025-05-26 11:00 → 2025-05-28 (+2d) |  | -1.79d → 0.5d | resources none → IT Consultant; baseline start 2011-05-11 09:00 → 2011-05-11; baseline finish 2011-05-11 17:00 → 2011-05-11 |
| 40 | Refit Office Complete | 2025-05-26 11:00 → 2025-05-28 (+2d) | 2025-05-26 11:00 → 2025-05-28 (+2d) |  | -1.79d → 0.5d | baseline start 2011-05-11 17:00 → 2011-05-11; baseline finish 2011-05-11 17:00 → 2011-05-11 |
| 41 | **Office Move** | 2025-05-15 15:30 → 2025-05-19 (+4d) | 2025-05-28 15:30 → 2025-05-31 (+3d) | 9d → 9.5d | -1.79d → 0d | baseline start 2011-04-29 12:30 → 2011-04-29; baseline finish 2011-05-16 17:00 → 2011-05-16 |
| 42 | Order packing boxes | 2025-05-15 15:30 → 2025-05-19 (+4d) | 2025-05-15 16:30 → 2025-05-19 (+4d) |  | 4.57d → 7.86d | resources none → Project Manager; baseline start 2011-04-29 12:30 → 2011-04-29; baseline finish 2011-04-29 14:30 → 2011-04-29 |
| 43 | Staff Pack | 2025-05-26 11:00 → 2025-05-29 (+3d) | 2025-05-26 15:30 → 2025-05-29 (+3d) |  | -1.79d → 0.5d | resources none → Project Manager; Staff [2000%]; baseline start 2011-05-12 09:00 → 2011-05-12; baseline finish 2011-05-12 12:30 → 2011-05-12 |
| 44 | Staff Move | 2025-05-26 15:30 → 2025-05-29 (+3d) | 2025-05-28 15:30 → 2025-05-31 (+3d) |  | -1.79d → 0d | resources none → Staff [2000%]; Labourer; baseline start 2011-05-12 12:30 → 2011-05-12; baseline finish 2011-05-14 11:00 → 2011-05-14 |
| 45 | Office Move Complete | 2025-05-27 08:00 → 2025-05-31 (+4d) | 2025-05-27 08:00 → 2025-05-31 (+4d) |  | -1.79d → 0d | constraint must finish on 2025-05-27 08:00 → none; baseline start 2011-05-16 17:00 → 2011-05-16; baseline finish 2011-05-16 17:00 → 2011-05-16 |

## Version 13 (saved 2024-12-19, file Timeline.mpp)

Last finish 2025-05-31 → 2025-06-09 (+9d).

Changed:

| ID | Task | Start | Finish | Duration | Total float | Predecessors | Other |
| --- | --- | --- | --- | --- | --- | --- | --- |
| 1 | **Planning & Research** |  | 2025-04-22 → 2025-05-01 (+9d) | 12d → 15.5d |  |  | baseline start 2011-04-04 → none; baseline finish 2011-04-14 → none |
| 2 | Develop Requirements Documentation |  |  |  |  |  | resources Project Manager → none; baseline start 2011-04-04 → none; baseline finish 2011-04-04 → none |
| 3 | Fit-Out Consultant Research |  | 2025-04-08 → 2025-04-09 (+1d) | 1d → 2d |  |  | resources Project Manager → none; baseline start 2011-04-05 → none; baseline finish 2011-04-05 → none |
| 4 | Telecommunications Consultant Research | 2025-04-09 → 2025-04-10 (+1d) | 2025-04-09 → 2025-04-11 (+2d) | 1d → 2d |  |  | resources Project Manager → none; baseline start 2011-04-05 → none; baseline finish 2011-04-05 → none |
| 5 | IT Network Contractor Research | 2025-04-10 → 2025-04-14 (+4d) | 2025-04-10 → 2025-04-15 (+5d) | 1d → 2d |  |  | resources Project Manager → none; baseline start 2011-04-06 → none; baseline finish 2011-04-06 → none |
| 6 | Building Contractors Research | 2025-04-11 → 2025-04-16 (+5d) | 2025-04-11 → 2025-04-17 (+6d) | 1d → 2d |  |  | resources Project Manager → none; baseline start 2011-04-06 → none; baseline finish 2011-04-06 → none |
| 7 | Submit Requirements to Resources & Request Quotes | 2025-04-14 → 2025-04-22 (+8d) | 2025-04-14 → 2025-04-22 (+8d) |  |  |  | resources Project Manager → none; baseline start 2011-04-07 → none; baseline finish 2011-04-07 → none |
| 8 | Quotes Received | 2025-04-22 → 2025-05-01 (+9d) | 2025-04-22 → 2025-05-01 (+9d) | 1d → 0.5d |  |  | resources Project Manager → none; baseline start 2011-04-14 → none; baseline finish 2011-04-14 → none |
| 9 | Planning & Research Complete | 2025-04-22 → 2025-05-01 (+9d) | 2025-04-22 → 2025-05-01 (+9d) |  |  |  | baseline start 2011-04-14 → none; baseline finish 2011-04-14 → none |
| 10 | **Management Approval** | 2025-04-23 → 2025-05-01 (+8d) | 2025-04-28 → 2025-05-08 (+10d) | 3.5d → 4.14d |  |  | baseline start 2011-04-14 → none; baseline finish 2011-04-15 → none |
| 11 | Consolidate Quotes and develop proposal | 2025-04-23 → 2025-05-01 (+8d) | 2025-04-24 → 2025-05-06 (+12d) | 1.5d → 2d |  |  | resources Project Manager → none; baseline start 2011-04-14 → none; baseline finish 2011-04-15 → none |
| 12 | Develop Project Plan & Durations | 2025-04-24 → 2025-05-06 (+12d) | 2025-04-25 → 2025-05-08 (+13d) | 1d → 2d |  |  | resources Project Manager → none; baseline start 2011-04-15 → none; baseline finish 2011-04-15 → none |
| 13 | Submit Project Plan & Costs to Management | 2025-04-25 → 2025-05-08 (+13d) | 2025-04-28 → 2025-05-08 (+10d) | 1d → 1h |  |  | resources Project Manager; Management → none; baseline start 2011-04-15 → none; baseline finish 2011-04-15 → none |
| 14 | Management Approval Received | 2025-04-28 → 2025-05-08 (+10d) | 2025-04-28 → 2025-05-08 (+10d) |  |  |  | baseline start 2011-04-15 → none; baseline finish 2011-04-15 → none |
| 15 | **Refit Office** | 2025-04-28 → 2025-05-08 (+10d) | 2025-05-28 → 2025-06-05 (+8d) | 22.5d → 20.07d |  |  | baseline start 2011-04-15 → none; baseline finish 2011-05-11 → none |
| 16 | Appoint Resources | 2025-04-28 → 2025-05-08 (+10d) | 2025-04-29 → 2025-05-09 (+10d) |  |  |  | resources Project Manager → none; baseline start 2011-04-15 → none; baseline finish 2011-04-15 → none |
| 17 | Staff Briefing | 2025-04-29 → 2025-05-09 (+10d) | 2025-04-30 → 2025-05-09 (+9d) | 1d → 1h |  |  | resources Project Manager; Staff [700%] → none; baseline start 2011-04-18 → none; baseline finish 2011-04-18 → none |
| 18 | **Fit-Out Consultations** | 2025-04-30 → 2025-05-09 (+9d) | 2025-05-06 → 2025-05-14 (+8d) | 4d → 2.5d |  |  | baseline start 2011-04-18 → none; baseline finish 2011-04-19 → none |
| 19 | Office Space / Structure Plan | 2025-04-30 → 2025-05-09 (+9d) | 2025-05-01 → 2025-05-12 (+11d) |  |  |  | resources Fit-out Consultant; Project Manager → none; baseline start 2011-04-18 → none; baseline finish 2011-04-18 → none |
| 20 | Select & Order Carpet | 2025-05-01 → 2025-05-12 (+11d) | 2025-05-02 → 2025-05-13 (+11d) | 1d → 0.5d |  |  | resources Fit-out Consultant; Project Manager → none; baseline start 2011-04-18 → none; baseline finish 2011-04-18 → none |
| 21 | Select & Order Paint | 2025-05-02 → 2025-05-13 (+11d) | 2025-05-05 → 2025-05-13 (+8d) | 1d → 0.5d |  |  | resources Fit-out Consultant; Project Manager → none; baseline start 2011-04-18 → none; baseline finish 2011-04-18 → none |
| 22 | Select & Order Office Furniture | 2025-05-05 → 2025-05-13 (+8d) | 2025-05-06 → 2025-05-14 (+8d) | 1d → 0.5d |  |  | resources Fit-out Consultant; Project Manager → none; baseline start 2011-04-18 → none; baseline finish 2011-04-19 → none |
| 23 | **Telecommuncations Consultations** | 2025-05-06 → 2025-05-14 (+8d) | 2025-05-07 → 2025-05-16 (+9d) | 1.5d → 2d | 0d → 16.43d |  | baseline start 2011-04-19 → none; baseline finish 2011-04-19 → none |
| 24 | Design Telephone Access Points Map | 2025-05-06 → 2025-05-14 (+8d) | 2025-05-06 → 2025-05-15 (+9d) | 0.5d → 1d | 0d → 16.43d |  | resources Project Manager; Telecommunications consultant → none; baseline start 2011-04-19 → none; baseline finish 2011-04-19 → none |
| 25 | Select & Order New PABX | 2025-05-07 → 2025-05-15 (+8d) | 2025-05-07 → 2025-05-16 (+9d) |  | 0d → 16.43d |  | resources Project Manager → none; baseline start 2011-04-19 → none; baseline finish 2011-04-19 → none |
| 26 | **IT Networking Consultations** | 2025-05-08 → 2025-05-14 (+6d) | 2025-05-20 → 2025-05-26 (+6d) | 8.5d → 8.14d |  |  | baseline start 2011-04-19 → none; baseline finish 2011-05-03 → none |
| 27 | Design Network Access Points Map | 2025-05-08 → 2025-05-14 (+6d) | 2025-05-08 → 2025-05-15 (+7d) | 0.5d → 1d |  | 22, 25 → 22 | resources IT Consultant; Project Manager → none; baseline start 2011-04-19 → none; baseline finish 2011-04-20 → none |
| 28 | Select & Order New PCs | 2025-05-08 → 2025-05-15 (+7d) | 2025-05-09 → 2025-05-16 (+7d) |  |  |  | resources Project Manager → none; baseline start 2011-04-20 → none; baseline finish 2011-04-20 → none |
| 29 | New PCs Arrive | 2025-05-16 → 2025-05-23 (+7d) | 2025-05-19 → 2025-05-23 (+4d) | 1d → 1h |  |  | resources Project Manager → none; baseline start 2011-04-29 → none; baseline finish 2011-04-29 → none |
| 30 | Configure SOE on PCs | 2025-05-19 → 2025-05-23 (+4d) | 2025-05-20 → 2025-05-26 (+6d) |  |  |  | resources IT Consultant → none; baseline start 2011-04-29 → none; baseline finish 2011-05-03 → none |
| 31 | **Restructure Office** | 2025-05-07 → 2025-05-26 (+19d) | 2025-05-28 → 2025-06-05 (+8d) | 16d → 8.29d | 0.5d → 0d |  | baseline start 2011-04-20 → none; baseline finish 2011-05-11 → none |
| 32 | Erect New Walls | 2025-05-07 → 2025-05-26 (+19d) | 2025-05-09 → 2025-05-27 (+18d) |  | 4d → 0d | 22 → 30 | resources Carpenter [200%] → none; baseline start 2011-04-20 → none; baseline finish 2011-04-26 → none |
| 33 | Gyprock, Plaster & Finish | 2025-05-09 → 2025-05-27 (+18d) | 2025-05-13 → 2025-05-28 (+15d) | 14h → 7h | 4d → 0d |  | resources Plasterer → none; baseline start 2011-04-26 → none; baseline finish 2011-04-30 → none |
| 34 | Install Network Points | 2025-05-20 → 2025-05-29 (+9d) | 2025-05-21 → 2025-05-30 (+9d) |  |  | 33FS+1d, 30 → 33FS+1d | resources IT Consultant → none; baseline start 2011-05-03 → none; baseline finish 2011-05-04 → none |
| 35 | Install Phone Connections | 2025-05-20 → 2025-05-29 (+9d) | 2025-05-20 → 2025-05-29 (+9d) | 0.5d → 2h |  |  | resources Telecommunications consultant → none; baseline start 2011-05-03 → none; baseline finish 2011-05-03 → none |
| 36 | Re-Paint | 2025-05-21 → 2025-05-29 (+8d) | 2025-05-23 → 2025-05-30 (+7d) |  |  |  | resources Paint [100 Litre]; Painter → none; baseline start 2011-05-04 → none; baseline finish 2011-05-06 → none |
| 37 | Carpet | 2025-05-24 → 2025-06-02 (+9d) | 2025-05-24 → 2025-06-03 (+10d) |  |  | 36FS+1ed → 36FS+1d | resources Carpet [100 Lin Metre]; Carpet Contractor → none; baseline start 2011-05-07 → none; baseline finish 2011-05-07 → none |
| 38 | Install New Furniture | 2025-05-26 → 2025-06-03 (+8d) | 2025-05-28 → 2025-06-04 (+7d) |  |  |  | resources Labourer → none; baseline start 2011-05-09 → none; baseline finish 2011-05-11 → none |
| 39 | Install New PCs | 2025-05-28 → 2025-06-04 (+7d) | 2025-05-28 → 2025-06-05 (+8d) |  | 0.5d → 0d |  | resources IT Consultant → none; baseline start 2011-05-11 → none; baseline finish 2011-05-11 → none |
| 40 | Refit Office Complete | 2025-05-28 → 2025-06-05 (+8d) | 2025-05-28 → 2025-06-05 (+8d) |  | 0.5d → 0d |  | baseline start 2011-05-11 → none; baseline finish 2011-05-11 → none |
| 41 | **Office Move** | 2025-05-19 → 2025-06-04 (+16d) | 2025-05-31 → 2025-06-09 (+9d) | 9.5d → 3d |  |  | baseline start 2011-04-29 → none; baseline finish 2011-05-16 → none |
| 42 | Order packing boxes | 2025-05-19 → 2025-06-04 (+16d) | 2025-05-19 → 2025-06-04 (+16d) |  | 7.86d → 2.86d | 29 → 38 | resources Project Manager → none; baseline start 2011-04-29 → none; baseline finish 2011-04-29 → none |
| 43 | Staff Pack | 2025-05-29 → 2025-06-05 (+7d) | 2025-05-29 → 2025-06-06 (+8d) | 0.5d → 1d | 0.5d → 0d | 40, 42 → 40 | resources Project Manager; Staff [2000%] → none; baseline start 2011-05-12 → none; baseline finish 2011-05-12 → none |
| 44 | Staff Move | 2025-05-29 → 2025-06-06 (+8d) | 2025-05-31 → 2025-06-09 (+9d) | 2d → 1d |  |  | resources Staff [2000%]; Labourer → none; baseline start 2011-05-12 → none; baseline finish 2011-05-14 → none |
| 45 | Office Move Complete | 2025-05-31 → 2025-06-09 (+9d) | 2025-05-31 → 2025-06-09 (+9d) |  |  |  | baseline start 2011-05-16 → none; baseline finish 2011-05-16 → none |
